# NGAO Design v7

Schedule from MS Project, 2005-10-03 to 2010-03-22, costs in $.
CARA

## Calendars

- Standard: Mon-Fri 08:00-12:00, 13:00-17:00; Sat-Sun off.

## Resources

| Resource | Group | Rate |
| --- | --- | --- |
| Dekany | COO |  |
| Gavel | UCO | 120 |
| Max | UCO |  |
| Wizinowich | WMKO | 104 |
| Adkins | KO | 104 |
| McGrath | UCO | 42 |
| Tyau | WMKO | 35 |
| Le Mignant | WMKO | 70 |
| Bell | KO | 69.56 |
| Chin | WMKO | 70 |
| Kupke | UCO | 62 |
| Lockwood | UCO | 109 |
| Neyman | WMKO | 70 |
| Reinig | UCO | 62 |
| Velur | COO | 96 |
| Free | WMKO |  |
| Student |  | 40 |
| Johansson | WMKO | 70 |
| Wetherell | WMKO | 70 |
| Medeiros | WMKO | 70 |
| Nance | WMKO | 70 |
| Summers | WMKO | 70 |
| Mogensen | WMKO | 47 |
| Bouchez | KO | 96.14 |
| Kissner | WMKO | 47 |
| Chock | WMKO | 70 |
| Panteleev | WMKO | 70 |
| Morrison | WMKO | 70 |
| Macintosh | UCO | 105 |
| Electrical Engineer / Programmer | UCO | 62 |
| Hale | COO | 96 |
| Grace |  | 70 |
| Doyle | WMKO | 47 |
| Contract Administrator | WMKO | 70 |
| Brown | COO | 70 |
| Johnson |  |  |
| COO ME |  |  |
| Stomski |  |  |
| Tolleth |  |  |
| Lu |  |  |

## Schedule

| ID | WBS | Task | Duration | Start | Finish | Total slack | Constraint | Resources | Work | Cost |
| --- | --- | --- | --- | --- | --- | --- | --- | --- | --- | --- |
| 1 | 1 | **NGAO Design** | 1166d? | 2005-10-03 | 2010-03-22 | 0d |  |  | 36485h | 2,435,375.19 |
| 2 | 1.1 | Proposal | 195d? | 2005-10-03 | 2006-06-30 | 971d | finish no earlier than 2006-06-30 |  |  |  |
| 3 | 1.2 | System Design | 413d? | 2006-10-02 | 2008-04-30 | 493d | finish no earlier than 2008-04-30 |  |  |  |
| 4 | 1.3 | **Preliminary Design** | 515d? | 2008-04-01 | 2010-03-22 | 0d |  |  | 36485h | 2,435,375.19 |
| 5 | 1.3.1 | Reserved | 1d? | 2008-05-01 | 2008-05-01 | 492d | start no earlier than 2008-05-01 |  |  |  |
| 6 | 1.3.2 | **PD Phase Management** | 515d? | 2008-04-01 | 2010-03-22 | 0d |  |  | 9634h | 680,741.58 |
| 7 | 1.3.2.1 | **Planning** | 479d? | 2008-04-01 | 2010-01-29 | 36d |  |  | 1932h | 176,736.12 |
| 8 | 1.3.2.1.1 | **Replans (PD phase)** | 309d? | 2008-04-01 | 2009-06-05 | 206d |  |  | 386h | 39,582.88 |
| 9 | 1.3.2.1.1.1 | **Replan based on SDR** | 102d? | 2008-04-01 | 2008-08-20 | 413d |  |  | 70h | 7,328.84 |
| 10 | 1.3.2.1.1.1.1 | Response to SDR Report | 3d? | 2008-04-01 | 2008-05-05 | 490d |  | Wizinowich [33.3%]; Dekany [8.3%]; Gavel [8.3%] | 12h | 1,264.28 |
| 11 | 1.3.2.1.1.1.2 | Response to SSC Report | 11d? | 2008-04-01 | 2008-06-16 | 460d |  | Wizinowich [4.5%] | 4h | 416 |
| 12 | 1.3.2.1.1.1.3 | Replan KAON | 78d? | 2008-04-01 | 2008-08-20 | 413d |  | Wizinowich [3.8%]; Dekany [0.6%]; Gavel [0.6%] | 32h | 3,360.56 |
| 13 | 1.3.2.1.1.1.4 | Replan MS Project Plan | 26d? | 2008-04-01 | 2008-08-20 | 413d |  | Wizinowich [10.6%] | 22h | 2,288 |
| 14 | 1.3.2.1.1.2 | **Phased Implementation Planning** | 130d? | 2008-05-05 | 2008-10-31 | 361d |  |  | 156h | 16,086.44 |
| 15 | 1.3.2.1.1.2.1 | Phased Implementation - Plan | 27d? | 2008-05-05 | 2008-06-10 | 464d | start no earlier than 2008-05-05 | Wizinowich [7.4%]; Dekany [0.9%]; Gavel [0.9%] | 20h | 2,096.28 |
| 16 | 1.3.2.1.1.2.2 | Phased Implementation - SDR Proposed System Baseline | 98d? | 2008-06-02 | 2008-10-15 | 373d | finish no earlier than 2008-10-15 | Wizinowich [2%] | 16h | 1,664 |
| 17 | 1.3.2.1.1.2.3 | Phased Implementation - SDR Proposed System Phasing | 98d? | 2008-06-02 | 2008-10-15 | 373d | finish no earlier than 2008-10-15 | Wizinowich [2%] | 16h | 1,664 |
| 18 | 1.3.2.1.1.2.4 | Phased Implementation - Keck AO Upgrade Option | 43d? | 2008-08-18 | 2008-10-15 | 373d | start no earlier than 2008-08-18 | Wizinowich [2.3%] | 8h | 832 |
| 19 | 1.3.2.1.1.2.5 | Phased Implementation - Descope Options | 43d? | 2008-08-18 | 2008-10-15 | 373d | start no earlier than 2008-08-18 | Wizinowich [4.7%] | 16h | 1,664 |
| 20 | 1.3.2.1.1.2.6 | Phased Implementation - Cost Savings Options | 43d? | 2008-06-02 | 2008-10-15 | 373d | start no earlier than 2008-06-02 | Wizinowich [2.3%]; Gavel [2.3%] | 16h | 1,792 |
| 21 | 1.3.2.1.1.2.7 | Phased Implementation - Wavefront Error Budgets | 30d? | 2008-07-21 | 2008-08-29 | 406d | start no earlier than 2008-07-21 | Dekany [16.7%] | 40h | 3,845.6 |
| 22 | 1.3.2.1.1.2.8 | Phased Implementation - Report | 110d? | 2008-06-02 | 2008-10-31 | 361d | start no earlier than 2008-06-02 | Wizinowich [1.8%]; Dekany [0.5%]; Gavel [0.5%] | 24h | 2,528.56 |
| 23 | 1.3.2.1.1.3 | Replan 1 | 10d? | 2008-10-27 | 2008-11-07 | 356d | finish no earlier than 2008-11-07 | Dekany [20%]; Gavel [20%]; Wizinowich [45%]; Lockwood [1.2%]; Velur [3.8%]; Neyman [1.2%]; Le Mignant [1.2%]; Johansson [2.5%]; Reinig [2.5%]; Bell [1.2%]; Wetherell [1.2%] | 80h | 8,142.8 |
| 24 | 1.3.2.1.1.4 | Replan 2 | 10d? | 2009-05-25 | 2009-06-05 | 206d | finish no earlier than 2009-06-05 | Dekany [20%]; Gavel [20%]; Wizinowich [40%]; Wetherell [2.5%]; Bell [1.2%]; Reinig [3.8%]; Johansson [2.5%]; Le Mignant [2.5%]; Neyman [1.2%]; Velur [5%]; Lockwood [1.2%] | 80h | 8,024.8 |

Notes:
- 6: PW
- 7: PW
- 8: PW
- 9: PW
- 14: PW
- 23: PW
- 24: PW

| ID | WBS | Task | Type | Duration | Start | Finish | Total slack | Constraint | Resources | Work | Cost |
| --- | --- | --- | --- | --- | --- | --- | --- | --- | --- | --- | --- |
| 25 | 1.3.2.1.2 | **WMKO FY Plans** |  | 280d? | 2008-05-05 | 2009-05-29 | 211d |  |  | 40h | 4,160 |
| 26 | 1.3.2.1.2.1 | Support WMKO FY09 Planning |  | 20d? | 2008-05-05 | 2008-05-30 | 471d | start no earlier than 2008-05-05 | Wizinowich [6.2%] | 10h | 1,040 |
| 27 | 1.3.2.1.2.2 | Support WMKO FY10 Planning |  | 85d? | 2009-02-02 | 2009-05-29 | 211d | start no earlier than 2009-02-02 | Wizinowich [4.4%] | 30h | 3,120 |
| 28 | 1.3.2.1.3 | **Cost Estimation** |  | 449d? | 2008-04-01 | 2009-12-18 | 66d |  |  | 576h | 46,806.32 |
| 29 | 1.3.2.1.3.1 | NFIRAOS Cost Comparison |  | 33d? | 2008-04-01 | 2008-09-30 | 384d |  | Dekany [18.2%]; Neyman [3%]; Gavel [3%]; Velur [3%]; Johansson [3%]; Wizinowich [6.1%] | 96h | 9,126.72 |
| 30 | 1.3.2.1.3.2 | Cost Estimation for SEMP |  | 20d? | 2009-11-23 | 2009-12-18 | 66d | start no earlier than 2009-11-23 | Dekany [37.5%]; Gavel [25%]; Max [6.2%]; Wizinowich [37.5%]; Nance [12.5%]; Neyman [18.8%]; Le Mignant [18.8%]; Bell [12.5%]; Johansson [25%]; Wetherell [9.4%]; Reinig [12.5%]; Kupke [9.4%]; Lockwood [12.5%]; Velur [9.4%]; Brown [25%]; COO ME [18.8%]; Hale [9.4%] | 480h | 37,679.6 |
| 31 | 1.3.2.1.4 | **Systems Engineering Management Plan** |  | 218d? | 2009-04-01 | 2010-01-29 | 36d |  |  | 930h | 86,186.92 |
| 32 | 1.3.2.1.4.1 | **Project Plan** |  | 50d? | 2009-11-02 | 2010-01-08 | 51d |  |  | 530h | 48,091 |
| 33 | 1.3.2.1.4.1.1 | PBS, WBS & Task Definition |  | 15d? | 2009-11-02 | 2009-11-20 | 86d | start no earlier than 2009-11-02 | Dekany [33.3%]; Gavel [33.3%]; Wizinowich [33.3%]; Max [8.3%]; Reinig [12.5%]; Wetherell [8.3%]; Johansson [12.5%]; Le Mignant [12.5%]; Neyman [8.3%]; Bell [8.3%]; Velur [33.3%]; Lockwood [12.5%] | 260h | 23,406.2 |
| 34 | 1.3.2.1.4.1.2 | Full Schedule (MS Project Plan) |  | 25d? | 2009-12-07 | 2010-01-08 | 51d | start no earlier than 2009-12-07 | Wizinowich [30%]; Dekany [15%]; Gavel [15%]; Velur [20%]; Bell [5%]; Neyman [7.5%]; Le Mignant [10%]; Johansson [10%]; Wetherell [5%]; Lockwood [7.5%]; Reinig [10%] | 270h | 24,684.8 |
| 35 | 1.3.2.1.4.2 | **Detailed Design Phase Plan** |  | 177d? | 2009-04-01 | 2009-12-03 | 77d |  |  | 320h | 30,124.56 |
| 36 | 1.3.2.1.4.2.1 | Detailed Design Plan v1 (FY10 planning) |  | 33d? | 2009-04-01 | 2009-05-15 | 221d | finish no earlier than 2009-05-15 | Wizinowich [15.2%] | 40h | 4,160 |
| 37 | 1.3.2.1.4.2.2 | Detailed Design Plan v2 (TSIP proposal) |  | 18d? | 2009-07-15 | 2009-08-07 | 161d | start no earlier than 2009-07-15 | Wizinowich [22.2%]; Dekany [27.8%]; Gavel [27.8%] | 40h | 4,192.56 |
| 38 | 1.3.2.1.4.2.3 | Detailed Design Plan Final Version |  | 19d? | 2009-11-09 | 2009-12-03 | 77d | start no earlier than 2009-11-09 | Wizinowich [46.1%]; Dekany [19.7%]; Gavel [19.7%]; Max [6.6%]; Lockwood [65.8%]; Nance; Bell; Neyman; Le Mignant; Johansson; Reinig; Velur | 240h | 21,772 |
| 39 | 1.3.2.1.4.3 | SEMP Document |  | 15d? | 2010-01-11 | 2010-01-29 | 36d | start no earlier than 2010-01-11 | Wizinowich [30%]; Dekany [20%]; Gavel [13.3%]; Max [3.3%] | 80h | 7,971.36 |
| 40 | 1.3.2.2 | **Project Management & Meetings** |  | 477d? | 2008-05-01 | 2010-02-26 | 16d |  |  | 2294h | 191,853 |
| 41 | 1.3.2.2.1 | **Senior Management Committee** |  | 477d? | 2008-05-01 | 2010-02-26 | 16d |  |  | 624h | 55,717 |
| 42 | 1.3.2.2.1.1 | Senior Management Activities |  | 477d? | 2008-05-01 | 2010-02-26 | 16d | finish no earlier than 2010-02-26 | Dekany [2%]; Gavel [2%]; Max [0.7%]; Wizinowich [3.3%] | 300h | 29,210.5 |
| 43 | 1.3.2.2.1.2 | Senior Management Telecons |  | 477d? | 2008-05-01 | 2010-02-26 | 16d | finish no earlier than 2010-02-26 | Dekany [2%]; Gavel [2%]; Max [2%]; Wizinowich [2%] | 300h | 24,010.5 |
| 44 | 1.3.2.2.1.3 | Implement Full-Time Systems Engineer |  | 87d? | 2009-10-01 | 2010-01-29 | 36d | finish no earlier than 2010-01-29 | Wizinowich [3.4%] | 24h | 2,496 |
| 45 | 1.3.2.2.2 | **Team Meetings** |  | 477d? | 2008-05-01 | 2010-02-26 | 16d |  |  | 1670h | 136,136 |
| 46 | 1.3.2.2.2.1 | Meeting Participation |  | 477d? | 2008-05-01 | 2010-02-26 | 16d | start no earlier than 2008-05-01 | Dekany [4.2%]; Gavel [4.2%]; Wizinowich [4.2%]; Le Mignant [3.9%]; Johansson [4.3%]; Neyman [3.9%]; Bell [2.1%]; Adkins [2.4%]; Kupke [2.4%]; Lockwood [2.4%]; Velur [3.9%]; Wetherell [3.3%]; Reinig [2.6%]; COO ME [2.6%] | 1670h | 136,136 |
| 47 | 1.3.2.2.2.2 | Team Meeting #1 (CIT - 1 day) | milestone | 0d | 2008-05-01 | 2008-05-01 | 493d | start no earlier than 2008-05-01 |  |  |  |
| 48 | 1.3.2.2.2.3 | Team Meeting #2 (telecon) | milestone | 0d | 2008-06-13 | 2008-06-13 | 462d | start no earlier than 2008-06-13 |  |  |  |
| 49 | 1.3.2.2.2.4 | Team Meeting #3 (telecon) | milestone | 0d? | 2008-07-11 | 2008-07-11 | 442d | start no earlier than 2008-07-11 |  |  |  |
| 50 | 1.3.2.2.2.5 | Team Meeting #4 (telecon) | milestone | 0d | 2008-08-15 | 2008-08-15 | 417d | start no earlier than 2008-08-15 |  |  |  |
| 51 | 1.3.2.2.2.6 | Team Meeting #5 (UC - 3 days) | milestone | 0d? | 2008-09-18 | 2008-09-18 | 392d | finish no earlier than 2008-09-18 |  |  |  |
| 52 | 1.3.2.2.2.7 | Team Meeting #6 (telecon) | milestone | 0d | 2008-10-17 | 2008-10-17 | 372d | start no earlier than 2008-10-17 |  |  |  |
| 53 | 1.3.2.2.2.8 | Team Meeting #7 (telecon) | milestone | 0d | 2008-11-14 | 2008-11-14 | 352d | start no earlier than 2008-11-14 |  |  |  |
| 54 | 1.3.2.2.2.9 | Team Meeting #8 (telecon) | milestone | 0d | 2008-12-12 | 2008-12-12 | 332d | start no earlier than 2008-12-12 |  |  |  |
| 55 | 1.3.2.2.2.10 | Team Meeting #9 (telecon) | milestone | 0d | 2009-01-16 | 2009-01-16 | 306d | finish no earlier than 2009-01-16 |  |  |  |
| 56 | 1.3.2.2.2.11 | Team Meeting #10 (WMKO - 4 days) | milestone | 0d | 2009-02-10 | 2009-02-10 | 290d | start no earlier than 2009-02-10 |  |  |  |
| 57 | 1.3.2.2.2.12 | Team Meeting #11 (telecon) | milestone | 0d | 2009-03-13 | 2009-03-13 | 267d | start no earlier than 2009-03-13 |  |  |  |
| 58 | 1.3.2.2.2.13 | Team Meeting #12 (telecon) | milestone | 0d | 2009-04-17 | 2009-04-17 | 242d | start no earlier than 2009-04-17 |  |  |  |
| 59 | 1.3.2.2.2.14 | Team Meeting #13 (telecon) | milestone | 0d | 2009-05-15 | 2009-05-15 | 221d | finish no earlier than 2009-05-15 |  |  |  |
| 60 | 1.3.2.2.2.15 | Team Meeting #14 (telecon) | milestone | 0d | 2009-06-12 | 2009-06-12 | 201d | finish no earlier than 2009-06-12 |  |  |  |
| 61 | 1.3.2.2.2.16 | Team Meeting #15 (telecon) | milestone | 0d | 2009-07-17 | 2009-07-17 | 177d | start no earlier than 2009-07-17 |  |  |  |
| 62 | 1.3.2.2.2.17 | Team Meeting #16 (CIT - 3 days)) | milestone | 0d | 2009-08-20 | 2009-08-20 | 152d | finish no earlier than 2009-08-20 |  |  |  |
| 63 | 1.3.2.2.2.18 | Team Meeting #17 (telecon) | milestone | 0d | 2009-09-18 | 2009-09-18 | 132d | start no earlier than 2009-09-18 |  |  |  |
| 64 | 1.3.2.2.2.19 | Team Meeting #18 (telecon) | milestone | 0d | 2009-10-16 | 2009-10-16 | 112d | start no earlier than 2009-10-16 |  |  |  |
| 65 | 1.3.2.2.2.20 | Team Meeting #19 (telecon) | milestone | 0d | 2009-11-13 | 2009-11-13 | 92d | start no earlier than 2009-11-13 |  |  |  |
| 66 | 1.3.2.2.2.21 | Team Meeting #20 (telecon) | milestone | 0d | 2009-12-11 | 2009-12-11 | 72d | start no earlier than 2009-12-11 |  |  |  |
| 67 | 1.3.2.2.2.22 | Team Meeting #21 (telecon) | milestone | 0d | 2010-01-15 | 2010-01-15 | 47d | start no earlier than 2010-01-15 |  |  |  |

Notes:
- 25: PW
- 26: PW
- 27: PW
- 28: RD
- 29: RD
- 30: RD
- 31: PW
- 33: PW
- 34: PW
- 35: PW
- 36: PW
- 37: PW
- 38: PW
- 39: PW
- 40: PW
- 41: PW
- 42: PW
- 43: PW
- 44: PW
- 45: PW

| ID | WBS | Task | Type | Duration | Start | Finish | Total slack | Constraint | Resources | Work | Cost |
| --- | --- | --- | --- | --- | --- | --- | --- | --- | --- | --- | --- |
| 68 | 1.3.2.2.3 | **Director Telecons** |  | 390d | 2008-05-09 | 2009-11-06 | 97d |  |  |  |  |
| 69 | 1.3.2.2.3.1 | Director Telecon #1 | milestone | 0d | 2008-05-09 | 2008-05-09 | 487d | start no earlier than 2008-05-09 |  |  |  |
| 70 | 1.3.2.2.3.2 | Director Telecon #2 | milestone | 0d | 2008-06-09 | 2008-06-09 | 466d | start no earlier than 2008-06-09 |  |  |  |
| 71 | 1.3.2.2.3.3 | Director Telecon #3 | milestone | 0d | 2008-11-07 | 2008-11-07 | 357d | start no earlier than 2008-11-07 |  |  |  |
| 72 | 1.3.2.2.3.4 | Director Telecon #4 | milestone | 0d | 2009-05-08 | 2009-05-08 | 227d | start no earlier than 2009-05-08 |  |  |  |
| 73 | 1.3.2.2.3.5 | Director Telecon #5 | milestone | 0d | 2009-11-06 | 2009-11-06 | 97d | start no earlier than 2009-11-06 |  |  |  |
| 74 | 1.3.2.3 | **Tracking & Reporting** |  | 478d? | 2008-04-30 | 2010-02-26 | 16d |  |  | 869h | 82,625.04 |
| 75 | 1.3.2.3.1 | **Monthly Status Reports** |  | 477d? | 2008-05-01 | 2010-02-26 | 16d |  |  | 546h | 48,333 |
| 76 | 1.3.2.3.1.1 | Monthly Team Status Reports |  | 477d? | 2008-05-01 | 2010-02-26 | 16d | start no earlier than 2008-05-01 | Wizinowich [1%]; Max [0.5%]; Gavel [1%]; Dekany [1%]; Reinig [0.6%]; Johansson [0.8%]; Le Mignant [0.7%]; Velur [1%]; Kupke [0.5%]; Neyman [0.5%]; Lockwood [0.5%]; Bell [0.3%]; Adkins [0.5%]; Wetherell [0.4%] | 340h | 28,826.2 |
| 77 | 1.3.2.3.1.2 | Monthly Project Reports (TSIP, Directors) |  | 467d? | 2008-05-15 | 2010-02-26 | 16d | start no earlier than 2008-05-15 | Wizinowich [2.4%]; Dekany [0.5%]; Gavel [0.5%]; Adkins [0.5%]; Max [0.5%] | 170h | 15,762.8 |
| 78 | 1.3.2.3.1.3 | TSIP Project Report Telecons |  | 464d? | 2008-05-20 | 2010-02-26 | 16d | start no earlier than 2008-05-20 | Adkins [0.5%]; Wizinowich [0.5%] | 36h | 3,744 |
| 79 | 1.3.2.3.2 | **SSC Meetings** |  | 459.88d? | 2008-04-30 | 2010-02-02 | 34.12d |  |  | 91h | 9,577.96 |
| 80 | 1.3.2.3.2.1 | SSC Meeting (CIT) - SDR report | milestone | 0d | 2008-04-30 | 2008-04-30 | 494d | start no earlier than 2008-04-30 |  |  |  |
| 81 | 1.3.2.3.2.2 | SSC Meeting (Keck) |  | 1.12d | 2008-06-18 | 2008-06-19 | 457.88d | start no earlier than 2008-06-18 | Dekany; Gavel; Wizinowich | 13h | 1,368.28 |
| 82 | 1.3.2.3.2.3 | SSC Meeting (UCSC) |  | 1.12d | 2008-11-03 | 2008-11-04 | 359.88d | start no earlier than 2008-11-03 | Dekany; Gavel; Wizinowich | 13h | 1,368.28 |
| 83 | 1.3.2.3.2.4 | SSC Meeting (Keck) |  | 1.12d | 2009-02-19 | 2009-02-20 | 281.88d | start no earlier than 2009-02-19 | Dekany; Gavel; Wizinowich | 13h | 1,368.28 |
| 84 | 1.3.2.3.2.5 | SSC Meeting (CIT) |  | 1.12d | 2009-04-29 | 2009-04-30 | 232.88d | start no earlier than 2009-04-29 | Dekany; Gavel; Wizinowich | 13h | 1,368.28 |
| 85 | 1.3.2.3.2.6 | SSC Meeting (Keck) |  | 1.12d | 2009-06-17 | 2009-06-18 | 197.88d | start no earlier than 2009-06-17 | Dekany; Gavel; Wizinowich | 13h | 1,368.28 |
| 86 | 1.3.2.3.2.7 | SSC Meeting (UCSC) |  | 1.12d | 2009-11-03 | 2009-11-04 | 98.88d | start no earlier than 2009-11-03 | Dekany; Gavel; Wizinowich | 13h | 1,368.28 |
| 87 | 1.3.2.3.2.8 | SSC Meeting (Keck) |  | 1.88d? | 2010-02-01 | 2010-02-02 | 34.12d | start no earlier than 2010-02-01 | Dekany [50%]; Gavel [50%]; Wizinowich [60%] | 13h | 1,368.28 |
| 88 | 1.3.2.3.3 | **Other Presentations** |  | 350d? | 2008-06-02 | 2009-10-02 | 121d |  |  | 232h | 24,714.08 |
| 89 | 1.3.2.3.3.1 | SPIE AO Conference Presentations/Papers |  | 15d? | 2008-06-02 | 2008-06-20 | 456d | start no earlier than 2008-06-02 | Dekany [33.3%]; Gavel [33.3%]; Wizinowich [33.3%] | 120h | 12,805.6 |
| 90 | 1.3.2.3.3.2 | SPIE AO Conference (Marseille) |  | 5d? | 2008-06-23 | 2008-06-28 | 451d | finish no earlier than 2008-06-28 |  |  |  |
| 91 | 1.3.2.3.3.3 | Keck Science Meeting 08 |  | 3d | 2008-09-18 | 2008-09-22 | 390d | start no earlier than 2008-09-18 | Dekany; Gavel; Wizinowich | 56h | 5,954.24 |
| 92 | 1.3.2.3.3.4 | Keck Science Meeting 09 |  | 3d | 2009-09-17 | 2009-09-21 | 130d | start no earlier than 2009-09-17 | Dekany; Gavel; Wizinowich | 56h | 5,954.24 |
| 93 | 1.3.2.3.3.5 | Other |  | 195d? | 2009-01-05 | 2009-10-02 | 121d | finish no earlier than 2009-10-02 |  |  |  |

Notes:
- 68: PW
- 69: PW
- 70: PW
- 71: PW
- 72: PW
- 73: PW
- 74: PW
- 75: PW
- 79: PW
- 88: PW

| ID | WBS | Task | Type | Duration | Start | Finish | Total slack | Constraint | Resources | Work | Cost |
| --- | --- | --- | --- | --- | --- | --- | --- | --- | --- | --- | --- |
| 94 | 1.3.2.4 | **Proposals** |  | 348d? | 2008-06-02 | 2009-09-30 | 123d |  |  | 480h | 4,322.8 |
| 95 | 1.3.2.4.1 | Advancement Support |  | 348d? | 2008-06-02 | 2009-09-30 | 123d | start no earlier than 2008-06-02 | Free [2.9%] | 80h |  |
| 96 | 1.3.2.4.2 | TSIP Proposal for DDR |  | 25d? | 2009-07-28 | 2009-08-31 | 145d | finish no earlier than 2009-08-31 | Dekany [10%]; Gavel [10%]; Max [10%]; Free [90%] | 240h | 4,322.8 |
| 97 | 1.3.2.4.3 | Other Proposal |  | 20d? | 2009-09-03 | 2009-09-30 | 123d | finish no earlier than 2009-09-30 | Free | 160h |  |
| 98 | 1.3.2.5 | **Programmatic Risk Assessment & Mitigation** |  | 400d? | 2008-05-19 | 2009-11-27 | 81d |  |  | 200h | 20,865.12 |
| 99 | 1.3.2.5.1 | **Risk Assessment** |  | 213.25d? | 2008-09-04 | 2009-06-30 | 189d |  |  | 60h | 6,305.12 |
| 100 | 1.3.2.5.1.1 | Programmatic Risk Assessment v1 |  | 6.25d? | 2008-09-04 | 2008-09-12 | 396d | finish no earlier than 2008-09-12 | Wizinowich [40%]; Dekany [8%]; Gavel [8%]; Adkins [8.9%] | 32h | 3,360.56 |
| 101 | 1.3.2.5.1.2 | Programmatic Risk Assessment v2 |  | 2d? | 2009-06-29 | 2009-06-30 | 189d | finish no earlier than 2009-06-30 | Wizinowich; Dekany; Gavel; Adkins | 28h | 2,944.56 |
| 102 | 1.3.2.5.2 | **Risk Mitigation** |  | 400d? | 2008-05-19 | 2009-11-27 | 81d |  |  | 140h | 14,560 |
| 103 | 1.3.2.5.2.1 | Laser Procurement |  | 350d? | 2008-05-26 | 2009-09-25 | 126d | finish no earlier than 2009-09-25 | Wizinowich [1.4%] | 40h | 4,160 |
| 104 | 1.3.2.5.2.2 | Science Instruments |  | 35d? | 2008-10-06 | 2008-11-21 | 346d | finish no earlier than 2008-11-21 | Wizinowich [14.3%] | 40h | 4,160 |
| 105 | 1.3.2.5.2.3 | Funding |  | 95d? | 2008-05-19 | 2008-09-26 | 386d | finish no earlier than 2008-09-26 | Wizinowich [5.3%] | 40h | 4,160 |
| 106 | 1.3.2.5.2.4 | Identify Long Lead Procurements |  | 40d? | 2009-10-05 | 2009-11-27 | 81d | start no earlier than 2009-10-05 | Wizinowich [6.2%] | 20h | 2,080 |
| 107 | 1.3.2.6 | **Preliminary Design Review** |  | 404.33d? | 2008-09-02 | 2010-03-22 | 0d |  |  | 498h | 42,922.5 |
| 108 | 1.3.2.6.1 | Define Success Criteria for all Reviews |  | 8.33d? | 2008-09-02 | 2008-09-12 | 396d | finish no earlier than 2008-09-12 | Wizinowich [60%]; Dekany [12%]; Gavel [12%]; Max [6%] | 60h | 5,889.12 |
| 109 | 1.3.2.6.2 | Review Setup (Date, Participants, Charter) |  | 5d? | 2009-09-07 | 2009-09-11 | 136d | start no earlier than 2009-09-07 | Wizinowich [30%]; Max [10%] | 16h | 1,248 |
| 110 | 1.3.2.6.3 | Preliminary Design Report |  | 12d? | 2010-01-11 | 2010-01-26 | 39d | start no earlier than 2010-01-11 | Wizinowich [52.1%]; Dekany [15.6%]; Gavel [15.6%]; Max [4.2%]; Neyman [2.1%]; Le Mignant [2.1%]; Johansson [2.1%]; Reinig [3.1%]; Velur [5.2%]; Kupke [2.1%] | 100h | 9,652.1 |
| 111 | 1.3.2.6.4 | Review Package Distributed |  | 1d? | 2010-01-27 | 2010-01-27 | 38d | start no earlier than 2010-01-27 | Wizinowich [75%] | 6h | 624 |
| 112 | 1.3.2.6.5 | Reviewer Comments Received | milestone | 0d | 2010-02-10 | 2010-02-10 | 29d | start no earlier than 2010-02-10 |  |  |  |
| 113 | 1.3.2.6.6 | Reviewer Comments Addressed |  | 5d? | 2010-02-11 | 2010-02-17 | 23d | start no earlier than 2010-02-11 | Wizinowich [50%]; Dekany [30%]; Gavel [30%]; Max [40%]; Reinig [5%]; Velur [15%]; Bell [2.5%]; Wetherell [2.5%]; Neyman [5%]; Le Mignant [5%]; Johansson [5%]; Kupke [5%]; Lockwood [5%] | 80h | 6,275.24 |
| 114 | 1.3.2.6.7 | PDR Presentation Preparation |  | 15d? | 2010-02-01 | 2010-02-19 | 21d | start no earlier than 2010-02-01 | Wizinowich [16.7%]; Dekany [10%]; Gavel [10%]; Reinig [3.3%]; Kupke [1.7%]; Lockwood [1.7%]; Velur [5%]; Wetherell [0.8%]; Bell [0.8%]; Neyman [1.7%]; Le Mignant [2.5%]; Johansson [2.5%] | 68h | 6,539.24 |
| 115 | 1.3.2.6.8 | Preliminary Design Review |  | 1d? | 2010-02-22 | 2010-02-22 | 20d | start no earlier than 2010-02-22 | Wizinowich [1250%]; Dekany [1250%]; Max [1250%]; Gavel [1250%]; Velur; Reinig; Lockwood; Kupke; Wetherell; Le Mignant; Neyman; Johansson; COO ME | 120h | 8,713.68 |
| 116 | 1.3.2.6.9 | Reviewer Report Received | milestone | 0d | 2010-03-15 | 2010-03-15 | 6d | start no earlier than 2010-03-15 |  |  |  |
| 117 | 1.3.2.6.10 | Response to Reviewer Report |  | 5d? | 2010-03-16 | 2010-03-22 | 0d | start no earlier than 2010-03-16 | Wizinowich [40%]; Dekany [20%]; Gavel [20%]; Max [20%]; Reinig [5%]; Kupke [2.5%]; Velur [5%]; Neyman [2.5%]; Le Mignant [2.5%]; Johansson [2.5%] | 48h | 3,981.12 |

Notes:
- 94: PW
- 98: PW
- 99: PW
- 102: PW
- 107: PW

| ID | WBS | Task | Duration | Start | Finish | Total slack | Constraint | Resources | Work | Cost |
| --- | --- | --- | --- | --- | --- | --- | --- | --- | --- | --- |
| 118 | 1.3.2.7 | **Project Support** | 477d? | 2008-05-01 | 2010-02-26 | 16d |  |  | 3361h | 161,417 |
| 119 | 1.3.2.7.1 | Administrative/Contract Support | 477d? | 2008-05-01 | 2010-02-26 | 16d | start no earlier than 2008-05-01 | Tyau [20.6%]; Contract Administrator [2.1%]; Wizinowich [10.4%] | 765h | 30,265 |
| 120 | 1.3.2.7.2 | Shared Infrastructure | 430d? | 2008-07-07 | 2010-02-26 | 16d | finish no earlier than 2010-02-26 | Chock [5.8%] | 200h | 14,000 |
| 121 | 1.3.2.7.3 | Research Time | 477d? | 2008-05-01 | 2010-02-26 | 16d | start no earlier than 2008-05-01 | McGrath [47.3%]; Le Mignant [15.5%] | 2396h | 117,152 |
| 122 | 1.3.3 | **Systems Engineering** | 479d? | 2008-04-01 | 2010-01-29 | 36d |  |  | 9473h | 548,270.48 |
| 123 | 1.3.3.1 | **Science Case Requirements** | 457d? | 2008-05-01 | 2010-01-29 | 36d |  |  | 4005h | 146,248 |
| 124 | 1.3.3.1.1 | **Science Case Requirements** | 447d? | 2008-05-01 | 2010-01-15 | 46d |  |  | 2701h | 103,520 |
| 125 | 1.3.3.1.1.1 | **Requirements for new Science Drivers** | 183d? | 2008-05-01 | 2009-01-12 | 310d |  |  | 440h | 13,040 |
| 126 | 1.3.3.1.1.1.1 | Astrometry Science in Sparse Fields | 71d? | 2008-10-06 | 2009-01-12 | 310d | finish no earlier than 2009-01-12 | McGrath [7%]; Student [14.1%]; Max [3.5%] | 140h | 4,880 |
| 127 | 1.3.3.1.1.1.2 | Resolved Stellar Populations in Crowded Fields | 61d? | 2008-07-14 | 2008-10-06 | 380d | finish no earlier than 2008-10-06 | Student [24.6%]; Max [8.2%] | 160h | 4,800 |
| 128 | 1.3.3.1.1.1.3 | Debris Disks & Young Stellar Objects | 61d? | 2008-07-14 | 2008-10-06 | 380d | finish no earlier than 2008-10-06 | McGrath [8.2%]; Max [8.2%] | 80h | 1,680 |
| 129 | 1.3.3.1.1.1.4 | QSO Host Galaxies | 52d? | 2008-05-01 | 2008-07-11 | 441d | finish no earlier than 2008-07-11 | McGrath [9.6%]; Max [4.8%] | 60h | 1,680 |
| 130 | 1.3.3.1.1.2 | **Extend SCRD Discussion of Science Drivers** | 168d? | 2008-05-01 | 2008-12-22 | 325d |  |  | 601h | 28,320 |
| 131 | 1.3.3.1.1.2.1 | Nearby AGNs | 52d? | 2008-05-01 | 2008-07-11 | 441d | finish no earlier than 2008-07-11 | McGrath [4.8%]; Max [2.4%] | 30h | 840 |
| 132 | 1.3.3.1.1.2.2 | Gravitational Lensing | 52d? | 2008-05-01 | 2008-07-11 | 441d | finish no earlier than 2008-07-11 | McGrath [9.6%]; Max [1%] | 44h | 1,680 |
| 133 | 1.3.3.1.1.2.3 | Backup Science | 52d? | 2008-05-01 | 2008-07-11 | 441d | finish no earlier than 2008-07-11 | McGrath [4.8%]; Max [1%]; Le Mignant [4.8%] | 44h | 2,240 |
| 134 | 1.3.3.1.1.2.4 | Ice Giant Planets | 61d? | 2008-07-14 | 2008-10-06 | 380d | finish no earlier than 2008-10-06 | McGrath [2%] | 10h | 420 |
| 135 | 1.3.3.1.1.2.5 | GR at Galactic Center | 61d? | 2008-07-14 | 2008-10-06 | 380d | finish no earlier than 2008-10-06 | Student [16.4%]; Max [3.1%] | 95h | 3,200 |
| 136 | 1.3.3.1.1.2.6 | Extrasolar Planets | 52d? | 2008-10-06 | 2008-12-16 | 329d | start no earlier than 2008-10-06 | McGrath [9.6%]; Macintosh [19.2%]; Max [4.8%] | 140h | 10,080 |
| 137 | 1.3.3.1.1.2.7 | Asteroids | 52d? | 2008-05-01 | 2008-07-11 | 441d | finish no earlier than 2008-07-11 | Student [9.6%]; Le Mignant [4.8%]; Max [1.9%] | 68h | 3,000 |
| 138 | 1.3.3.1.1.2.8 | QSO Host Galaxies | 116d? | 2008-07-14 | 2008-12-22 | 325d | finish no earlier than 2008-12-22 | McGrath [6.5%]; Max [2.2%] | 80h | 2,520 |
| 139 | 1.3.3.1.1.2.9 | Backup Science - NGS & Acquisition Camera | 61d? | 2008-07-14 | 2008-10-06 | 380d | finish no earlier than 2008-10-06 | McGrath [4.1%]; Le Mignant [6.1%]; Neyman [4.1%]; Max [4.1%] | 90h | 4,340 |
| 140 | 1.3.3.1.1.3 | **Characterize PSF Stability, Knowledge & Subtraction Requirements** | 226d? | 2008-10-06 | 2009-08-17 | 155d |  |  | 1340h | 52,080 |
| 141 | 1.3.3.1.1.3.1 | Nearby AGNs | 226d? | 2008-10-06 | 2009-08-17 | 155d | finish no earlier than 2009-08-17 | McGrath [8.8%]; Student [19.9%]; Max [3.3%] | 580h | 21,120 |
| 142 | 1.3.3.1.1.3.2 | Galactic Center Astrometry | 97d? | 2008-10-06 | 2009-02-17 | 284d | start no earlier than 2008-10-06 | Student [20.6%]; Max [3.9%] | 190h | 6,400 |
| 143 | 1.3.3.1.1.3.3 | Extrasolar Planets | 96d? | 2009-01-12 | 2009-05-25 | 215d | start no earlier than 2009-01-12 | McGrath [5.2%]; Student [15.6%]; Macintosh [10.4%]; Max [2.6%] | 260h | 14,880 |
| 144 | 1.3.3.1.1.3.4 | Minor Planet Multiplicity | 36d? | 2008-10-20 | 2008-12-08 | 335d | start no earlier than 2008-10-20 | Student [27.8%]; Max [3.5%] | 90h | 3,200 |
| 145 | 1.3.3.1.1.3.5 | QSO Host Galaxies | 81d? | 2008-10-06 | 2009-01-26 | 300d | finish no earlier than 2009-01-26 | McGrath [6.2%]; Student [18.5%]; Max [9.3%] | 220h | 6,480 |
| 146 | 1.3.3.1.1.4 | Characterize Sensitivity & Background Requirements | 96d? | 2009-01-12 | 2009-05-25 | 215d | finish no earlier than 2009-05-25 | McGrath [15.6%]; Max [5.2%] | 160h | 5,040 |
| 147 | 1.3.3.1.1.5 | Science Requirements Summary Matrix | 165d? | 2009-05-25 | 2010-01-08 | 51d | finish no earlier than 2010-01-08 | McGrath [6.1%]; Max [1.5%] | 100h | 3,360 |
| 148 | 1.3.3.1.1.6 | SEMP Input | 75d? | 2009-10-05 | 2010-01-15 | 46d | start no earlier than 2009-10-05 | McGrath [6.7%]; Max [3.3%] | 60h | 1,680 |

Notes:
- 118: PW
- 122: RD
- 123: CM
- 124: CM

| ID | WBS | Task | Duration | Start | Finish | Total slack | Constraint | Resources | Work | Cost |
| --- | --- | --- | --- | --- | --- | --- | --- | --- | --- | --- |
| 149 | 1.3.3.1.2 | **Science Observing Planning & Execution** | 379d? | 2008-08-04 | 2010-01-14 | 47d |  |  | 480h | 22,120 |
| 150 | 1.3.3.1.2.1 | Key Science Driver Observing Scenarios | 120d? | 2008-08-04 | 2009-01-16 | 306d | start no earlier than 2008-08-04 | McGrath [13.5%]; Le Mignant [8.3%]; Max [3.1%] | 240h | 11,060 |
| 151 | 1.3.3.1.2.2 | Design Reference Missions | 119d? | 2009-08-03 | 2010-01-14 | 47d | start no earlier than 2009-08-03 | McGrath [13.7%]; Le Mignant [8.5%]; Max [3.2%] | 240h | 11,060 |
| 152 | 1.3.3.1.3 | **Science Performance Input** | 315d? | 2008-10-06 | 2009-12-18 | 66d |  |  | 180h | 5,460 |
| 153 | 1.3.3.1.3.1 | Define Science Driver Parameters for Performance Budgets | 12d? | 2008-10-13 | 2008-10-28 | 364d | start no earlier than 2008-10-13 | McGrath [10.4%]; Max [10.4%] | 20h | 420 |
| 154 | 1.3.3.1.3.2 | Input to User Interfaces, Planning & Observing Tools | 300d? | 2008-10-06 | 2009-11-27 | 81d | finish no earlier than 2009-11-27 | McGrath [3.3%] | 80h | 3,360 |
| 155 | 1.3.3.1.3.3 | Input to Preliminary Operations Concept Document | 275d? | 2008-12-01 | 2009-12-18 | 66d | finish no earlier than 2009-12-18 | McGrath [1.8%]; Max [1.8%] | 80h | 1,680 |
| 156 | 1.3.3.1.4 | **Science Competitiveness** | 380d? | 2008-07-07 | 2009-12-18 | 66d |  |  | 144h | 4,368 |
| 157 | 1.3.3.1.4.1 | Update List of Science Goals for Other Facilities | 380d? | 2008-07-07 | 2009-12-18 | 66d | finish no earlier than 2009-12-18 | McGrath [1.4%]; Max [0.7%] | 64h | 1,848 |
| 158 | 1.3.3.1.4.2 | Evaluate NGAO Potential to Compliment Other Facilities | 380d? | 2008-07-07 | 2009-12-18 | 66d | finish no earlier than 2009-12-18 | McGrath [1.3%]; Max [0.3%] | 50h | 1,680 |
| 159 | 1.3.3.1.4.3 | Define NGAO Uniqueness Space | 380d? | 2008-07-07 | 2009-12-18 | 66d | finish no earlier than 2009-12-18 | McGrath [0.7%]; Max [0.3%] | 30h | 840 |
| 160 | 1.3.3.1.5 | **User Community Liaison** | 445d? | 2008-05-19 | 2010-01-29 | 36d |  |  | 220h | 2,940 |
| 161 | 1.3.3.1.5.1 | Enlist People to work on new NGAO Science Aspects | 358d? | 2008-05-19 | 2009-09-30 | 123d | finish no earlier than 2009-09-30 | Max [1.4%]; McGrath [0.7%] | 60h | 840 |
| 162 | 1.3.3.1.5.2 | **SSC & Keck Science Meeting** | 435d? | 2008-06-02 | 2010-01-29 | 36d |  |  | 160h | 2,100 |
| 163 | 1.3.3.1.5.2.1 | Prepare & Give Presentations | 435d? | 2008-06-02 | 2010-01-29 | 36d | finish no earlier than 2010-01-29 | Max [2%]; McGrath [1.1%] | 110h | 1,680 |
| 164 | 1.3.3.1.5.2.2 | Obtain & Document Feedback | 435d? | 2008-06-02 | 2010-01-29 | 36d | finish no earlier than 2010-01-29 | Max [1.1%]; McGrath [0.3%] | 50h | 420 |
| 165 | 1.3.3.1.6 | **Science Advisory Team Meetings** | 385d? | 2008-06-09 | 2009-11-27 | 81d |  |  | 280h | 7,840 |
| 166 | 1.3.3.1.6.1 | Prepare Minutes, Presentations & KAONs | 385d? | 2008-06-09 | 2009-11-27 | 81d | finish no earlier than 2009-11-27 | Max [2.6%]; McGrath [2.6%]; Le Mignant [0.6%] | 180h | 4,760 |
| 167 | 1.3.3.1.6.2 | Refine Science Requirements | 355d? | 2008-07-21 | 2009-11-27 | 81d | finish no earlier than 2009-11-27 | Le Mignant [0.7%] | 20h | 1,400 |
| 168 | 1.3.3.1.6.3 | Evaluate Science Impact of Proposed Changes | 355d? | 2008-07-21 | 2009-11-27 | 81d | finish no earlier than 2009-11-27 | Max [1.4%]; McGrath [1.4%] | 80h | 1,680 |
| 169 | 1.3.3.2 | **Requirements** | 410d? | 2008-05-26 | 2009-12-18 | 66d |  |  | 970h | 68,139 |
| 170 | 1.3.3.2.1 | **Operations Concept Document (OCD)** | 410d? | 2008-05-26 | 2009-12-18 | 66d |  |  | 480h | 34,552 |
| 171 | 1.3.3.2.1.1 | OCD Outline | 10d? | 2008-05-26 | 2008-06-06 | 466d | start no earlier than 2008-05-26 | Le Mignant [40%]; Wizinowich [10%] | 40h | 3,072 |
| 172 | 1.3.3.2.1.2 | OCD Release 1 | 45d? | 2008-12-01 | 2009-01-30 | 296d | start no earlier than 2008-12-01 | Le Mignant [33.3%]; Neyman [13.9%]; Wizinowich [2.8%]; Johansson [5.6%] | 200h | 14,340 |
| 173 | 1.3.3.2.1.3 | OCD Release 2 | 55d? | 2009-10-05 | 2009-12-18 | 66d | start no earlier than 2009-10-05 | Le Mignant [36.4%]; Neyman [11.4%]; Johansson [4.5%]; Wizinowich [2.3%] | 240h | 17,140 |

Notes:
- 149: CM
- 152: CM
- 156: CM
- 160: CM
- 165: CM
- 169: EJ
- 170: DLM
- 171: DLM
- 172: DLM
- 173: DLM

| ID | WBS | Task | Duration | Start | Finish | Total slack | Constraint | Resources | Work | Cost |
| --- | --- | --- | --- | --- | --- | --- | --- | --- | --- | --- |
| 174 | 1.3.3.2.2 | **System Requirements (SRD)** | 270d? | 2008-12-01 | 2009-12-11 | 71d |  |  | 80h | 5,600 |
| 175 | 1.3.3.2.2.1 | SRD Release I | 10d? | 2008-12-01 | 2008-12-12 | 331d | finish no earlier than 2008-12-12 | Johansson [62.5%] | 50h | 3,500 |
| 176 | 1.3.3.2.2.2 | SRD Release 2 | 10d? | 2009-11-30 | 2009-12-11 | 71d | finish no earlier than 2009-12-11 | Johansson [37.5%] | 30h | 2,100 |
| 177 | 1.3.3.2.3 | **Functional Requirements (FRD)** | 375d? | 2008-07-14 | 2009-12-18 | 66d |  |  | 250h | 20,987 |
| 178 | 1.3.3.2.3.1 | FRD Release 1 | 35d? | 2008-07-14 | 2008-08-29 | 406d | start no earlier than 2008-07-14 | Johansson [14.3%]; Dekany [10.7%]; Wizinowich [7.1%]; Gavel [10.7%] | 120h | 11,364.2 |
| 179 | 1.3.3.2.3.2 | FRD Release 2 | 35d? | 2009-11-02 | 2009-12-18 | 66d | start no earlier than 2009-11-02 | Johansson [17.9%]; Dekany [7.1%] | 70h | 5,422.8 |
| 180 | 1.3.3.2.3.3 | Compliance Matrix | 20d? | 2008-10-06 | 2008-10-31 | 361d | finish no earlier than 2008-10-31 | Johansson [37.5%] | 60h | 4,200 |
| 181 | 1.3.3.2.4 | Software Standards (Define & Document) | 31d? | 2008-10-06 | 2008-11-17 | 350d | start no earlier than 2008-10-06 | Johansson [8.1%]; Johnson [24.2%] | 80h | 1,400 |
| 182 | 1.3.3.2.5 | Component Standards (Define & Document) | 25d? | 2008-11-03 | 2008-12-05 | 336d | finish no earlier than 2008-12-05 | Johansson [40%] | 80h | 5,600 |
| 183 | 1.3.3.3 | **Systems Engineering Analysis** | 427d? | 2008-05-01 | 2009-12-18 | 66d |  |  | 1790h | 142,789.96 |
| 184 | 1.3.3.3.1 | **Performance Budgets** | 389d? | 2008-06-24 | 2009-12-18 | 66d |  |  | 870h | 72,116.36 |
| 185 | 1.3.3.3.1.1 | Requirements Flowdown Report | 15d? | 2009-11-30 | 2009-12-18 | 66d | start no earlier than 2009-11-30 | Dekany [50%] | 60h | 5,768.4 |
| 186 | 1.3.3.3.1.2 | **Throughput & Background Budget** | 30d? | 2008-11-03 | 2008-12-12 | 331d |  |  | 80h | 7,691.2 |
| 187 | 1.3.3.3.1.2.1 | Thermal Background Analysis Software with Documentation | 15d? | 2008-11-03 | 2008-11-21 | 346d | finish no earlier than 2008-11-21 | Bouchez [41.7%] | 50h | 4,807 |
| 188 | 1.3.3.3.1.2.2 | Thermal Analysis | 10d? | 2008-12-01 | 2008-12-12 | 331d | finish no earlier than 2008-12-12 | Bouchez [37.5%] | 30h | 2,884.2 |
| 189 | 1.3.3.3.1.3 | **Wavefront & Encircled Energy** | 325d? | 2008-09-01 | 2009-11-27 | 81d |  |  | 370h | 35,616.76 |
| 190 | 1.3.3.3.1.3.1 | **WFE/EE Budget Tool** | 325d? | 2008-09-01 | 2009-11-27 | 81d |  |  | 322h | 31,002.04 |
| 191 | 1.3.3.3.1.3.1.1 | NGS TT & TTFA Sharpening Budgets | 31.5d? | 2008-10-06 | 2008-11-18 | 349.5d | start no earlier than 2008-10-06 | Dekany [23.8%] | 60h | 5,768.4 |
| 192 | 1.3.3.3.1.3.1.2 | Improved Bandwidth Model | 25d? | 2008-12-01 | 2009-01-02 | 316d | start no earlier than 2008-12-01 | Dekany [4%]; Gavel [36%] | 80h | 9,409.12 |
| 193 | 1.3.3.3.1.3.1.3 | Improved Atmospheric Dispersion Model | 15d? | 2008-09-01 | 2008-09-19 | 391d | start no earlier than 2008-09-01 | Bouchez [33.3%] | 40h | 3,845.6 |
| 194 | 1.3.3.3.1.3.1.4 | NFIRAOS Budget Comparison | 33d? | 2008-10-01 | 2008-11-14 | 351d | start no earlier than 2008-10-01 | Dekany [18.2%]; Neyman [9.1%] | 72h | 6,294.72 |
| 195 | 1.3.3.3.1.3.1.5 | Determine Additional Performance Modeling/Anchoring | 5d? | 2008-11-17 | 2008-11-21 | 346d | finish no earlier than 2008-11-21 | Dekany [25%] | 10h | 961.4 |
| 196 | 1.3.3.3.1.3.1.6 | Perform Additional Performance Modeling/Anchoring | 40d? | 2009-10-05 | 2009-11-27 | 81d | finish no earlier than 2009-11-27 | Dekany [6.2%]; Neyman [12.5%] | 60h | 4,722.8 |
| 197 | 1.3.3.3.1.3.2 | **WFE/EE Performance Analysis** | 195d? | 2008-12-01 | 2009-08-28 | 146d |  |  | 48h | 4,614.72 |
| 198 | 1.3.3.3.1.3.2.1 | Key Science Cases Analysis | 20d? | 2009-06-01 | 2009-06-26 | 191d | start no earlier than 2009-06-01 | Dekany [15%] | 24h | 2,307.36 |
| 199 | 1.3.3.3.1.3.2.2 | Additional Science Case Analysis | 20d? | 2009-08-03 | 2009-08-28 | 146d | finish no earlier than 2009-08-28 | Dekany [5%] | 8h | 769.12 |
| 200 | 1.3.3.3.1.3.2.3 | Laser Return Evaluation | 10d? | 2008-12-01 | 2008-12-12 | 331d | finish no earlier than 2008-12-12 | Dekany [20%] | 16h | 1,538.24 |

Notes:
- 174: EJ
- 175: EJ
- 176: EJ
- 177: EJ
- 178: EJ
- 179: EJ
- 180: EJ
- 181: EJ
- 182: EJ
- 183: RD
- 184: RD
- 185: RD
- 186: AB
- 189: RD
- 190: RD
- 191: RD
- 192: RD
- 193: AB
- 194: RD
- 195: RD
- 196: RD
- 197: RD
- 198: RD
- 199: RD
- 200: RD

| ID | WBS | Task | Duration | Start | Finish | Predecessors | Total slack | Free slack | Constraint | Resources | Work | Cost |
| --- | --- | --- | --- | --- | --- | --- | --- | --- | --- | --- | --- | --- |
| 201 | 1.3.3.3.1.4 | **Astrometric Precision** | 105d? | 2008-10-06 | 2009-02-27 |  | 276d |  |  |  | 200h | 11,840 |
| 202 | 1.3.3.3.1.4.1 | Develop Astrometric Budget Tool | 55d? | 2008-10-06 | 2008-12-19 |  | 326d |  | start no earlier than 2008-10-06 | Lu [13.6%]; Wizinowich [13.6%] | 120h | 6,240 |
| 203 | 1.3.3.3.1.4.2 | Galactic Center Astrometric Analysis | 40d? | 2009-01-05 | 2009-02-27 |  | 276d |  | start no earlier than 2009-01-05 | Neyman [25%] | 80h | 5,600 |
| 204 | 1.3.3.3.1.5 | **Observing Efficiency** | 266d? | 2008-06-24 | 2009-06-30 |  | 189d |  |  |  | 80h | 5,600 |
| 205 | 1.3.3.3.1.5.1 | Observing Efficiency Tool | 5d? | 2008-06-24 | 2008-06-30 |  | 450d |  | finish no earlier than 2008-06-30 | Le Mignant | 40h | 2,800 |
| 206 | 1.3.3.3.1.5.2 | Observing Efficiency Analysis | 5d? | 2009-06-24 | 2009-06-30 |  | 189d |  | finish no earlier than 2009-06-30 | Le Mignant | 40h | 2,800 |
| 207 | 1.3.3.3.1.6 | **Observing Uptime** | 250d? | 2008-12-01 | 2009-11-13 |  | 91d |  |  |  | 80h | 5,600 |
| 208 | 1.3.3.3.1.6.1 | Observing Uptime Tool | 10d? | 2008-12-01 | 2008-12-12 |  | 331d |  | start no earlier than 2008-12-01 | Neyman [50%] | 40h | 2,800 |
| 209 | 1.3.3.3.1.6.2 | Observing Uptime Analysis | 10d? | 2009-11-02 | 2009-11-13 |  | 91d |  | start no earlier than 2009-11-02 | Johansson [25%]; Neyman [25%] | 40h | 2,800 |
| 210 | 1.3.3.3.2 | **Modeling & Analysis** | 247d? | 2008-05-01 | 2009-04-10 |  | 246d |  |  |  | 840h | 65,073.6 |
| 211 | 1.3.3.3.2.1 | T/T Sharpening Study Report | 42d? | 2008-05-01 | 2008-06-27 |  | 451d |  | start no earlier than 2008-05-01 | Dekany [23.8%]; Neyman [47.6%] | 240h | 18,891.2 |
| 212 | 1.3.3.3.2.2 | Performance vs T/T NGS Report | 32d? | 2008-09-01 | 2008-10-14 |  | 374d |  | start no earlier than 2008-09-01 | Dekany [41.7%]; Neyman [62.5%] | 200h | 15,045.6 |
| 213 | 1.3.3.3.2.3 | Galactic Center Performance Report | 30d? | 2009-03-02 | 2009-04-10 |  | 246d |  | start no earlier than 2009-03-02 | Dekany [50%]; Neyman [50%] | 240h | 19,936.8 |
| 214 | 1.3.3.3.2.4 | PSF Libraries | 35d? | 2008-11-03 | 2008-12-19 |  | 326d |  | finish no earlier than 2008-12-19 | Neyman [57.1%] | 160h | 11,200 |
| 215 | 1.3.3.3.3 | PSF Calibration | 125d? | 2009-05-04 | 2009-10-23 |  | 106d |  | start no earlier than 2009-05-04 | Le Mignant [8%] | 80h | 5,600 |
| 216 | 1.3.3.4 | **System Architecture** | 411d? | 2008-05-05 | 2009-11-30 |  | 80d |  |  |  | 1070h | 72,784.16 |
| 217 | 1.3.3.4.1 | **System Hardware Architecture** | 391d? | 2008-06-02 | 2009-11-30 |  | 80d |  |  |  | 264h | 22,244.16 |
| 218 | 1.3.3.4.1.1 | Hybrid Rayleigh / Sodium Trade Study | 65d? | 2008-06-30 | 2008-09-26 |  | 386d |  | start no earlier than 2008-06-30 | Dekany [15.4%]; Neyman [15.4%] | 160h | 13,291.2 |
| 219 | 1.3.3.4.1.2 | Degraded Laser Power Trade Study | 10d? | 2008-08-04 | 2008-08-15 |  | 416d |  | start no earlier than 2008-08-04 | Neyman [50%] | 40h | 2,800 |
| 220 | 1.3.3.4.1.3 | System Architecture: Evaluate & Document Changes | 391d? | 2008-06-02 | 2009-11-30 |  | 80d |  | start no earlier than 2008-06-02 | Dekany [2%] | 64h | 6,152.96 |
| 221 | 1.3.3.4.2 | **Software Architecture** | 47d? | 2008-07-28 | 2008-09-30 |  | 384d |  |  |  | 162h | 5,460 |
| 222 | 1.3.3.4.2.1 | Evaluate Software Architecture Options | 20d? | 2008-07-28 | 2008-08-22 |  | 391d | 0d | start no earlier than 2008-07-28 | Johansson [9.4%]; Morrison [9.4%]; Johnson [12.5%] | 50h | 2,100 |
| 223 | 1.3.3.4.2.2 | Determine/Document Software Arch Approach | 20d? | 2008-08-25 | 2008-09-19 | 222 | 391d |  | finish no earlier than 2008-09-19 | Johansson [25%]; Johnson [25%] | 80h | 2,800 |
| 224 | 1.3.3.4.2.3 | Software Architecture: Evaluate & Document Changes | 7d? | 2008-09-22 | 2008-09-30 |  | 384d |  | start no earlier than 2008-09-22 | Johnson [42.9%]; Johansson [14.3%] | 32h | 560 |

Notes:
- 201: PW
- 204: DLM
- 207: EJ
- 210: RD
- 215: DLM
- 216: RD
- 217: RD
- 221: EJ
- 222: EJ
- 223: EJ
- 224: EJ

| ID | WBS | Task | Duration | Start | Finish | Predecessors | Total slack | Free slack | Constraint | Resources | Work | Cost |
| --- | --- | --- | --- | --- | --- | --- | --- | --- | --- | --- | --- | --- |
| 225 | 1.3.3.4.3 | **Control Systems Architecture** | 261d? | 2008-10-01 | 2009-09-30 |  | 123d |  |  |  | 420h | 29,400 |
| 226 | 1.3.3.4.3.1 | Evaluate Control Systems Arch Options | 33d? | 2008-10-01 | 2008-11-14 |  | 315d | 0d | finish no earlier than 2008-11-14 | Johansson [30.3%] | 80h | 5,600 |
| 227 | 1.3.3.4.3.2 | Determine/Document Control Systems Arch | 36d? | 2008-11-17 | 2009-01-05 | 226 | 315d |  | start no earlier than 2008-11-17 | Johansson [34.7%] | 100h | 7,000 |
| 228 | 1.3.3.4.3.3 | Evaluate Motion Control Arch Options | 37d? | 2009-01-08 | 2009-02-27 |  | 256d | 0d | finish no earlier than 2009-02-27 | Johansson [20.3%]; Wetherell [20.3%] | 120h | 8,400 |
| 229 | 1.3.3.4.3.4 | Determine/Document Motion Control Arch | 20d? | 2009-03-02 | 2009-03-27 | 228 | 256d |  | finish no earlier than 2009-03-27 | Johansson [18.8%]; Wetherell [18.8%] | 60h | 4,200 |
| 230 | 1.3.3.4.3.5 | Control Systems Architecture: Evaluate & Document Changes | 190d? | 2009-01-08 | 2009-09-30 |  | 123d |  | start no earlier than 2009-01-08 | Johansson [2.6%]; Wetherell [1.3%] | 60h | 4,200 |
| 231 | 1.3.3.4.4 | **Operations Sequences Architecture** | 330d? | 2008-05-05 | 2009-08-07 |  | 161d |  |  |  | 224h | 15,680 |
| 232 | 1.3.3.4.4.1 | Define Required System Level Sequences | 10d? | 2008-05-05 | 2008-05-16 |  | 481d |  | start no earlier than 2008-05-05 | Le Mignant [50%] | 40h | 2,800 |
| 233 | 1.3.3.4.4.2 | Develop System Level Sequences Approach | 15d? | 2008-05-19 | 2008-06-06 |  | 466d |  | finish no earlier than 2008-06-06 | Le Mignant [33.3%] | 40h | 2,800 |
| 234 | 1.3.3.4.4.3 | Sequences Definition Document | 15d? | 2008-06-09 | 2008-06-27 |  | 451d |  | start no earlier than 2008-06-09 | Le Mignant [66.7%] | 80h | 5,600 |
| 235 | 1.3.3.4.4.4 | Sequences: Evaluate & Document Changes | 285d? | 2008-07-07 | 2009-08-07 |  | 161d |  | start no earlier than 2008-07-07 | Le Mignant [2.8%] | 64h | 4,480 |
| 236 | 1.3.3.5 | **External Interface Control** | 100d? | 2008-10-06 | 2009-02-20 |  | 281d |  |  |  | 244h | 19,116.48 |
| 237 | 1.3.3.5.1 | **Observatory Interfaces** | 100d? | 2008-10-06 | 2009-02-20 |  | 281d |  |  |  | 120h | 8,740 |
| 238 | 1.3.3.5.1.1 | AO System ICD | 15d? | 2009-02-02 | 2009-02-20 |  | 281d |  | finish no earlier than 2009-02-20 | Neyman [33.3%] | 40h | 2,800 |
| 239 | 1.3.3.5.1.2 | Laser System ICD | 10d? | 2008-10-06 | 2008-10-17 |  | 371d |  | finish no earlier than 2008-10-17 | Chin [12.5%]; Neyman [25%]; Adkins [12.5%] | 40h | 3,140 |
| 240 | 1.3.3.5.1.3 | Science Tools ICD | 20d? | 2008-10-06 | 2008-10-31 |  | 361d |  | finish no earlier than 2008-10-31 | Le Mignant [15.6%]; Johansson | 40h | 2,800 |
| 241 | 1.3.3.5.2 | **Science Instrument Interfaces to NGAO** | 40d? | 2008-10-06 | 2008-11-28 |  | 341d |  |  |  | 124h | 10,376.48 |
| 242 | 1.3.3.5.2.1 | Generic Science Instrument ICD to AO | 20d? | 2008-10-06 | 2008-10-31 |  | 361d |  | finish no earlier than 2008-10-31 | Adkins [5%]; Neyman [12.5%]; Lockwood [2.5%]; Kupke [2.5%]; Bell [2.5%] | 40h | 3,194.24 |
| 243 | 1.3.3.5.2.2 | Generic Science Instrument ICD to NGAO Science Tools | 20d? | 2008-10-06 | 2008-10-31 |  | 361d |  | finish no earlier than 2008-10-31 | Adkins [9.4%]; Le Mignant [9.4%]; Johansson | 40h | 3,310 |
| 244 | 1.3.3.5.2.3 | Interferometer Specific ICD | 20d? | 2008-11-03 | 2008-11-28 |  | 341d |  | finish no earlier than 2008-11-28 | Neyman [7.5%] | 12h | 840 |
| 245 | 1.3.3.5.2.4 | OSIRIS Specific ICD | 20d? | 2008-11-03 | 2008-11-28 |  | 341d |  | start no earlier than 2008-11-03 | Adkins [2.5%]; Kupke [1.2%]; Bell [1.2%] | 8h | 679.12 |
| 246 | 1.3.3.5.2.5 | NIR Camera Specific ICD | 20d? | 2008-11-03 | 2008-11-28 |  | 341d |  | start no earlier than 2008-11-03 | Adkins [1.2%]; Kupke [0.6%]; Lockwood [0.6%] | 4h | 379 |
| 247 | 1.3.3.5.2.6 | Visible Camera Specific ICD | 20d? | 2008-11-03 | 2008-11-28 |  | 341d |  | start no earlier than 2008-11-03 | Adkins [1.2%]; Kupke [0.6%]; Lockwood [0.6%] | 4h | 379 |
| 248 | 1.3.3.5.2.7 | d-IFS Specific ICD | 20d? | 2008-11-03 | 2008-11-28 |  | 341d |  | start no earlier than 2008-11-03 | Adkins [6.2%]; Wizinowich [2.5%]; Bell [1.2%] | 16h | 1,595.12 |

Notes:
- 225: EJ
- 226: EJ
- 227: EJ
- 228: EJ
- 229: EJ
- 230: EJ
- 231: DLM
- 236: CN
- 237: CN
- 238: CN
- 239: CN
- 240: DLM
- 241: SA
- 242: CN
- 243: DLM
- 244: CN
- 245: SA
- 246: SA
- 247: SA
- 248: SA

| ID | WBS | Task | Duration | Start | Finish | Total slack | Constraint | Resources | Work | Cost |
| --- | --- | --- | --- | --- | --- | --- | --- | --- | --- | --- |
| 249 | 1.3.3.6 | **Internal Interface Control** | 100d? | 2008-08-04 | 2008-12-19 | 326d |  |  | 280h | 23,980 |
| 250 | 1.3.3.6.1 | Diagram & Document Draft Outline | 40d? | 2008-08-04 | 2008-09-26 | 386d | finish no earlier than 2008-09-26 | Neyman [12.5%]; Wizinowich [3.1%] | 50h | 3,840 |
| 251 | 1.3.3.6.2 | Interface N-Squared Diagram | 25d? | 2008-10-06 | 2008-11-07 | 356d | start no earlier than 2008-10-06 | Neyman [20%]; Gavel [20%]; Velur [10%] | 100h | 9,520 |
| 252 | 1.3.3.6.3 | Interface Definition Document | 40d? | 2008-10-27 | 2008-12-19 | 326d | start no earlier than 2008-10-27 | Neyman [28.1%]; Gavel [6.2%]; Velur [6.2%] | 130h | 10,620 |
| 253 | 1.3.3.7 | **Configuration Control** | 15d? | 2009-10-05 | 2009-10-23 | 106d |  |  | 218h | 17,536.28 |
| 254 | 1.3.3.7.1 | Change Control Guidelines & Tools Definition | 15d? | 2009-10-05 | 2009-10-23 | 106d | finish no earlier than 2009-10-23 | Wetherell [60.6%]; Johansson; Gavel [50%]; Dekany [50%]; Bell | 218h | 17,536.28 |
| 255 | 1.3.3.8 | **Documentation Control** | 5d? | 2009-01-12 | 2009-01-16 | 306d |  |  | 20h | 1,400 |
| 256 | 1.3.3.8.1 | Document Control Guidelines & Tools Definition | 5d? | 2009-01-12 | 2009-01-16 | 306d | finish no earlier than 2009-01-16 | Johansson [50%] | 20h | 1,400 |
| 257 | 1.3.3.9 | **Technical Risk Assessment & Mitigation** | 392d? | 2008-04-01 | 2009-09-30 | 123d |  |  | 756h | 44,058.8 |
| 258 | 1.3.3.9.1 | **Risk Assessment** | 229.2d? | 2008-10-13 | 2009-08-28 | 146d |  |  | 100h | 10,562.8 |
| 259 | 1.3.3.9.1.1 | Risk Assessment v1 | 13.2d? | 2008-10-13 | 2008-10-30 | 362d | finish no earlier than 2008-10-30 | Wizinowich [28.4%]; Gavel [28.4%] | 50h | 5,520 |
| 260 | 1.3.3.9.1.2 | Risk Assessment v2 | 12d? | 2009-08-13 | 2009-08-28 | 146d | finish no earlier than 2009-08-28 | Wizinowich [31.2%]; Dekany [31.2%] | 50h | 5,042.8 |
| 261 | 1.3.3.9.2 | **Risk Mitigation Efforts** | 392d? | 2008-04-01 | 2009-09-30 | 123d |  |  | 656h | 33,496 |
| 262 | 1.3.3.9.2.1 | **PSF Calibration** | 100d? | 2008-09-15 | 2009-01-30 | 296d |  |  | 200h | 14,680 |
| 263 | 1.3.3.9.2.1.1 | Support/Monitor Profiler Implementation | 100d? | 2008-09-15 | 2009-01-30 | 296d | start no earlier than 2008-09-15 | Neyman [22.5%]; Wizinowich [2.5%] | 200h | 14,680 |
| 264 | 1.3.3.9.2.2 | **Sky Coverage** | 135d? | 2008-10-06 | 2009-04-10 | 246d |  |  | 400h | 12,480 |
| 265 | 1.3.3.9.2.2.1 | Prototype NIR Tip/tilt Sensor | 135d? | 2008-10-06 | 2009-04-10 | 246d | start no earlier than 2008-10-06 | COO ME [25%]; Velur [12%] | 400h | 12,480 |
| 266 | 1.3.3.9.2.3 | **On-Sky & Lab Demonstration Coordination** | 392d? | 2008-04-01 | 2009-09-30 | 123d |  |  | 56h | 6,336 |
| 267 | 1.3.3.9.2.3.1 | Define Demonstrations | 34d? | 2008-04-01 | 2008-08-29 | 406d |  | Gavel [4.4%]; Wizinowich [1.5%] | 16h | 1,856 |
| 268 | 1.3.3.9.2.3.2 | Analyze & Document Demonstration Results | 261d? | 2008-10-01 | 2009-09-30 | 123d | start no earlier than 2008-10-01 | Gavel [1%]; Wizinowich [1%] | 40h | 4,480 |
| 269 | 1.3.3.10 | Preliminary Design Manual | 101.67d? | 2009-08-03 | 2009-12-22 | 64.33d | start no earlier than 2009-08-03 | Wizinowich [9.8%]; Dekany [4.4%]; Gavel [2.2%]; Reinig [0.2%]; Velur [0.4%]; Neyman [0.2%]; Le Mignant [0.4%]; Johansson [0.4%]; Kupke [0.2%]; Lockwood [0.2%] | 120h | 12,217.8 |
| 270 | 1.3.4 | **AO System Design** | 425d? | 2008-05-12 | 2009-12-25 | 61d |  |  | 10725h | 738,405.77 |
| 271 | 1.3.4.1 | AO Enclosure | 130d? | 2008-10-01 | 2009-03-31 | 254d | finish no earlier than 2009-03-31 | Bell [28.8%] | 300h | 20,868 |
| 272 | 1.3.4.2 | **Opto-Mechanical** | 371d? | 2008-06-02 | 2009-11-02 | 100d |  |  | 5373h | 372,211.77 |
| 273 | 1.3.4.2.1 | AO Support Structure | 50d? | 2008-11-03 | 2009-01-09 | 311d | start no earlier than 2008-11-03 | Lockwood [36%]; Gavel [4%] | 160h | 17,616 |
| 274 | 1.3.4.2.2 | Rotator | 13d? | 2009-03-12 | 2009-03-30 | 255d | start no earlier than 2009-03-12 | Lockwood [86.5%]; Kupke [17.3%]; Gavel [11.5%] | 120h | 12,366 |
| 275 | 1.3.4.2.3 | Optical Relays | 80d? | 2008-12-29 | 2009-04-17 | 241d | start no earlier than 2008-12-28 | Lockwood [30.2%]; Kupke [45.3%]; Gavel [7.8%] | 533h | 45,017 |
| 276 | 1.3.4.2.4 | Optical Switchyard | 70d? | 2008-08-04 | 2008-11-07 | 356d | start no earlier than 2008-08-04 | Lockwood [38.6%]; Kupke [25.7%]; Gavel [7.1%] | 400h | 37,272 |

Notes:
- 249: CN
- 250: CN
- 251: CN
- 252: CN
- 253: EJ
- 254: EJ
- 255: EJ
- 256: EJ
- 257: PW
- 258: PW
- 259: PW
- 260: PW
- 261: PW
- 263: CN
- 265: VV
- 266: DG
- 267: DG
- 268: DG
- 269: PW
- 270: DG
- 271: JB
- 272: DG
- 273: CL
- 274: CL
- 275: RK
- 276: RK

| ID | WBS | Task | Duration | Start | Finish | Predecessors | Total slack | Free slack | Constraint | Resources | Work | Cost |
| --- | --- | --- | --- | --- | --- | --- | --- | --- | --- | --- | --- | --- |
| 277 | 1.3.4.2.5 | **LGS Wavefront Sensor Assembly** | 203d? | 2008-06-02 | 2009-03-11 |  | 268d |  |  |  | 1520h | 75,200.45 |
| 278 | 1.3.4.2.5.1 | Review concept design for LGS WFS assembly (includes OSM) | 20d? | 2008-06-02 | 2008-06-27 |  | 268d | 0d | start no earlier than 2008-06-02 | COO ME [50%]; Velur [25%] | 120h | 3,840 |
| 279 | 1.3.4.2.5.2 | Develop to preliminary design level the opto-mechanical design for the LGS wavefront sensor unit. | 70d? | 2008-06-30 | 2008-10-03 | 278 | 268d | 0d |  | COO ME [50%]; Velur [25%] | 420h | 13,440 |
| 280 | 1.3.4.2.5.3 | Identify the issues with uplink TTM, asterism generation and OSM concepts to ensure it conforms to the dithering requirements. This is important when the LGSs have to move with the source | 19.25d? | 2008-10-06 | 2008-10-31 | 279 | 268d | 0d |  | Velur [18.7%]; COO ME [50%] | 100h | 2,688.45 |
| 281 | 1.3.4.2.5.4 | Develop to preliminary design level the opto-mechanical design for the LGS OSM. (overlaps with TT(FA) OSMs; hence costed there) | 10d? | 2008-11-03 | 2008-11-14 | 280 | 268d | 0d | start no earlier than 2008-09-15 | COO ME [25%]; Velur [25%] | 40h | 1,920 |
| 282 | 1.3.4.2.5.5 | Package and model the assembly. | 20d? | 2008-11-17 | 2008-12-25 | 281 | 268d | 0d |  | COO ME [50%]; Velur [75%] | 200h | 11,520 |
| 283 | 1.3.4.2.5.6 | Develop background model and work out stray LGS light problems. | 13.33d? | 2008-12-25 | 2009-01-13 | 282 | 309.33d |  |  | Velur [75%] | 80h | 7,680 |
| 284 | 1.3.4.2.5.7 | Identify the motion control needs and specify solutions. | 20d? | 2008-12-25 | 2009-01-22 | 282 | 268d | 0d |  | Wetherell [50%]; Hale [50%]; Velur [50%] | 240h | 20,960 |
| 285 | 1.3.4.2.5.8 | Identify design risks and mitigation of the identified risks. | 4.67d? | 2009-01-22 | 2009-01-28 | 284 | 268d | 0d |  | COO ME [142%]; Velur [75%] | 80h | 2,592 |
| 286 | 1.3.4.2.5.9 | Develop a preliminary integration plan for the assembly. | 10d? | 2009-01-29 | 2009-02-11 | 285 | 268d | 0d |  | COO ME [62.5%]; Velur [40.9%] | 80h | 2,880 |
| 287 | 1.3.4.2.5.10 | LGS WFS Assembly Documentation | 20d? | 2009-02-12 | 2009-03-11 | 286 | 268d |  |  | COO ME [50%]; Velur [50%] | 160h | 7,680 |
| 288 | 1.3.4.2.6 | **NGS WFS/TWFS Assembly** | 143d? | 2009-04-16 | 2009-11-02 |  | 100d |  |  |  | 628h | 31,528 |
| 289 | 1.3.4.2.6.1 | Review concept design for NGS WFS and TWFS; jointly called NGS WFS assembly. | 10d? | 2009-04-16 | 2009-04-29 |  | 128.5d | 0d |  | COO ME [50%] | 40h |  |
| 290 | 1.3.4.2.6.2 | Develop to preliminary design level the opto-mechanical design for the NGS wavefront sensor assembly. | 28d? | 2009-04-30 | 2009-06-08 | 289 | 128.5d | 0d | start no earlier than 2009-01-19 | COO ME [44.6%]; Velur [44.6%] | 200h | 9,600 |
| 291 | 1.3.4.2.6.3 | Check compliance of design with the design of the field steering mirror assembly. | 14d? | 2009-06-09 | 2009-06-26 | 290 | 128.5d | 0d |  | Velur [44.6%]; COO ME [44.6%] | 100h | 4,800 |
| 292 | 1.3.4.2.6.4 | Package and model the NGS WFS assembly. | 18d? | 2009-06-29 | 2009-08-20 | 291 | 128.5d | 0d |  | COO ME [40.3%]; Velur [40.3%] | 116h | 5,568 |
| 293 | 1.3.4.2.6.5 | Identify the motion control needs and specify solutions. | 7d? | 2009-08-21 | 2009-08-31 | 292 | 128.5d | 0d |  | Hale [50%]; Wetherell [50%] | 56h | 4,648 |
| 294 | 1.3.4.2.6.6 | Identify design risks and mitigation of the identified risks. | 4.67d? | 2009-09-01 | 2009-09-07 | 293 | 128.5d | 0d |  | Velur [75%] | 28h | 2,688 |
| 295 | 1.3.4.2.6.7 | Check compliance with alignment plan for the NGS OSM (written as part of opto-mechanical relay sub-system design effort). | 4.83d? | 2009-09-07 | 2009-09-14 | 294 | 128.5d | 28.5d |  | COO ME [41.4%]; Velur [41.4%] | 32h | 1,536 |
| 296 | 1.3.4.2.6.8 | NGS WFS Assembly Documentation | 7d? | 2009-10-23 | 2009-11-02 | 295 | 100d |  | finish no earlier than 2009-11-02 | Velur [50%]; COO ME [50%] | 56h | 2,688 |
| 297 | 1.3.4.2.7 | **Low Order Wavefront Sensor Assembly** | 321d? | 2008-08-11 | 2009-11-02 |  | 100d |  |  |  | 1564h | 119,388.32 |
| 298 | 1.3.4.2.7.1 | Review concept design for LOWFS assembly. | 26.67d? | 2008-08-11 | 2008-09-16 |  | 148d | 0d | start no earlier than 2008-08-11 | COO ME [15%]; Hale [15%] | 64h | 3,072 |
| 299 | 1.3.4.2.7.2 | Investigate optimum method of dithering based on requirements. | 25.33d? | 2008-09-16 | 2008-10-21 | 298 | 148d | 2d |  | Hale [19.7%]; Velur [19.7%] | 80h | 7,680 |
| 300 | 1.3.4.2.7.3 | Develop to preliminary design level the opto-mechanical design for the tip-tilt and the TTFA-TWFS wavefront sensor units | 24d? | 2009-01-12 | 2009-02-12 | 299 | 147d | 0d |  | Hale [50%]; COO ME [50%]; Dekany [25%] | 240h | 13,830.72 |
| 301 | 1.3.4.2.7.4 | Develop to preliminary design level the opto-mechanical design for the LOWFS OSM | 13.33d? | 2009-02-13 | 2009-03-04 | 300 | 147d | 0d |  | Hale [75%]; COO ME [75%]; Velur [75%] | 240h | 15,360 |
| 302 | 1.3.4.2.7.5 | Make sure that the design doesn't preclude the inclusion of a PSF monitor later | 3.33d? | 2009-03-04 | 2009-03-09 | 301 | 147d | 0d |  | Velur [75%] | 20h | 1,920 |
| 303 | 1.3.4.2.7.6 | Package and model the assembly. | 13.33d? | 2009-03-09 | 2009-03-26 | 302 | 147d | 0d |  | COO ME [75%]; Velur [75%] | 160h | 7,680 |
| 304 | 1.3.4.2.7.7 | Develop thermal model and work emissivity details of the LOWFS assembly and feed into the overall emissivity budget | 10d? | 2009-03-27 | 2009-04-09 | 303 | 147d | 0d |  | Bouchez [50%] | 40h | 3,845.6 |
| 305 | 1.3.4.2.7.8 | Identify the motion control needs and specify solutions. | 60d? | 2009-04-10 | 2009-07-02 | 304 | 147d | 0d |  | Wetherell [25%]; Hale [25%]; Velur [25%] | 360h | 31,440 |
| 306 | 1.3.4.2.7.9 | Identify design risks and mitigation of the identified risks. | 10d? | 2009-07-03 | 2009-07-16 | 305 | 147d | 0d |  | Hale [50%]; Velur [50%] | 80h | 7,680 |
| 307 | 1.3.4.2.7.10 | Develop a preliminary integration plan for the assembly. | 13.33d? | 2009-07-17 | 2009-08-05 | 306 | 147d | 0d |  | Velur [75%] | 80h | 7,680 |
| 308 | 1.3.4.2.7.11 | Develop a test plan based on the design to test performance | 10d? | 2009-08-05 | 2009-08-19 | 307 | 147d | 47d |  | Hale [75%]; Velur [75%] | 120h | 11,520 |
| 309 | 1.3.4.2.7.12 | LOWFS Assembly Documentation | 6.67d? | 2009-10-23 | 2009-11-02 | 308 | 100d |  | finish no earlier than 2009-11-02 | Hale [75%]; Velur [75%] | 80h | 7,680 |

Notes:
- 277: VV
- 288: VV
- 297: VV

| ID | WBS | Task | Duration | Start | Finish | Total slack | Constraint | Resources | Work | Cost |
| --- | --- | --- | --- | --- | --- | --- | --- | --- | --- | --- |
| 310 | 1.3.4.2.8 | **Tip/Tilt Vibration Mitigation** | 40d? | 2008-07-07 | 2008-08-29 | 406d |  |  | 80h | 5,600 |
| 311 | 1.3.4.2.8.1 | TT Vibration Mitigation Analysis | 40d? | 2008-07-07 | 2008-08-29 | 406d | start no earlier than 2008-07-07 | Neyman [25%] | 80h | 5,600 |
| 312 | 1.3.4.2.9 | **Acquisition Cameras** | 305d? | 2008-09-01 | 2009-10-30 | 101d |  |  | 128h | 9,584 |
| 313 | 1.3.4.2.9.1 | Implementation Issues | 20d? | 2008-09-01 | 2008-09-26 | 386d | start no earlier than 2008-09-01 | Neyman [12.5%]; Le Mignant [12.5%] | 40h | 2,800 |
| 314 | 1.3.4.2.9.2 | Opto-Mechanical Design | 20d? | 2009-10-01 | 2009-10-30 | 101d | start no earlier than 2009-10-01 | Neyman [35%]; Panteleev [10%]; Lockwood [10%] | 88h | 6,784 |
| 315 | 1.3.4.2.10 | **Atmospheric Dispersion Correctors** | 96d? | 2008-10-17 | 2009-02-27 | 276d |  |  | 240h | 18,640 |
| 316 | 1.3.4.2.10.1 | LOWFS ADCs | 10d? | 2008-10-17 | 2008-10-30 | 362d | finish no earlier than 2008-10-30 | Kupke; Lockwood [75%] | 140h | 11,500 |
| 317 | 1.3.4.2.10.2 | NIR Science ADC | 5d? | 2008-12-24 | 2008-12-30 | 319d | finish no earlier than 2008-12-30 | Kupke; Lockwood [25%] | 50h | 3,570 |
| 318 | 1.3.4.2.10.3 | Visible Science & NGS WFS ADC | 5d? | 2009-02-23 | 2009-02-27 | 276d | finish no earlier than 2009-02-27 | Kupke; Lockwood [25%] | 50h | 3,570 |
| 319 | 1.3.4.3 | **Alignment, Calibration & Diagnostics** | 90d? | 2009-02-02 | 2009-06-05 | 206d |  |  | 505h | 38,788 |
| 320 | 1.3.4.3.1 | **Simulator** | 45d? | 2009-02-02 | 2009-04-03 | 251d |  |  | 250h | 19,178 |
| 321 | 1.3.4.3.1.1 | Simulator Requirements & Interfaces | 10d? | 2009-02-02 | 2009-02-13 | 286d | finish no earlier than 2009-02-13 | Neyman [50%]; Wizinowich [12.5%] | 50h | 3,840 |
| 322 | 1.3.4.3.1.2 | Simulator Optical Design | 10d? | 2009-02-16 | 2009-02-27 | 276d | finish no earlier than 2009-02-27 | Neyman [12.5%]; Wizinowich [50%] | 50h | 4,860 |
| 323 | 1.3.4.3.1.3 | Simulator Mechanical Design | 10d? | 2009-03-02 | 2009-03-13 | 266d | finish no earlier than 2009-03-13 | Neyman [12.5%]; Bell [62.5%] | 60h | 4,178 |
| 324 | 1.3.4.3.1.4 | Simulator Electrical Design | 10d? | 2009-03-09 | 2009-03-20 | 261d | finish no earlier than 2009-03-20 | Neyman [25%]; Wetherell [37.5%] | 50h | 3,500 |
| 325 | 1.3.4.3.1.5 | Simulator Assembly, Alignment & Test Plans | 10d? | 2009-03-23 | 2009-04-03 | 251d | start no earlier than 2009-03-23 | Neyman [50%] | 40h | 2,800 |
| 326 | 1.3.4.3.2 | **System Alignment Tools** | 45d? | 2009-04-06 | 2009-06-05 | 206d |  |  | 255h | 19,610 |
| 327 | 1.3.4.3.2.1 | Alignment Requirements & Interfaces | 10d? | 2009-04-06 | 2009-04-17 | 241d | finish no earlier than 2009-04-17 | Neyman [50%]; Kupke [12.5%]; Wizinowich [12.5%] | 60h | 4,460 |
| 328 | 1.3.4.3.2.2 | Alignment Optical Design | 10d? | 2009-04-20 | 2009-05-01 | 231d | finish no earlier than 2009-05-01 | Neyman [12.5%]; Kupke [50%] | 50h | 3,180 |
| 329 | 1.3.4.3.2.3 | Alignment Mechanical Design | 10d? | 2009-05-04 | 2009-05-15 | 221d | finish no earlier than 2009-05-15 | Neyman [12.5%]; Lockwood [50%] | 50h | 5,060 |
| 330 | 1.3.4.3.2.4 | Alignment Electrical Design | 10d? | 2009-05-11 | 2009-05-22 | 216d | finish no earlier than 2009-05-22 | Neyman [25%]; Wetherell [18.8%] | 35h | 2,450 |
| 331 | 1.3.4.3.2.5 | Alignment Assembly, Alignment & Test Plans | 10d? | 2009-05-25 | 2009-06-05 | 206d | finish no earlier than 2009-06-05 | Neyman [50%]; Kupke [12.5%]; Wizinowich [12.5%] | 60h | 4,460 |
| 332 | 1.3.4.4 | **Non-real-time Control** | 130d? | 2009-01-19 | 2009-07-17 | 176d |  |  | 990h | 59,500 |
| 333 | 1.3.4.4.1 | AO Controls Infrastructure | 1d? | 2009-02-02 | 2009-02-02 | 295d | start no earlier than 2009-02-02 |  |  |  |

Notes:
- 310: CN
- 312: CN
- 315: RK
- 319: CN
- 320: CN
- 326: CN
- 332: EJ

| ID | WBS | Task | Type | Duration | Start | Finish | Total slack | Constraint | Resources | Work | Cost |
| --- | --- | --- | --- | --- | --- | --- | --- | --- | --- | --- | --- |
| 334 | 1.3.4.4.2 | **AO Sequencer** |  | 20d? | 2009-02-02 | 2009-02-27 | 276d |  |  | 140h | 9,800 |
| 335 | 1.3.4.4.2.1 | AO Sequencer: Architecture |  | 15d? | 2009-02-02 | 2009-02-20 | 281d | start no earlier than 2009-02-02 | Johansson [50%]; Morrison [16.7%] | 80h | 5,600 |
| 336 | 1.3.4.4.2.2 | AO Sequencer: Interface Control Document |  | 20d? | 2009-02-02 | 2009-02-27 | 276d | finish no earlier than 2009-02-27 | Johansson [12.5%] | 20h | 1,400 |
| 337 | 1.3.4.4.2.3 | AO Sequencer: Software Module Design |  | 20d? | 2009-02-02 | 2009-02-27 | 276d | start no earlier than 2009-02-02 | Johansson [9.4%]; Morrison [9.4%] | 30h | 2,100 |
| 338 | 1.3.4.4.2.4 | AO Sequencer: User Interface Design | milestone | 0d? | 2009-02-02 | 2009-02-02 | 296d | start no earlier than 2009-02-02 |  |  |  |
| 339 | 1.3.4.4.2.5 | AO Sequencer: Technical Specifications | milestone | 0d? | 2009-02-02 | 2009-02-02 | 296d | start no earlier than 2009-02-02 |  |  |  |
| 340 | 1.3.4.4.2.6 | AO Sequencer: Compliance Matrix | milestone | 0d? | 2009-02-02 | 2009-02-02 | 296d | start no earlier than 2009-02-02 |  |  |  |
| 341 | 1.3.4.4.2.7 | AO Sequencer: Test Plan | milestone | 0d? | 2009-02-02 | 2009-02-02 | 296d | start no earlier than 2009-02-02 |  |  |  |
| 342 | 1.3.4.4.2.8 | AO Sequencer: Summary Report |  | 20d? | 2009-02-02 | 2009-02-27 | 276d | finish no earlier than 2009-02-27 | Johansson [6.2%] | 10h | 700 |
| 343 | 1.3.4.4.3 | **AO Motion Control Software** |  | 40d? | 2009-03-02 | 2009-04-24 | 236d |  |  | 230h | 16,100 |
| 344 | 1.3.4.4.3.1 | Motion Control SW: Architecture |  | 40d? | 2009-03-02 | 2009-04-24 | 236d | start no earlier than 2009-03-02 | Johansson [15.6%]; Morrison [9.4%] | 80h | 5,600 |
| 345 | 1.3.4.4.3.2 | Motion Control SW: ICD |  | 40d? | 2009-03-02 | 2009-04-24 | 236d | start no earlier than 2009-03-02 | Johansson [6.2%]; Morrison [6.2%] | 40h | 2,800 |
| 346 | 1.3.4.4.3.3 | Motion Control SW: Module Design |  | 40d? | 2009-03-02 | 2009-04-24 | 236d | start no earlier than 2009-03-02 | Johansson [6.2%]; Morrison [21.9%] | 90h | 6,300 |
| 347 | 1.3.4.4.3.4 | Motion Control SW: User Interface Design | milestone | 0d? | 2009-03-02 | 2009-03-02 | 276d | start no earlier than 2009-03-02 |  |  |  |
| 348 | 1.3.4.4.3.5 | Motion Control SW: Technical Specifications | milestone | 0d? | 2009-03-02 | 2009-03-02 | 276d | start no earlier than 2009-03-02 |  |  |  |
| 349 | 1.3.4.4.3.6 | Motion Control SW: Compliance Matrix | milestone | 0d? | 2009-03-02 | 2009-03-02 | 276d | start no earlier than 2009-03-02 |  |  |  |
| 350 | 1.3.4.4.3.7 | Motion Control SW: Test Plan | milestone | 0d? | 2009-03-02 | 2009-03-02 | 276d | start no earlier than 2009-03-02 |  |  |  |
| 351 | 1.3.4.4.3.8 | Motion Control SW: Summary Report |  | 40d? | 2009-03-02 | 2009-04-24 | 236d | finish no earlier than 2009-04-24 | Johansson [6.2%] | 20h | 1,400 |
| 352 | 1.3.4.4.4 | **AO Device Control Software** |  | 55d? | 2009-05-04 | 2009-07-17 | 176d |  |  | 240h | 16,800 |
| 353 | 1.3.4.4.4.1 | Device Control: Software Architecture |  | 20d? | 2009-05-04 | 2009-05-29 | 211d | finish no earlier than 2009-05-29 | Morrison [50%] | 80h | 5,600 |
| 354 | 1.3.4.4.4.2 | Device Control: Interface Control Document |  | 15d? | 2009-05-25 | 2009-06-12 | 201d | finish no earlier than 2009-06-12 | Morrison [33.3%] | 40h | 2,800 |
| 355 | 1.3.4.4.4.3 | Device Control: Software Module Design |  | 25d? | 2009-06-15 | 2009-07-17 | 176d | finish no earlier than 2009-07-17 | Morrison [50%] | 100h | 7,000 |
| 356 | 1.3.4.4.4.4 | Device Control: User Interface Design | milestone | 0d? | 2009-06-15 | 2009-06-15 | 201d | start no earlier than 2009-06-15 |  |  |  |
| 357 | 1.3.4.4.4.5 | Device Control: Technical Specifications | milestone | 0d? | 2009-06-15 | 2009-06-15 | 201d | start no earlier than 2009-06-15 |  |  |  |
| 358 | 1.3.4.4.4.6 | Device Control: Compliance Matrix | milestone | 0d? | 2009-06-15 | 2009-06-15 | 201d | start no earlier than 2009-06-15 |  |  |  |
| 359 | 1.3.4.4.4.7 | Device Control: Test Plan | milestone | 0d? | 2009-06-15 | 2009-06-15 | 201d | start no earlier than 2009-06-15 |  |  |  |
| 360 | 1.3.4.4.4.8 | Device Control: Summary Report |  | 25d? | 2009-06-15 | 2009-07-17 | 176d | finish no earlier than 2009-07-17 | Morrison [10%] | 20h | 1,400 |

Notes:
- 334: EJ
- 343: EJ
- 352: DM

| ID | WBS | Task | Type | Duration | Start | Finish | Total slack | Constraint | Resources | Work | Cost |
| --- | --- | --- | --- | --- | --- | --- | --- | --- | --- | --- | --- |
| 361 | 1.3.4.4.5 | **AO Motion Control Electronics** |  | 30d? | 2009-01-19 | 2009-02-27 | 276d |  |  | 60h | 4,200 |
| 362 | 1.3.4.4.5.1 | Motion Control HW: Spreadsheet |  | 30d? | 2009-01-19 | 2009-02-27 | 276d | finish no earlier than 2009-02-27 | Wetherell [25%] | 60h | 4,200 |
| 363 | 1.3.4.4.6 | **Non-RTC Electronics** |  | 40d? | 2009-04-06 | 2009-05-29 | 211d |  |  | 160h | 11,200 |
| 364 | 1.3.4.4.6.1 | Non-RTC Electronics: Architecture |  | 40d? | 2009-04-06 | 2009-05-29 | 211d | finish no earlier than 2009-05-29 | Wetherell [25%] | 80h | 5,600 |
| 365 | 1.3.4.4.6.2 | Non-RTC Electronics: Selection/Specification |  | 40d? | 2009-04-06 | 2009-05-29 | 211d | start no earlier than 2009-04-06 | Wetherell [18.8%] | 60h | 4,200 |
| 366 | 1.3.4.4.6.3 | Non-RTC Electronics: Compliance Matrix |  | 1d? | 2009-04-06 | 2009-04-06 | 250d | start no earlier than 2009-04-06 |  |  |  |
| 367 | 1.3.4.4.6.4 | Non-RTC Electronics: Test Plan |  | 1d? | 2009-04-06 | 2009-04-06 | 250d | start no earlier than 2009-04-06 |  |  |  |
| 368 | 1.3.4.4.6.5 | Non-RTC Electronics: Documentation |  | 40d? | 2009-04-06 | 2009-05-29 | 211d | start no earlier than 2009-04-06 | Wetherell [6.2%] | 20h | 1,400 |
| 369 | 1.3.4.4.7 | **Non-RTC Lab System Integration & Test** |  | 0d? | 2009-02-02 | 2009-02-02 | 296d |  |  |  |  |
| 370 | 1.3.4.4.7.1 | Non-RTC I&T: Architecture | milestone | 0d? | 2009-02-02 | 2009-02-02 | 296d | start no earlier than 2009-02-02 |  |  |  |
| 371 | 1.3.4.4.7.2 | Non-RTC I&T: Electronics Specification & Selection | milestone | 0d? | 2009-02-02 | 2009-02-02 | 296d | start no earlier than 2009-02-02 |  |  |  |
| 372 | 1.3.4.4.7.3 | Non-RTC I&T: Test Plan | milestone | 0d? | 2009-02-02 | 2009-02-02 | 296d | start no earlier than 2009-02-02 |  |  |  |
| 373 | 1.3.4.4.7.4 | Non-RTC I&T: Summary Report | milestone | 0d? | 2009-02-02 | 2009-02-02 | 296d | start no earlier than 2009-02-02 |  |  |  |
| 374 | 1.3.4.4.8 | **Acquisition, Guiding & Offload (AGO) Control** |  | 47d? | 2009-04-27 | 2009-06-30 | 189d |  |  | 160h | 1,400 |
| 375 | 1.3.4.4.8.1 | AGO: Architecture |  | 47d? | 2009-04-27 | 2009-06-30 | 189d | finish no earlier than 2009-06-30 | Stomski [16%]; Le Mignant | 80h | 1,400 |
| 376 | 1.3.4.4.8.2 | AGO: ICD |  | 47d? | 2009-04-27 | 2009-06-30 | 189d | start no earlier than 2009-04-27 | Stomski [10.6%] | 40h |  |
| 377 | 1.3.4.4.8.3 | AGO: Software Module Design |  | 47d? | 2009-04-27 | 2009-06-30 | 189d | start no earlier than 2009-04-27 | Stomski [5.3%] | 20h |  |
| 378 | 1.3.4.4.8.4 | AGO: User Interface | milestone | 0d? | 2009-04-27 | 2009-04-27 | 236d | start no earlier than 2009-04-27 |  |  |  |
| 379 | 1.3.4.4.8.5 | AGO: Technical Specification | milestone | 0d? | 2009-04-27 | 2009-04-27 | 236d | start no earlier than 2009-04-27 |  |  |  |
| 380 | 1.3.4.4.8.6 | AGO: Compliance Matrix | milestone | 0d? | 2009-04-27 | 2009-04-27 | 236d | start no earlier than 2009-04-27 |  |  |  |
| 381 | 1.3.4.4.8.7 | AGO: Test Plan | milestone | 0d? | 2009-04-27 | 2009-04-27 | 236d | start no earlier than 2009-04-27 |  |  |  |
| 382 | 1.3.4.4.8.8 | AGO: Summary Report |  | 47d? | 2009-04-27 | 2009-06-30 | 189d | finish no earlier than 2009-06-30 | Stomski [5.3%] | 20h |  |
| 383 | 1.3.4.5 | **Real-time Control** |  | 425d? | 2008-05-12 | 2009-12-25 | 61d |  |  | 3357h | 232,494 |
| 384 | 1.3.4.5.1 | **RTC Processor** |  | 425d? | 2008-05-12 | 2009-12-25 | 61d |  |  | 3037h | 196,994 |
| 385 | 1.3.4.5.1.1 | RTC Technical Management |  | 3400h? | 2008-05-12 | 2009-12-25 | 61d | start no earlier than 2008-05-12 | Reinig [9.2%]; Gavel [4.4%] | 463h | 37,406 |
| 386 | 1.3.4.5.1.2 | Centroid/Wavefront Reconstruction Processing Requirements |  | 105d? | 2008-05-12 | 2008-10-03 | 381d | start no earlier than 2008-05-12 | Electrical Engineer / Programmer [37.4%] | 314h | 19,468 |
| 387 | 1.3.4.5.1.3 | Centroid/Wavefront Reconstruction Test Definition |  | 47d? | 2008-09-08 | 2008-11-11 | 354d | start no earlier than 2008-09-08 | Electrical Engineer / Programmer [23.9%] | 90h | 5,580 |
| 388 | 1.3.4.5.1.4 | Preconditioning & Scaling Processing Requirements |  | 75d? | 2008-10-06 | 2009-01-16 | 306d | start no earlier than 2008-10-06 | Electrical Engineer / Programmer [51.7%] | 310h | 19,220 |
| 389 | 1.3.4.5.1.5 | Preconditioning & Scaling Processing Test Definition |  | 30d? | 2008-12-29 | 2009-02-06 | 291d | start no earlier than 2008-12-28 | Electrical Engineer / Programmer [37.5%] | 90h | 5,580 |
| 390 | 1.3.4.5.1.6 | Low Order WFS Processing Requirements |  | 65d? | 2009-02-09 | 2009-05-08 | 226d | start no earlier than 2009-02-08 | Electrical Engineer / Programmer [59.6%] | 310h | 19,220 |
| 391 | 1.3.4.5.1.7 | Low Order WFS Processing Test Definition |  | 11.25d? | 2009-05-18 | 2009-06-02 | 209.75d | start no earlier than 2009-05-17 | Electrical Engineer / Programmer | 90h | 5,580 |
| 392 | 1.3.4.5.1.8 | Layer Combining & DM Processing Requirements |  | 41d? | 2009-06-01 | 2009-07-27 | 170d | start no earlier than 2009-05-31 | Electrical Engineer / Programmer [94.5%] | 310h | 19,220 |
| 393 | 1.3.4.5.1.9 | Camera Data Transfer Issues |  | 24.19d? | 2009-07-27 | 2009-08-28 | 146.81d | start no earlier than 2009-07-26 | Electrical Engineer / Programmer [46.5%] | 90h | 5,580 |
| 394 | 1.3.4.5.1.10 | Radial versus Rectilinear Voxels Trade Study |  | 73d? | 2008-11-03 | 2009-02-11 | 288d | start no earlier than 2008-11-03 | Electrical Engineer / Programmer [37.7%] | 220h | 13,640 |
| 395 | 1.3.4.5.1.11 | Define Required Bit Resolution |  | 22d? | 2008-05-19 | 2008-06-17 | 459d | start no earlier than 2008-05-18 | Electrical Engineer / Programmer [36.9%] | 65h | 4,030 |
| 396 | 1.3.4.5.1.12 | Characterize Single Event Upset |  | 30d? | 2009-08-24 | 2009-10-02 | 121d | start no earlier than 2009-08-23 | Electrical Engineer / Programmer [27.1%] | 65h | 4,030 |
| 397 | 1.3.4.5.1.13 | Power Characterization and Parameter Estimation |  | 11.25d? | 2009-10-05 | 2009-10-20 | 109.75d | start no earlier than 2009-10-04 | Electrical Engineer / Programmer | 90h | 5,580 |
| 398 | 1.3.4.5.1.14 | Voxel Communication Parameters |  | 11.25d? | 2009-11-30 | 2009-12-15 | 69.75d | start no earlier than 2009-11-30 | Electrical Engineer / Programmer | 90h | 5,580 |
| 399 | 1.3.4.5.1.15 | Diagnostic Control & I/O Requirements |  | 30d? | 2009-02-02 | 2009-03-13 | 266d | start no earlier than 2009-02-02 | Electrical Engineer / Programmer [45.8%] | 110h | 6,820 |
| 400 | 1.3.4.5.1.16 | Monitoring Control & I/O Requirements |  | 40d? | 2009-10-12 | 2009-12-04 | 76d | start no earlier than 2009-10-11 | Electrical Engineer / Programmer [34.4%] | 110h | 6,820 |
| 401 | 1.3.4.5.1.17 | Define Testing Procedures |  | 45d? | 2008-09-29 | 2008-11-28 | 341d | start no earlier than 2008-09-28 | Electrical Engineer / Programmer [25%] | 90h | 5,580 |
| 402 | 1.3.4.5.1.18 | Documentation |  | 140d? | 2009-06-08 | 2009-12-18 | 66d | start no earlier than 2009-06-08 | Electrical Engineer / Programmer [11.6%] | 130h | 8,060 |

Notes:
- 361: EW
- 363: EW
- 374: EJ
- 383: DG
- 384: DG
- 385: MR

| ID | WBS | Task | Duration | Start | Finish | Total slack | Constraint | Resources | Work | Cost |
| --- | --- | --- | --- | --- | --- | --- | --- | --- | --- | --- |
| 403 | 1.3.4.5.2 | **DMs & Tip/Tilt Stages** | 105d? | 2008-10-06 | 2009-02-27 | 276d |  |  | 320h | 35,500 |
| 404 | 1.3.4.5.2.1 | **Woofer DM/TT** | 105d? | 2008-10-06 | 2009-02-27 | 276d |  |  | 132h | 14,828 |
| 405 | 1.3.4.5.2.1.1 | Define Requirements | 20d? | 2008-10-06 | 2008-10-31 | 361d | start no earlier than 2008-10-06 | Gavel [10%] | 16h | 1,920 |
| 406 | 1.3.4.5.2.1.2 | Evaluate Tip/Tilt Mount Options | 30d? | 2008-12-01 | 2009-01-09 | 311d | finish no earlier than 2009-01-09 | Lockwood [16.7%]; Gavel [50%] | 44h | 4,840 |
| 407 | 1.3.4.5.2.1.3 | Evaluate Combined DM & Tip/Tilt Performance | 10d? | 2009-01-12 | 2009-01-23 | 301d | finish no earlier than 2009-01-23 | Gavel [20%] | 16h | 1,920 |
| 408 | 1.3.4.5.2.1.4 | Select Tip/Tilt Mount | 5d? | 2009-01-26 | 2009-01-30 | 296d | finish no earlier than 2009-01-30 | Gavel [10%]; Lockwood | 8h | 916 |
| 409 | 1.3.4.5.2.1.5 | Design Mechanical Package | 10d? | 2009-02-16 | 2009-02-27 | 276d | finish no earlier than 2009-02-27 | Lockwood [50%] | 40h | 4,360 |
| 410 | 1.3.4.5.2.1.6 | Obtain Quotes | 20d? | 2009-01-05 | 2009-01-30 | 296d | finish no earlier than 2009-01-30 | Lockwood [5%] | 8h | 872 |
| 411 | 1.3.4.5.2.2 | **Tweeter DM/TT** | 95d? | 2008-10-06 | 2009-02-13 | 286d |  |  | 48h | 5,452 |
| 412 | 1.3.4.5.2.2.1 | Define Requirements | 20d? | 2008-10-06 | 2008-10-31 | 361d | finish no earlier than 2008-10-31 | Gavel [5%] | 8h | 960 |
| 413 | 1.3.4.5.2.2.2 | Evaluate Options & Select Tip/Tilt Mount | 20d? | 2008-11-03 | 2008-11-28 | 341d | finish no earlier than 2008-11-28 | Lockwood [12.5%]; Gavel [50%] | 28h | 3,140 |
| 414 | 1.3.4.5.2.2.3 | Design Mechanical Package | 10d? | 2009-02-02 | 2009-02-13 | 286d | finish no earlier than 2009-02-13 | Lockwood [10%] | 8h | 872 |
| 415 | 1.3.4.5.2.2.4 | Obtain Quotes | 20d? | 2008-11-03 | 2008-11-28 | 341d | finish no earlier than 2008-11-28 | Gavel [2.5%] | 4h | 480 |
| 416 | 1.3.4.5.2.3 | **LOWFS DM/TT** | 95d? | 2008-10-06 | 2009-02-13 | 286d |  |  | 140h | 15,220 |
| 417 | 1.3.4.5.2.3.1 | Define Requirements including LOWFS Interface | 20d? | 2008-10-06 | 2008-10-31 | 361d | finish no earlier than 2008-10-31 | Gavel [50%]; Velur [12.5%] | 28h | 2,880 |
| 418 | 1.3.4.5.2.3.2 | Evaluate Options & Select Tip/Tilt Mount | 20d? | 2008-11-03 | 2008-11-28 | 341d | finish no earlier than 2008-11-28 | Lockwood [12.5%]; Gavel [50%] | 28h | 3,140 |
| 419 | 1.3.4.5.2.3.3 | Design Mechanical Package | 25d? | 2009-01-12 | 2009-02-13 | 286d | finish no earlier than 2009-02-13 | Lockwood [40%] | 80h | 8,720 |
| 420 | 1.3.4.5.2.3.4 | Obtain Quotes | 20d? | 2008-11-03 | 2008-11-28 | 341d | finish no earlier than 2008-11-28 | Gavel [2.5%] | 4h | 480 |
| 421 | 1.3.4.6 | **AO System Lab I&T** | 40d? | 2009-07-06 | 2009-08-28 | 146d |  |  | 200h | 14,544 |
| 422 | 1.3.4.6.1 | AO System Lab I&T Scope Definition | 10d? | 2009-07-06 | 2009-07-17 | 176d | finish no earlier than 2009-07-17 | Wizinowich [20%] | 16h | 1,664 |
| 423 | 1.3.4.6.2 | AO System Lab Facility Plan | 30d? | 2009-07-20 | 2009-08-28 | 146d | finish no earlier than 2009-08-28 | Neyman [10%] | 24h | 1,680 |
| 424 | 1.3.4.6.3 | AO System Lab Integration Plan | 30d? | 2009-07-20 | 2009-08-28 | 146d | finish no earlier than 2009-08-28 | Neyman [33.3%] | 80h | 5,600 |
| 425 | 1.3.4.6.4 | AO System Lab Test Plan | 25d? | 2009-07-27 | 2009-08-28 | 146d | finish no earlier than 2009-08-28 | Neyman [40%] | 80h | 5,600 |
| 426 | 1.3.5 | **Laser System Design** | 390d? | 2008-05-05 | 2009-10-30 | 101d |  |  | 2964h | 224,074 |
| 427 | 1.3.5.1 | **Laser Enclosure (LE)** | 40d? | 2009-01-19 | 2009-03-13 | 266d |  |  | 160h | 11,200 |
| 428 | 1.3.5.1.1 | LE Requirements & Interfaces | 20d? | 2009-01-19 | 2009-02-13 | 286d | finish no earlier than 2009-02-13 | Chin [12.5%]; Medeiros [12.5%] | 40h | 2,800 |
| 429 | 1.3.5.1.2 | LE Mechanical Design | 10d? | 2009-02-16 | 2009-02-27 | 276d | finish no earlier than 2009-02-27 | Chin; Medeiros [50%] | 50h | 3,500 |
| 430 | 1.3.5.1.3 | LE Environmental Control Design | 10d? | 2009-02-16 | 2009-02-27 | 276d | finish no earlier than 2009-02-27 | Chin; Nance [50%] | 50h | 3,500 |
| 431 | 1.3.5.1.4 | LE Assembly & Test Plans | 10d? | 2009-03-02 | 2009-03-13 | 266d | finish no earlier than 2009-03-13 | Chin; Nance [10%]; Medeiros [10%] | 20h | 1,400 |

Notes:
- 403: DG
- 404: DG
- 411: DG
- 416: DG
- 421: CN
- 422: PW
- 423: CN
- 424: CN
- 425: CN
- 426: CN
- 427: JC
- 428: JC
- 429: DM
- 430: CN
- 431: JC

| ID | WBS | Task | Duration | Start | Finish | Predecessors | Total slack | Free slack | Constraint | Resources | Work | Cost |
| --- | --- | --- | --- | --- | --- | --- | --- | --- | --- | --- | --- | --- |
| 432 | 1.3.5.2 | **Laser** | 280d? | 2008-05-05 | 2009-05-29 |  | 211d |  |  |  | 820h | 73,994 |
| 433 | 1.3.5.2.1 | Laser Project Management | 280d? | 2008-05-05 | 2009-05-29 |  | 211d |  | finish no earlier than 2009-05-29 | Adkins [6.7%]; Kissner [6.7%] | 300h | 22,650 |
| 434 | 5.2.3.1 | **Laser Requirements** | 110d | 2008-05-05 | 2008-10-03 |  | 211d |  |  |  | 160h | 16,640 |
| 435 | 5.2.3.1.1 | Laser Performance Analysis | 20d | 2008-05-05 | 2008-05-30 |  | 211d | 0d | start no earlier than 2008-05-05 | Adkins [25%] | 40h | 4,160 |
| 436 | 5.2.3.1.2 | Laser Requirements Analysis | 20d | 2008-06-02 | 2008-06-27 | 435 | 211d | 0d |  | Adkins [25%] | 40h | 4,160 |
| 437 | 5.2.3.1.3 | Laser Requirements Development | 20d | 2008-06-30 | 2008-07-25 | 436 | 211d | 0d |  | Adkins [25%] | 40h | 4,160 |
| 438 | 5.2.3.1.4 | Laser Requirements Drafting and Revisions | 50d | 2008-07-28 | 2008-10-03 | 437 | 211d | 0d |  | Adkins [10%] | 40h | 4,160 |
| 439 | 5.2.3.2 | **Laser Preliminary ICD** | 20d | 2008-07-28 | 2008-08-22 |  | 411d |  |  |  | 40h | 4,160 |
| 440 | 5.2.3.2.1 | Laser ICD Drafting and Revisions | 20d | 2008-07-28 | 2008-08-22 | 437 | 411d |  |  | Adkins [25%] | 40h | 4,160 |
| 441 | 5.2.3.3 | **Laser Request for Proposals (RFP)** | 90d | 2008-10-06 | 2009-02-06 |  | 211d |  |  |  | 120h | 9,744 |
| 442 | 5.2.3.3.1 | Laser Proposal Drafting | 20d | 2008-10-06 | 2008-10-31 | 438 | 211d | 0d |  | Adkins [25%] | 40h | 4,160 |
| 443 | 5.2.3.3.2 | Laser Proposal Release | 10d | 2008-11-03 | 2008-11-14 | 442 | 211d | 0d |  | Adkins [25%]; Kissner [30%] | 40h | 2,792 |
| 444 | 5.2.3.3.3 | Laser Proposal Response Period | 3mo | 2008-11-17 | 2009-02-06 | 443 | 211d | 0d |  | Adkins [3.3%]; Kissner [5%] | 40h | 2,792 |
| 445 | 5.2.3.4 | **Laser RFP Response Report** | 40d | 2009-02-09 | 2009-04-03 |  | 211d |  |  |  | 120h | 12,480 |
| 446 | 5.2.3.4.1 | Laser Proposal Evaluation | 20d | 2009-02-09 | 2009-03-06 | 444 | 211d | 0d |  | Adkins [25%] | 40h | 4,160 |
| 447 | 5.2.3.4.2 | Laser Response Discussions | 20d | 2009-03-09 | 2009-04-03 | 446 | 251d |  |  | Adkins [25%] | 40h | 4,160 |
| 448 | 5.2.3.4.3 | Laser Report Drafting and Revisions | 20d | 2009-03-09 | 2009-04-03 | 446 | 211d | 0d |  | Adkins [25%] | 40h | 4,160 |
| 449 | 5.2.3.5 | **Laser Contract** | 40d | 2009-04-06 | 2009-05-29 |  | 211d |  |  |  | 80h | 8,320 |
| 450 | 5.2.3.5.1 | Laser Contract Drafting and Revisions | 20d | 2009-04-06 | 2009-05-01 | 448 | 211d | 0d |  | Adkins [25%] | 40h | 4,160 |
| 451 | 5.2.3.5.2 | Laser Contract Negotiations | 20d | 2009-05-04 | 2009-05-29 | 450 | 211d |  |  | Adkins [25%] | 40h | 4,160 |
| 452 | 1.3.5.3 | **Laser Launch Facility (LLF)** | 170d? | 2009-01-19 | 2009-09-11 |  | 136d |  |  |  | 856h | 59,920 |
| 453 | 1.3.5.3.1 | LLF Requirements & Interfaces | 20d? | 2009-01-19 | 2009-02-13 |  | 286d |  | finish no earlier than 2009-02-13 | Neyman [50%]; Chin | 100h | 7,000 |
| 454 | 1.3.5.3.2 | LLF Optical Design | 53d? | 2009-04-01 | 2009-06-12 |  | 201d |  | finish no earlier than 2009-06-12 | Neyman [14.2%]; Panteleev [47.2%] | 260h | 18,200 |
| 455 | 1.3.5.3.3 | LLF Launch Telescope Preliminary Design Contract | 100d? | 2009-03-16 | 2009-07-31 |  | 166d |  | start no earlier than 2009-03-16 | Neyman [9%]; Chin [3%] | 96h | 6,720 |
| 456 | 1.3.5.3.4 | LLF Mechanical Design | 45d? | 2009-06-01 | 2009-07-31 |  | 166d |  | finish no earlier than 2009-07-31 | Neyman; Medeiros [55.6%] | 220h | 15,400 |
| 457 | 1.3.5.3.5 | LLF Electrical Design | 30d? | 2009-07-20 | 2009-08-28 |  | 146d |  | start no earlier than 2009-07-20 | Neyman [8.3%]; Chin [41.7%] | 120h | 8,400 |
| 458 | 1.3.5.3.6 | LLF Assembly, Alignment & Test Plans | 10d? | 2009-08-31 | 2009-09-11 |  | 136d |  | finish no earlier than 2009-09-11 | Neyman [62.5%]; Chin | 60h | 4,200 |

Notes:
- 432: SA
- 433: SA
- 434: SA
- 439: SA
- 441: SA
- 445: SA
- 449: SA
- 452: CN

| ID | WBS | Task | Duration | Start | Finish | Total slack | Constraint | Resources | Work | Cost |
| --- | --- | --- | --- | --- | --- | --- | --- | --- | --- | --- |
| 459 | 1.3.5.4 | **Laser Safety Systems** | 65d? | 2009-08-03 | 2009-10-30 | 101d |  |  | 170h | 11,900 |
| 460 | 1.3.5.4.1 | **Personnel & Equipment Safety System** | 43d? | 2009-08-03 | 2009-09-30 | 123d |  |  | 130h | 9,100 |
| 461 | 1.3.5.4.1.1 | Safety Requirements & Interfaces | 10d? | 2009-08-03 | 2009-08-14 | 156d | start no earlier than 2009-08-03 | Chin [50%] | 40h | 2,800 |
| 462 | 1.3.5.4.1.2 | Safety Algorithms, Diagrams & Dataflow | 33d? | 2009-08-17 | 2009-09-30 | 123d | start no earlier than 2009-08-17 | Chin [7.6%] | 20h | 1,400 |
| 463 | 1.3.5.4.1.3 | Safety Communication Protocols & Methods | 33d? | 2009-08-17 | 2009-09-30 | 123d | start no earlier than 2009-08-17 | Chin [7.6%] | 20h | 1,400 |
| 464 | 1.3.5.4.1.4 | Safety Performance Estimate | 33d? | 2009-08-17 | 2009-09-30 | 123d | start no earlier than 2009-08-17 | Chin [7.6%] | 20h | 1,400 |
| 465 | 1.3.5.4.1.5 | Safety Electronics, Shutter & Interlocks | 33d? | 2009-08-17 | 2009-09-30 | 123d | start no earlier than 2009-08-17 | Wetherell [3.8%] | 10h | 700 |
| 466 | 1.3.5.4.1.6 | Safety Test Plans | 33d? | 2009-08-17 | 2009-09-30 | 123d | start no earlier than 2009-08-17 | Chin [3.8%]; Wetherell [3.8%] | 20h | 1,400 |
| 467 | 1.3.5.4.2 | **Laser Traffic Control System (LTCS) Modifications** | 20d? | 2009-10-05 | 2009-10-30 | 101d |  |  | 40h | 2,800 |
| 468 | 1.3.5.4.2.1 | LTCS Requirements & Interfaces | 20d? | 2009-10-05 | 2009-10-30 | 101d | start no earlier than 2009-10-05 | Summers [5%] | 8h | 560 |
| 469 | 1.3.5.4.2.2 | LTCS Algorithms, Diagrams & Dataflow | 20d? | 2009-10-05 | 2009-10-30 | 101d | start no earlier than 2009-10-05 | Summers [5%] | 8h | 560 |
| 470 | 1.3.5.4.2.3 | LTCS Communication Protocols & Methods | 20d? | 2009-10-05 | 2009-10-30 | 101d | start no earlier than 2009-10-05 | Summers [5%] | 8h | 560 |
| 471 | 1.3.5.4.2.4 | LTCS Performance Estimate | 20d? | 2009-10-05 | 2009-10-30 | 101d | start no earlier than 2009-10-05 | Summers [5%] | 8h | 560 |
| 472 | 1.3.5.4.2.5 | LTCS Test Plans | 20d? | 2009-10-05 | 2009-10-30 | 101d | start no earlier than 2009-10-05 | Summers [5%] | 8h | 560 |
| 473 | 1.3.5.5 | **Laser System Control (LSC)** | 128.33d? | 2009-04-28 | 2009-10-23 | 106d |  |  | 910h | 63,700 |
| 474 | 1.3.5.5.1 | **LSC Software** | 90d? | 2009-06-22 | 2009-10-23 | 106d |  |  | 600h | 42,000 |
| 475 | 1.3.5.5.1.1 | LSC Software Requirements & Interfaces | 8d? | 2009-07-01 | 2009-07-10 | 181d | start no earlier than 2009-07-01 | Morrison [62.5%]; Neyman [93.8%]; Chin [31.2%] | 120h | 8,400 |
| 476 | 1.3.5.5.1.2 | LSC Sequencer Software | 40d? | 2009-06-22 | 2009-09-04 | 141d | finish no earlier than 2009-09-04 | Johansson [6.2%]; Morrison [68.8%] | 240h | 16,800 |
| 477 | 1.3.5.5.1.3 | LSC Motion Control Software | 30d? | 2009-07-20 | 2009-08-28 | 146d | finish no earlier than 2009-08-28 | Morrison [50%] | 120h | 8,400 |
| 478 | 1.3.5.5.1.4 | LSC Device Control Software | 30d? | 2009-09-14 | 2009-10-23 | 106d | start no earlier than 2009-09-14 | Morrison [50%] | 120h | 8,400 |
| 479 | 1.3.5.5.2 | **LSC Hardware** | 125.62d? | 2009-04-28 | 2009-10-21 | 108.71d |  |  | 310h | 21,700 |
| 480 | 1.3.5.5.2.1 | LSC Hardware Requirements & Interfaces | 13.33d? | 2009-04-28 | 2009-05-15 | 221d | finish no earlier than 2009-05-15 | Neyman [37.5%]; Wetherell [28.1%]; Chin [18.8%] | 90h | 6,300 |
| 481 | 1.3.5.5.2.2 | LSC Motion Control Hardware | 15d? | 2009-05-18 | 2009-06-05 | 206d | start no earlier than 2009-05-18 | Wetherell | 120h | 8,400 |
| 482 | 1.3.5.5.2.3 | LSC Device Control Hardware | 14.29d? | 2009-10-01 | 2009-10-21 | 108.71d | start no earlier than 2009-10-01 | Wetherell [87.5%] | 100h | 7,000 |
| 483 | 1.3.5.6 | Laser System Lab I&T Plan | 20d? | 2009-10-05 | 2009-10-30 | 101d | finish no earlier than 2009-10-30 | Neyman [20%]; Chin; Nance | 48h | 3,360 |

Notes:
- 459: JC
- 460: JC
- 467: DS
- 473: EJ
- 474: EJ
- 475: EJ
- 476: EJ
- 477: DM
- 478: DM
- 479: EW
- 480: EW
- 481: EW
- 482: EW
- 483: CN

| ID | WBS | Task | Duration | Start | Finish | Total slack | Constraint | Resources | Work | Cost |
| --- | --- | --- | --- | --- | --- | --- | --- | --- | --- | --- |
| 484 | 1.3.6 | **Science Operations Tools Design** | 349d? | 2008-07-01 | 2009-10-30 | 101d |  |  | 1800h | 110,600 |
| 485 | 1.3.6.1 | **Multi-Systems Command Sequencer (MCS)** | 155d? | 2008-07-01 | 2009-02-02 | 295d |  |  | 620h | 38,850 |
| 486 | 1.3.6.1.1 | **MCS Infrastructure** | 80d? | 2008-07-07 | 2008-10-24 | 366d |  |  | 180h | 8,050 |
| 487 | 1.3.6.1.1.1 | **MCS Infrastructure Architecture** | 80d? | 2008-07-07 | 2008-10-24 | 366d |  |  | 140h | 5,250 |
| 488 | 1.3.6.1.1.1.1 | MCS Architecture | 80d? | 2008-07-07 | 2008-10-24 | 366d | start no earlier than 2008-07-07 | Johansson [2.3%]; Le Mignant [1.6%]; Johnson [2.3%] | 40h | 1,750 |
| 489 | 1.3.6.1.1.1.2 | MCS Operations Concept Document | 80d? | 2008-07-07 | 2008-10-24 | 366d | start no earlier than 2008-07-07 | Johansson [3.1%]; Johnson [3.1%] | 40h | 1,400 |
| 490 | 1.3.6.1.1.1.3 | MCS Software Requirements | 80d? | 2008-07-07 | 2008-10-24 | 366d | start no earlier than 2008-07-07 | Johansson [3.1%]; Johnson [3.1%] | 40h | 1,400 |
| 491 | 1.3.6.1.1.1.4 | MCS Module Definitions | 80d? | 2008-07-07 | 2008-10-24 | 366d | start no earlier than 2008-07-07 | Johansson [1.6%]; Johnson [1.6%] | 20h | 700 |
| 492 | 1.3.6.1.1.2 | **Coordination Sequence Support Library** | 80d? | 2008-07-07 | 2008-10-24 | 366d |  |  | 20h | 1,400 |
| 493 | 1.3.6.1.1.2.1 | Functional Requirements | 80d? | 2008-07-07 | 2008-10-24 | 366d | start no earlier than 2008-07-07 | Johansson [3.1%] | 20h | 1,400 |
| 494 | 1.3.6.1.1.2.2 | Interface Definitions | 1d? | 2008-07-07 | 2008-07-07 | 445d | start no earlier than 2008-07-07 |  |  |  |
| 495 | 1.3.6.1.1.3 | **Command Interface** | 80d? | 2008-07-07 | 2008-10-24 | 366d |  |  | 10h | 700 |
| 496 | 1.3.6.1.1.3.1 | Functional Requirements | 80d? | 2008-07-07 | 2008-10-24 | 366d | start no earlier than 2008-07-07 | Johansson [1.6%] | 10h | 700 |
| 497 | 1.3.6.1.1.3.2 | Interface Definitions | 1d? | 2008-07-07 | 2008-07-07 | 445d | finish no earlier than 2008-07-07 |  |  |  |
| 498 | 1.3.6.1.1.4 | **System Health** | 80d? | 2008-07-07 | 2008-10-24 | 366d |  |  | 10h | 700 |
| 499 | 1.3.6.1.1.4.1 | Functional Requirements | 80d? | 2008-07-07 | 2008-10-24 | 366d | start no earlier than 2008-07-07 | Johansson [1.6%] | 10h | 700 |
| 500 | 1.3.6.1.1.4.2 | Interface Definitions | 1d? | 2008-07-07 | 2008-07-07 | 445d | start no earlier than 2008-07-07 |  |  |  |
| 501 | 1.3.6.1.2 | **Setup Sequences: Configuration & Calibration** | 89d? | 2008-07-01 | 2008-10-31 | 361d |  |  | 100h | 7,000 |
| 502 | 1.3.6.1.2.1 | **Setup Sequences Common Structure** | 89d? | 2008-07-01 | 2008-10-31 | 361d |  |  | 60h | 4,200 |
| 503 | 1.3.6.1.2.1.1 | Setup Sequences Operations Concept Document | 89d? | 2008-07-01 | 2008-10-31 | 361d | finish no earlier than 2008-10-31 | Johansson [2.8%] | 20h | 1,400 |
| 504 | 1.3.6.1.2.1.2 | Setup Sequences Software Requirements | 89d? | 2008-07-01 | 2008-10-31 | 361d | finish no earlier than 2008-10-31 | Johansson [2.8%] | 20h | 1,400 |
| 505 | 1.3.6.1.2.1.3 | Setup Sequences Module Definitions | 89d? | 2008-07-01 | 2008-10-31 | 361d | finish no earlier than 2008-10-31 | Johansson [2.8%] | 20h | 1,400 |
| 506 | 1.3.6.1.2.2 | **Configuration Sequences** | 89d? | 2008-07-01 | 2008-10-31 | 361d |  |  | 20h | 1,400 |
| 507 | 1.3.6.1.2.2.1 | Functional Requirements | 89d? | 2008-07-01 | 2008-10-31 | 361d | finish no earlier than 2008-10-31 | Le Mignant [2.8%] | 20h | 1,400 |
| 508 | 1.3.6.1.2.2.2 | Interface Definitions | 1d? | 2008-07-01 | 2008-07-01 | 449d | start no earlier than 2008-07-01 |  |  |  |

Notes:
- 484: DLM
- 485: EJ

| ID | WBS | Task | Duration | Start | Finish | Total slack | Constraint | Resources | Work | Cost |
| --- | --- | --- | --- | --- | --- | --- | --- | --- | --- | --- |
| 509 | 1.3.6.1.2.3 | **Calibration Sequences** | 89d? | 2008-07-01 | 2008-10-31 | 361d |  |  | 20h | 1,400 |
| 510 | 1.3.6.1.2.3.1 | Functional Requirements | 89d? | 2008-07-01 | 2008-10-31 | 361d | finish no earlier than 2008-10-31 | Le Mignant [2.8%] | 20h | 1,400 |
| 511 | 1.3.6.1.2.3.2 | Interface Definitions | 1d? | 2008-07-01 | 2008-07-01 | 449d | start no earlier than 2008-07-01 |  |  |  |
| 512 | 1.3.6.1.3 | **Observing Sequences** | 89d? | 2008-10-01 | 2009-02-02 | 295d |  |  | 240h | 16,800 |
| 513 | 1.3.6.1.3.1 | **Observing Sequences Common Structure** | 89d? | 2008-10-01 | 2009-02-02 | 295d |  |  | 120h | 8,400 |
| 514 | 1.3.6.1.3.1.1 | Observing Sequences Operations Concept Document | 89d? | 2008-10-01 | 2009-02-02 | 295d | finish no earlier than 2009-02-02 | Le Mignant [4.2%]; Johansson [1.4%] | 40h | 2,800 |
| 515 | 1.3.6.1.3.1.2 | Observing Sequences Software Requirements | 89d? | 2008-10-01 | 2009-02-02 | 295d | start no earlier than 2008-10-01 | Johansson [5.6%] | 40h | 2,800 |
| 516 | 1.3.6.1.3.1.3 | Observing Sequences Module Definitions | 89d? | 2008-10-01 | 2009-02-02 | 295d | finish no earlier than 2009-02-02 | Johansson [2.8%]; Le Mignant [2.8%] | 40h | 2,800 |
| 517 | 1.3.6.1.3.2 | **Acquisition Sequences** | 89d? | 2008-10-01 | 2009-02-02 | 295d |  |  | 60h | 4,200 |
| 518 | 1.3.6.1.3.2.1 | Functional Requirements | 89d? | 2008-10-01 | 2009-02-02 | 295d | finish no earlier than 2009-02-02 | Le Mignant [4.2%]; Johansson [1.4%] | 40h | 2,800 |
| 519 | 1.3.6.1.3.2.2 | Interface Definitions | 89d? | 2008-10-01 | 2009-02-02 | 295d | finish no earlier than 2009-02-02 | Johansson [2.8%] | 20h | 1,400 |
| 520 | 1.3.6.1.3.3 | **Observing Sequences** | 89d? | 2008-10-01 | 2009-02-02 | 295d |  |  | 20h | 1,400 |
| 521 | 1.3.6.1.3.3.1 | Functional Requirements | 89d? | 2008-10-01 | 2009-02-02 | 295d | finish no earlier than 2009-02-02 | Le Mignant [2.8%] | 20h | 1,400 |
| 522 | 1.3.6.1.3.3.2 | Interface Definitions | 1d? | 2008-10-01 | 2008-10-01 | 383d | start no earlier than 2008-10-01 |  |  |  |
| 523 | 1.3.6.1.3.4 | **Quality Monitoring Sequences** | 89d? | 2008-10-01 | 2009-02-02 | 295d |  |  | 20h | 1,400 |
| 524 | 1.3.6.1.3.4.1 | Functional Requirements | 89d? | 2008-10-01 | 2009-02-02 | 295d | finish no earlier than 2009-02-02 | Le Mignant [2.8%] | 20h | 1,400 |
| 525 | 1.3.6.1.3.4.2 | Interface Definitions | 1d? | 2008-10-01 | 2008-10-01 | 383d | start no earlier than 2008-10-01 |  |  |  |
| 526 | 1.3.6.1.3.5 | **Optimization Sequences** | 89d? | 2008-10-01 | 2009-02-02 | 295d |  |  | 20h | 1,400 |
| 527 | 1.3.6.1.3.5.1 | Functional Requirements | 89d? | 2008-10-01 | 2009-02-02 | 295d | finish no earlier than 2009-02-02 | Le Mignant [2.8%] | 20h | 1,400 |
| 528 | 1.3.6.1.3.5.2 | Interface Definitions | 1d? | 2008-10-01 | 2008-10-01 | 383d | start no earlier than 2008-10-01 |  |  |  |
| 529 | 1.3.6.1.4 | **Alarm Handler & Troubleshooting Sequences** | 89d? | 2008-10-01 | 2009-02-02 | 295d |  |  | 100h | 7,000 |
| 530 | 1.3.6.1.4.1 | **Alarm Handler & Troubleshooting Common Structure** | 89d? | 2008-10-01 | 2009-02-02 | 295d |  |  | 100h | 7,000 |
| 531 | 1.3.6.1.4.1.1 | Alarm & Troubleshooting Operations Concept Document | 89d? | 2008-10-01 | 2009-02-02 | 295d | finish no earlier than 2009-02-02 | Le Mignant [4.2%]; Morrison [1.4%] | 40h | 2,800 |
| 532 | 1.3.6.1.4.1.2 | Alarm & Troubleshooting Software Requirements | 89d? | 2008-10-01 | 2009-02-02 | 295d | finish no earlier than 2009-02-02 | Morrison [2.8%] | 20h | 1,400 |
| 533 | 1.3.6.1.4.1.3 | Alarm & Troubleshooting Module Definitions | 89d? | 2008-10-01 | 2009-02-02 | 295d | finish no earlier than 2009-02-02 | Morrison [2.8%]; Le Mignant [2.8%] | 40h | 2,800 |

| ID | WBS | Task | Duration | Start | Finish | Total slack | Constraint | Resources | Work | Cost |
| --- | --- | --- | --- | --- | --- | --- | --- | --- | --- | --- |
| 534 | 1.3.6.1.4.2 | **Alarm Handler Sequences** | 1d? | 2008-10-01 | 2008-10-01 | 383d |  |  |  |  |
| 535 | 1.3.6.1.4.2.1 | Functional Requirements | 1d? | 2008-10-01 | 2008-10-01 | 383d | start no earlier than 2008-10-01 |  |  |  |
| 536 | 1.3.6.1.4.2.2 | Interface Definitions | 1d? | 2008-10-01 | 2008-10-01 | 383d | start no earlier than 2008-10-01 |  |  |  |
| 537 | 1.3.6.1.4.3 | **Troubleshooting Sequences** | 1d? | 2008-10-01 | 2008-10-01 | 383d |  |  |  |  |
| 538 | 1.3.6.1.4.3.1 | Functional Requirements | 1d? | 2008-10-01 | 2008-10-01 | 383d | start no earlier than 2008-10-01 |  |  |  |
| 539 | 1.3.6.1.4.3.2 | Interface Definitions | 1d? | 2008-10-01 | 2008-10-01 | 383d | start no earlier than 2008-10-01 |  |  |  |
| 540 | 1.3.6.2 | **User Interfaces** | 239d? | 2008-07-01 | 2009-05-29 | 211d |  |  | 500h | 28,350 |
| 541 | 1.3.6.2.1 | **User Interface (UI) Infrastructure** | 89d? | 2008-07-01 | 2008-10-31 | 361d |  |  | 180h | 5,950 |
| 542 | 1.3.6.2.1.1 | **UI Infrastructure Architecture** | 89d? | 2008-07-01 | 2008-10-31 | 361d |  |  | 120h | 1,750 |
| 543 | 1.3.6.2.1.1.1 | UI Architecture | 89d? | 2008-07-01 | 2008-10-31 | 361d | finish no earlier than 2008-10-31 | Johnson [4.9%]; Le Mignant | 40h | 350 |
| 544 | 1.3.6.2.1.1.2 | UI Operations Concept Document | 89d? | 2008-07-01 | 2008-10-31 | 361d | finish no earlier than 2008-10-31 | Le Mignant [2.8%]; Johnson [2.8%] | 40h | 1,400 |
| 545 | 1.3.6.2.1.1.3 | UI Software Requirements | 89d? | 2008-07-01 | 2008-10-31 | 361d | finish no earlier than 2008-10-31 | Johnson [2.8%] | 20h |  |
| 546 | 1.3.6.2.1.1.4 | UI Module Definitions | 89d? | 2008-07-01 | 2008-10-31 | 361d | finish no earlier than 2008-10-31 | Johnson [2.8%] | 20h |  |
| 547 | 1.3.6.2.1.2 | **UI Command Interface to MCS** | 89d? | 2008-07-01 | 2008-10-31 | 361d |  |  | 40h | 2,800 |
| 548 | 1.3.6.2.1.2.1 | Functional Requirements | 89d? | 2008-07-01 | 2008-10-31 | 361d | finish no earlier than 2008-10-31 | Morrison [2.8%] | 20h | 1,400 |
| 549 | 1.3.6.2.1.2.2 | Interface Definitions | 89d? | 2008-07-01 | 2008-10-31 | 361d | finish no earlier than 2008-10-31 | Morrison [2.8%] | 20h | 1,400 |
| 550 | 1.3.6.2.1.3 | **UI Command Interface to Pre- & Post-Observing Tools** | 89d? | 2008-07-01 | 2008-10-31 | 361d |  |  | 20h | 1,400 |
| 551 | 1.3.6.2.1.3.1 | Functional Requirements | 89d? | 2008-07-01 | 2008-10-31 | 361d | finish no earlier than 2008-10-31 | Morrison [2.8%] | 20h | 1,400 |
| 552 | 1.3.6.2.1.3.2 | Interface Definitions | 89d? | 2008-07-01 | 2008-10-31 | 361d | finish no earlier than 2008-10-31 |  |  |  |
| 553 | 1.3.6.2.2 | **Setup User Interfaces** | 130d? | 2008-10-01 | 2009-03-31 | 254d |  |  | 80h | 5,600 |
| 554 | 1.3.6.2.2.1 | **Setup UI Common Structure** | 130d? | 2008-10-01 | 2009-03-31 | 254d |  |  | 50h | 3,500 |
| 555 | 1.3.6.2.2.1.1 | Setup UI Operations Concept Document | 130d? | 2008-10-01 | 2009-03-31 | 254d | start no earlier than 2008-10-01 | Le Mignant [1.9%] | 20h | 1,400 |
| 556 | 1.3.6.2.2.1.2 | Setup UI Software Requirements | 130d? | 2008-10-01 | 2009-03-31 | 254d | finish no earlier than 2009-03-31 | Morrison [1%] | 10h | 700 |
| 557 | 1.3.6.2.2.1.3 | Setup UI Module Definitions | 130d? | 2008-10-01 | 2009-03-31 | 254d | finish no earlier than 2009-03-31 | Morrison [1.9%] | 20h | 1,400 |

Notes:
- 540: DLM

| ID | WBS | Task | Duration | Start | Finish | Total slack | Constraint | Resources | Work | Cost |
| --- | --- | --- | --- | --- | --- | --- | --- | --- | --- | --- |
| 558 | 1.3.6.2.2.2 | **Setup UI Configurations** | 130d? | 2008-10-01 | 2009-03-31 | 254d |  |  | 15h | 1,050 |
| 559 | 1.3.6.2.2.2.1 | Functional Requirements | 130d? | 2008-10-01 | 2009-03-31 | 254d | finish no earlier than 2009-03-31 | Le Mignant [1.4%] | 15h | 1,050 |
| 560 | 1.3.6.2.2.2.2 | Interface Definitions | 130d? | 2008-10-01 | 2009-03-31 | 254d | finish no earlier than 2009-03-31 |  |  |  |
| 561 | 1.3.6.2.2.3 | **Setup UI Calibrations** | 130d? | 2008-10-01 | 2009-03-31 | 254d |  |  | 15h | 1,050 |
| 562 | 1.3.6.2.2.3.1 | Functional Requirements | 130d? | 2008-10-01 | 2009-03-31 | 254d | finish no earlier than 2009-03-31 | Le Mignant [1.4%] | 15h | 1,050 |
| 563 | 1.3.6.2.2.3.2 | Interface Definitions | 130d? | 2008-10-01 | 2009-03-31 | 254d | finish no earlier than 2009-03-31 |  |  |  |
| 564 | 1.3.6.2.3 | **Observations User Interfaces** | 173d? | 2008-10-01 | 2009-05-29 | 211d |  |  | 240h | 16,800 |
| 565 | 1.3.6.2.3.1 | **Observations UI Common Structure** | 173d? | 2008-10-01 | 2009-05-29 | 211d |  |  | 130h | 9,100 |
| 566 | 1.3.6.2.3.1.1 | Observations UI Operations Concept Document | 173d? | 2008-10-01 | 2009-05-29 | 211d | finish no earlier than 2009-05-29 | Le Mignant [2.2%]; Morrison | 40h | 2,800 |
| 567 | 1.3.6.2.3.1.2 | Observations UI Software Requirements | 173d? | 2008-10-01 | 2009-05-29 | 211d | finish no earlier than 2009-05-29 | Morrison [0.7%] | 10h | 700 |
| 568 | 1.3.6.2.3.1.3 | Observations UI Module Definitions | 173d? | 2008-10-01 | 2009-05-29 | 211d | finish no earlier than 2009-05-29 | Morrison [2.9%]; Le Mignant [2.9%] | 80h | 5,600 |
| 569 | 1.3.6.2.3.2 | **Acquisition & AO Control UI** | 173d? | 2008-10-01 | 2009-05-29 | 211d |  |  | 30h | 2,100 |
| 570 | 1.3.6.2.3.2.1 | Functional Requirements | 173d? | 2008-10-01 | 2009-05-29 | 211d | finish no earlier than 2009-05-29 | Le Mignant [1.4%] | 20h | 1,400 |
| 571 | 1.3.6.2.3.2.2 | Interface Definitions | 173d? | 2008-10-01 | 2009-05-29 | 211d | finish no earlier than 2009-05-29 | Morrison [0.7%] | 10h | 700 |
| 572 | 1.3.6.2.3.3 | **Observing Sequences UI** | 173d? | 2008-10-01 | 2009-05-29 | 211d |  |  | 20h | 1,400 |
| 573 | 1.3.6.2.3.3.1 | Functional Requirements | 173d? | 2008-10-01 | 2009-05-29 | 211d | finish no earlier than 2009-05-29 | Le Mignant [1.4%] | 20h | 1,400 |
| 574 | 1.3.6.2.3.3.2 | Interface Definitions | 173d? | 2008-10-01 | 2009-05-29 | 211d | finish no earlier than 2009-05-29 |  |  |  |
| 575 | 1.3.6.2.3.4 | **Status & Graph UI** | 173d? | 2008-10-01 | 2009-05-29 | 211d |  |  | 20h | 1,400 |
| 576 | 1.3.6.2.3.4.1 | Functional Requirements | 173d? | 2008-10-01 | 2009-05-29 | 211d | finish no earlier than 2009-05-29 | Le Mignant [1.4%] | 20h | 1,400 |
| 577 | 1.3.6.2.3.4.2 | Interface Definitions | 173d? | 2008-10-01 | 2009-05-29 | 211d | finish no earlier than 2009-05-29 |  |  |  |
| 578 | 1.3.6.2.3.5 | **Advanced Monitoring UI** | 173d? | 2008-10-01 | 2009-05-29 | 211d |  |  | 20h | 1,400 |
| 579 | 1.3.6.2.3.5.1 | Functional Requirements | 173d? | 2008-10-01 | 2009-05-29 | 211d | finish no earlier than 2009-05-29 | Le Mignant [1.4%] | 20h | 1,400 |
| 580 | 1.3.6.2.3.5.2 | Interface Definitions | 173d? | 2008-10-01 | 2009-05-29 | 211d | finish no earlier than 2009-05-29 |  |  |  |
| 581 | 1.3.6.2.3.6 | **Optimization & Troubleshooting UI** | 173d? | 2008-10-01 | 2009-05-29 | 211d |  |  | 20h | 1,400 |
| 582 | 1.3.6.2.3.6.1 | Functional Requirements | 173d? | 2008-10-01 | 2009-05-29 | 211d | finish no earlier than 2009-05-29 | Le Mignant [1.4%] | 20h | 1,400 |
| 583 | 1.3.6.2.3.6.2 | Interface Definitions | 173d? | 2008-10-01 | 2009-05-29 | 211d | finish no earlier than 2009-05-29 |  |  |  |

| ID | WBS | Task | Duration | Start | Finish | Total slack | Constraint | Resources | Work | Cost |
| --- | --- | --- | --- | --- | --- | --- | --- | --- | --- | --- |
| 584 | 1.3.6.3 | **Pre- & Post-Observing Science Support Tools** | 217d? | 2009-01-01 | 2009-10-30 | 101d |  |  | 610h | 42,700 |
| 585 | 1.3.6.3.1 | **User Documentation** | 174d? | 2009-01-01 | 2009-09-01 | 144d |  |  | 20h | 1,400 |
| 586 | 1.3.6.3.1.1 | User Documentation Operations Concept | 174d? | 2009-01-01 | 2009-09-01 | 144d | finish no earlier than 2009-09-01 | Le Mignant [0.7%] | 10h | 700 |
| 587 | 1.3.6.3.1.2 | User Documentation Functional Requirements | 174d? | 2009-01-01 | 2009-09-01 | 144d | finish no earlier than 2009-09-01 | Le Mignant [0.7%] | 10h | 700 |
| 588 | 1.3.6.3.2 | **Science Observations Planning Tools** | 148d? | 2009-01-07 | 2009-07-31 | 166d |  |  | 340h | 23,800 |
| 589 | 1.3.6.3.2.1 | **NGS Star Finder** | 148d? | 2009-01-07 | 2009-07-31 | 166d |  |  | 60h | 4,200 |
| 590 | 1.3.6.3.2.1.1 | Operations Concept | 148d? | 2009-01-07 | 2009-07-31 | 166d | finish no earlier than 2009-07-31 | Le Mignant [1.7%] | 20h | 1,400 |
| 591 | 1.3.6.3.2.1.2 | Functional Requirements & Use Case Definitions | 148d? | 2009-01-07 | 2009-07-31 | 166d | finish no earlier than 2009-07-31 | Le Mignant [3.4%] | 40h | 2,800 |
| 592 | 1.3.6.3.2.1.3 | Interface Definitions | 148d? | 2009-01-07 | 2009-07-31 | 166d | finish no earlier than 2009-07-31 |  |  |  |
| 593 | 1.3.6.3.2.1.4 | Module Definitions | 148d? | 2009-01-07 | 2009-07-31 | 166d | finish no earlier than 2009-07-31 |  |  |  |
| 594 | 1.3.6.3.2.2 | **Performance Prediction Tool** | 148d? | 2009-01-07 | 2009-07-31 | 166d |  |  | 140h | 9,800 |
| 595 | 1.3.6.3.2.2.1 | Operations Concept | 148d? | 2009-01-07 | 2009-07-31 | 166d | finish no earlier than 2009-07-31 | Le Mignant [3.4%] | 40h | 2,800 |
| 596 | 1.3.6.3.2.2.2 | Functional Requirements & Use Case Definitions | 148d? | 2009-01-07 | 2009-07-31 | 166d | finish no earlier than 2009-07-31 | Le Mignant [3.4%] | 40h | 2,800 |
| 597 | 1.3.6.3.2.2.3 | Interface Definitions | 148d? | 2009-01-07 | 2009-07-31 | 166d | finish no earlier than 2009-07-31 | Johansson [1.7%] | 20h | 1,400 |
| 598 | 1.3.6.3.2.2.4 | Module Definitions | 148d? | 2009-01-07 | 2009-07-31 | 166d | finish no earlier than 2009-07-31 | Johansson [1.7%]; Le Mignant [1.7%] | 40h | 2,800 |
| 599 | 1.3.6.3.2.3 | **Observation Planning & Efficiency Tool** | 148d? | 2009-01-07 | 2009-07-31 | 166d |  |  | 140h | 9,800 |
| 600 | 1.3.6.3.2.3.1 | Operations Concept | 148d? | 2009-01-07 | 2009-07-31 | 166d | finish no earlier than 2009-07-31 | Le Mignant [3.4%] | 40h | 2,800 |
| 601 | 1.3.6.3.2.3.2 | Functional Requirements & Use Case Definitions | 148d? | 2009-01-07 | 2009-07-31 | 166d | finish no earlier than 2009-07-31 | Le Mignant [3.4%] | 40h | 2,800 |
| 602 | 1.3.6.3.2.3.3 | Interface Definitions | 148d? | 2009-01-07 | 2009-07-31 | 166d | finish no earlier than 2009-07-31 | Johansson [1.7%] | 20h | 1,400 |
| 603 | 1.3.6.3.2.3.4 | Module Definitions | 148d? | 2009-01-07 | 2009-07-31 | 166d | finish no earlier than 2009-07-31 | Johansson [1.7%]; Le Mignant [1.7%] | 40h | 2,800 |
| 604 | 1.3.6.3.2.4 | **Laser Clearinghouse Coordination Tool** | 148d? | 2009-01-07 | 2009-07-31 | 166d |  |  |  |  |
| 605 | 1.3.6.3.2.4.1 | Operations Concept | 148d? | 2009-01-07 | 2009-07-31 | 166d | finish no earlier than 2009-07-31 |  |  |  |
| 606 | 1.3.6.3.2.4.2 | Functional Requirements & Use Case Definitions | 148d? | 2009-01-07 | 2009-07-31 | 166d | finish no earlier than 2009-07-31 |  |  |  |
| 607 | 1.3.6.3.2.4.3 | Interface Definitions | 148d? | 2009-01-07 | 2009-07-31 | 166d | finish no earlier than 2009-07-31 |  |  |  |
| 608 | 1.3.6.3.2.4.4 | Module Definitions | 148d? | 2009-01-07 | 2009-07-31 | 166d | finish no earlier than 2009-07-31 |  |  |  |

Notes:
- 584: DLM

| ID | WBS | Task | Type | Duration | Start | Finish | Total slack | Constraint | Resources | Work | Cost |
| --- | --- | --- | --- | --- | --- | --- | --- | --- | --- | --- | --- |
| 609 | 1.3.6.3.3 | **Data Products** |  | 195d? | 2009-02-02 | 2009-10-30 | 101d |  |  | 250h | 17,500 |
| 610 | 1.3.6.3.3.1 | **Generic Data Products** |  | 152d? | 2009-02-02 | 2009-09-01 | 144d |  |  | 80h | 5,600 |
| 611 | 1.3.6.3.3.1.1 | Operations Concept |  | 152d? | 2009-02-02 | 2009-09-01 | 144d | finish no earlier than 2009-09-01 | Le Mignant [1.6%] | 20h | 1,400 |
| 612 | 1.3.6.3.3.1.2 | Functional Requirements & Use Case Definitions |  | 152d? | 2009-02-02 | 2009-09-01 | 144d | finish no earlier than 2009-09-01 | Le Mignant [3.3%] | 40h | 2,800 |
| 613 | 1.3.6.3.3.1.3 | Interface Definitions |  | 152d? | 2009-02-02 | 2009-09-01 | 144d | finish no earlier than 2009-09-01 | Johansson [1.6%] | 20h | 1,400 |
| 614 | 1.3.6.3.3.2 | **Science Data Quality Assessment** |  | 195d? | 2009-02-02 | 2009-10-30 | 101d |  |  | 160h | 11,200 |
| 615 | 1.3.6.3.3.2.1 | **Quality Metrics & Logged Information** |  | 152d? | 2009-02-02 | 2009-09-01 | 144d |  |  | 80h | 5,600 |
| 616 | 1.3.6.3.3.2.1.1 | Operations Concept |  | 152d? | 2009-02-02 | 2009-09-01 | 144d | finish no earlier than 2009-09-01 | Le Mignant [3.3%] | 40h | 2,800 |
| 617 | 1.3.6.3.3.2.1.2 | Functional Requirements & Use Case Definitions |  | 152d? | 2009-02-02 | 2009-09-01 | 144d | finish no earlier than 2009-09-01 | Le Mignant [3.3%] | 40h | 2,800 |
| 618 | 1.3.6.3.3.2.1.3 | Interface Definitions |  | 152d? | 2009-02-02 | 2009-09-01 | 144d | finish no earlier than 2009-09-01 |  |  |  |
| 619 | 1.3.6.3.3.2.2 | **PSF Calibration** |  | 195d? | 2009-02-02 | 2009-10-30 | 101d |  |  | 80h | 5,600 |
| 620 | 1.3.6.3.3.2.2.1 | Operations Concept |  | 195d? | 2009-02-02 | 2009-10-30 | 101d | finish no earlier than 2009-10-30 | Le Mignant [2.6%] | 40h | 2,800 |
| 621 | 1.3.6.3.3.2.2.2 | Functional Requirements & Use Case Definitions |  | 195d? | 2009-02-02 | 2009-10-30 | 101d | finish no earlier than 2009-10-30 | Le Mignant [2.6%] | 40h | 2,800 |
| 622 | 1.3.6.3.3.2.2.3 | Interface Definitions |  | 195d? | 2009-02-02 | 2009-10-30 | 101d | finish no earlier than 2009-10-30 |  |  |  |
| 623 | 1.3.6.3.3.2.2.4 | Module Definitions |  | 195d? | 2009-02-02 | 2009-10-30 | 101d | finish no earlier than 2009-10-30 |  |  |  |
| 624 | 1.3.6.3.3.3 | **Science Data Archiving** |  | 195d? | 2009-02-02 | 2009-10-30 | 101d |  |  | 10h | 700 |
| 625 | 1.3.6.3.3.3.1 | Operations Concept |  | 195d? | 2009-02-02 | 2009-10-30 | 101d | finish no earlier than 2009-10-30 | Le Mignant [0.6%] | 10h | 700 |
| 626 | 1.3.6.3.3.3.2 | Functional Requirements & Use Case Definitions |  | 195d? | 2009-02-02 | 2009-10-30 | 101d | finish no earlier than 2009-10-30 |  |  |  |
| 627 | 1.3.6.3.3.3.3 | Interface Definitions |  | 195d? | 2009-02-02 | 2009-10-30 | 101d | finish no earlier than 2009-10-30 |  |  |  |
| 628 | 1.3.6.4 | **Data Server** |  | 195d? | 2009-02-02 | 2009-10-30 | 101d |  |  | 70h | 700 |
| 629 | 1.3.6.4.1 | Data Server: Architecture |  | 195d? | 2009-02-02 | 2009-10-30 | 101d | start no earlier than 2009-02-02 | Johansson [0.6%]; Johnson [1.9%] | 40h | 700 |
| 630 | 1.3.6.4.2 | Data Server: HW & SW Specification & Selection |  | 195d? | 2009-02-02 | 2009-10-30 | 101d | finish no earlier than 2009-10-30 | Johnson [1.3%] | 20h |  |
| 631 | 1.3.6.4.3 | Data Server: Software Design | milestone | 0d? | 2009-02-02 | 2009-02-02 | 296d | start no earlier than 2009-02-02 |  |  |  |
| 632 | 1.3.6.4.4 | Data Server: Compliance Matrix | milestone | 0d? | 2009-02-02 | 2009-02-02 | 296d | start no earlier than 2009-02-02 |  |  |  |
| 633 | 1.3.6.4.5 | Data Server: Test Plan | milestone | 0d? | 2009-02-02 | 2009-02-02 | 296d | start no earlier than 2009-02-02 |  |  |  |
| 634 | 1.3.6.4.6 | Data Server: Summary Report |  | 195d? | 2009-02-02 | 2009-10-30 | 101d | finish no earlier than 2009-10-30 | Johnson [0.6%] | 10h |  |

Notes:
- 628: EJ

| ID | WBS | Task | Duration | Start | Finish | Total slack | Constraint | Resources | Work | Cost |
| --- | --- | --- | --- | --- | --- | --- | --- | --- | --- | --- |
| 635 | 1.3.7 | **Telescope & Summit Engineering Design** | 215d? | 2008-12-08 | 2009-10-02 | 121d |  |  | 1101h | 75,746 |
| 636 | 1.3.7.1 | Telescope Performance | 1d? | 2009-05-04 | 2009-05-04 | 230d | start no earlier than 2009-05-04 |  |  |  |
| 637 | 1.3.7.2 | **Infrastructure Modifications for AO** | 110d? | 2009-05-04 | 2009-10-02 | 121d |  |  | 660h | 45,797.2 |
| 638 | 1.3.7.2.1 | Infrastructure Requirements & Interfaces | 20d? | 2009-05-04 | 2009-05-29 | 211d | finish no earlier than 2009-05-29 | Bell [37.5%]; Wetherell; Wizinowich [60%] | 90h | 6,613.6 |
| 639 | 1.3.7.2.2 | Infrastructure Mechanical Modifications | 45d? | 2009-06-01 | 2009-07-31 | 166d | finish no earlier than 2009-07-31 | Bell; Medeiros [33.3%]; Mogensen | 160h | 10,505.6 |
| 640 | 1.3.7.2.3 | Infrastructure Electrical Modifications | 45d? | 2009-07-06 | 2009-09-04 | 141d | finish no earlier than 2009-09-04 | Nance [33.3%] | 120h | 8,400 |
| 641 | 1.3.7.2.4 | Infrastructure Glycol Cooling Modifications | 45d? | 2009-07-13 | 2009-09-11 | 136d | finish no earlier than 2009-09-11 | Nance [38.9%] | 140h | 9,800 |
| 642 | 1.3.7.2.5 | Infrastructure CCR Modifications | 45d? | 2009-07-13 | 2009-09-11 | 136d | finish no earlier than 2009-09-11 | Nance [11.1%] | 40h | 2,800 |
| 643 | 1.3.7.2.6 | Infrastructure Implementation & Test Plans | 25d? | 2009-08-31 | 2009-10-02 | 121d | finish no earlier than 2009-10-02 | Bell [25%]; Medeiros; Nance; Chin | 110h | 7,678 |
| 644 | 1.3.7.3 | **Infrastructure modifications for Laser System** | 110d? | 2009-05-04 | 2009-10-02 | 121d |  |  | 280h | 19,564.8 |
| 645 | 1.3.7.3.1 | Infrastructure Requirements & Interfaces | 20d? | 2009-05-04 | 2009-05-29 | 211d | finish no earlier than 2009-05-29 | Bell [25%]; Chin; Nance | 70h | 4,882.4 |
| 646 | 1.3.7.3.2 | Infrastructure Mechanical Modifications | 45d? | 2009-06-29 | 2009-08-28 | 146d | finish no earlier than 2009-08-28 | Medeiros [13.9%] | 50h | 3,500 |
| 647 | 1.3.7.3.3 | Infrastructure Electrical Modifications | 45d? | 2009-07-06 | 2009-09-04 | 141d | finish no earlier than 2009-09-04 | Nance [11.1%] | 40h | 2,800 |
| 648 | 1.3.7.3.4 | Infrastructure Glycol Cooling Modifications | 45d? | 2009-07-13 | 2009-09-11 | 136d | finish no earlier than 2009-09-11 | Nance [13.9%] | 50h | 3,500 |
| 649 | 1.3.7.3.5 | Infrastructure Implementation & Test Plans | 25d? | 2009-08-31 | 2009-10-02 | 121d | finish no earlier than 2009-10-02 | Bell [20%]; Chin; Medeiros; Nance | 70h | 4,882.4 |
| 650 | 1.3.7.4 | OSIRIS Modifications | 15d? | 2009-01-12 | 2009-01-30 | 296d | start no earlier than 2009-01-12 | Adkins [16.7%]; Tolleth [33.3%]; Medeiros [33.3%] | 100h | 4,880 |
| 651 | 1.3.7.5 | **Interferometer Modifications** | 40d? | 2008-12-08 | 2009-01-30 | 296d |  |  | 61h | 5,504 |
| 652 | 1.3.7.5.1 | Optical Design of Post Field Selector Optics | 40d? | 2008-12-08 | 2009-01-30 | 296d | finish no earlier than 2009-01-30 | Wizinowich [7.8%]; Kupke [6.2%] | 45h | 3,840 |
| 653 | 1.3.7.5.2 | Evaluation of Optical Design Impact on Interferometer | 40d? | 2008-12-08 | 2009-01-30 | 296d | start no earlier than 2008-12-08 | Wizinowich [5%] | 16h | 1,664 |
| 654 | 1.3.8 | **Telescope Integration & Test** | 55d? | 2009-10-05 | 2009-12-18 | 66d |  |  | 622h | 45,194.4 |
| 655 | 1.3.8.1 | **Old AO/Laser Removal** | 20d? | 2009-10-05 | 2009-10-30 | 101d |  |  | 120h | 8,159.2 |
| 656 | 1.3.8.1.1 | AO Removal Plan | 20d? | 2009-10-05 | 2009-10-30 | 101d | start no earlier than 2009-10-05 | Nance [7.5%]; Bell [15%]; Wetherell [12.5%]; Wizinowich [2.5%]; Doyle | 60h | 4,143.2 |
| 657 | 1.3.8.1.2 | Laser Removal Plan | 20d? | 2009-10-05 | 2009-10-30 | 101d | start no earlier than 2009-10-05 | Chin [2.5%]; Medeiros [12.5%]; Doyle [5%]; Grace [10%]; Nance [7.5%] | 60h | 4,016 |
| 658 | 1.3.8.2 | Laser Enclosure Integration | 1d? | 2009-10-05 | 2009-10-05 | 120d | start no earlier than 2009-10-05 |  |  |  |
| 659 | 1.3.8.3 | AO Enclosure Integration | 1d? | 2009-10-05 | 2009-10-05 | 120d | start no earlier than 2009-10-05 |  |  |  |

Notes:
- 635: CN
- 637: JB
- 638: JB
- 639: DM
- 640: CN
- 641: CN
- 642: CN
- 643: JB
- 644: JB
- 645: JB
- 646: DM
- 647: CN
- 648: CN
- 649: JB
- 650: SA
- 651: PW
- 652: PW
- 653: PW
- 654: CN
- 655: JB
- 656: JB
- 657: DM

| ID | WBS | Task | Duration | Start | Finish | Total slack | Constraint | Resources | Work | Cost |
| --- | --- | --- | --- | --- | --- | --- | --- | --- | --- | --- |
| 660 | 1.3.8.4 | **AO System Install + I&T** | 35d? | 2009-11-02 | 2009-12-18 | 66d |  |  | 170h | 12,027.2 |
| 661 | 1.3.8.4.1 | Opto-Mechanical Integration Plan | 27d? | 2009-11-02 | 2009-12-08 | 74d | start no earlier than 2009-11-02 | Wizinowich [1.9%]; Bell [9.3%]; Neyman [16.7%] | 60h | 4,327.2 |
| 662 | 1.3.8.4.2 | Electronics Integration Plan | 35d? | 2009-11-02 | 2009-12-18 | 66d | start no earlier than 2009-11-02 | Wetherell [14.3%] | 40h | 2,800 |
| 663 | 1.3.8.4.3 | Computer Integration Plan | 35d? | 2009-11-02 | 2009-12-18 | 66d | start no earlier than 2009-11-02 | Chock [7.1%] | 20h | 1,400 |
| 664 | 1.3.8.4.4 | AO System Integration Plan | 35d? | 2009-11-02 | 2009-12-18 | 66d | start no earlier than 2009-11-02 | Neyman [14.3%] | 40h | 2,800 |
| 665 | 1.3.8.4.5 | AO System Test Plan | 35d? | 2009-11-02 | 2009-12-18 | 66d | start no earlier than 2009-11-02 | Neyman [3.6%] | 10h | 700 |
| 666 | 1.3.8.5 | **Laser System Install + I&T** | 35d? | 2009-11-02 | 2009-12-18 | 66d |  |  | 212h | 15,248 |
| 667 | 1.3.8.5.1 | Laser System Installation & Integration Plan | 35d? | 2009-11-02 | 2009-12-18 | 66d | finish no earlier than 2009-12-18 | Chin [21.4%]; Nance [7.1%]; Medeiros [7.1%]; Wetherell [7.1%]; Neyman [7.1%]; Adkins [2.9%] | 148h | 10,632 |
| 668 | 1.3.8.5.2 | Laser System Test Plan | 35d? | 2009-11-02 | 2009-12-18 | 66d | start no earlier than 2009-11-02 | Neyman [14.3%]; Wetherell [1.4%]; Johansson [2.9%]; Chin [2.9%]; Adkins [1.4%] | 64h | 4,616 |
| 669 | 1.3.8.6 | LGS AO System On-sky I&T Plan | 10d? | 2009-11-02 | 2009-11-13 | 91d | finish no earlier than 2009-11-13 | Le Mignant [25%]; Wizinowich [25%] | 40h | 3,480 |
| 670 | 1.3.8.7 | Performance Characterization | 1d? | 2009-11-02 | 2009-11-02 | 100d | start no earlier than 2009-11-02 |  |  |  |
| 671 | 1.3.8.8 | Science Verification Plan | 20d? | 2009-11-02 | 2009-11-27 | 81d | finish no earlier than 2009-11-27 | Le Mignant [37.5%]; Wizinowich [12.5%] | 80h | 6,280 |
| 672 | 1.3.9 | **Operations Transition** | 232d? | 2009-01-09 | 2009-11-30 | 80d |  |  | 166h | 12,342.96 |
| 673 | 1.3.9.1 | **Operations Plans** | 65d? | 2009-09-01 | 2009-11-30 | 80d |  |  | 96h | 7,102.96 |
| 674 | 1.3.9.1.1 | Operations Support Plan | 65d? | 2009-09-01 | 2009-11-30 | 80d | finish no earlier than 2009-11-30 | Le Mignant [7.7%] | 40h | 2,800 |
| 675 | 1.3.9.1.2 | Operations Maintenance & Spares Plan Template | 65d? | 2009-09-01 | 2009-11-30 | 80d | start no earlier than 2009-09-01 | Wetherell [5.4%]; Bell [3.1%]; Lockwood [1.2%]; Velur [1.2%] | 56h | 4,302.96 |
| 676 | 1.3.9.2 | **Operations Handover** | 232d? | 2009-01-09 | 2009-11-30 | 80d |  |  | 70h | 5,240 |
| 677 | 1.3.9.2.1 | Operations Personnel Training Plan | 65d? | 2009-09-01 | 2009-11-30 | 80d | finish no earlier than 2009-11-30 | Le Mignant [7.7%]; Wizinowich [1.9%] | 50h | 3,840 |
| 678 | 1.3.9.2.2 | Documentation Transition Plan | 232d? | 2009-01-09 | 2009-11-30 | 80d | finish no earlier than 2009-11-30 | Le Mignant [1.1%] | 20h | 1,400 |

Notes:
- 660: CN
- 661: CN
- 662: EW
- 663: JC
- 664: CN
- 665: CN
- 666: JC
- 667: JC
- 668: CN
- 669: DLM
- 671: DLM
- 672: DLM
- 673: DLM
- 674: DLM
- 675: EW
- 676: DLM
- 677: DLM
- 678: DLM
