# NGAO Design v7

Schedule from MS Project, 2005-10-03 to 2010-03-22, costs in $.
CARA

## Calendars

- Standard: Mon-Fri 08:00-12:00, 13:00-17:00; Sat-Sun off.

## Resources

| Resource | Group | Rate |
| --- | --- | --- |
| Dekany | COO | 96.14 |
| Gavel | UCO | 133.6 |
| Max | UCO |  |
| Wizinowich | WMKO | 104 |
| Adkins | KO | 104 |
| McGrath | UCO | 36.9 |
| Tyau | WMKO | 35 |
| Le Mignant | WMKO | 70 |
| Bell | KO | 69.56 |
| Chin | WMKO | 70 |
| Kupke | UCO | 48.3 |
| Lockwood | UCO | 86.55 |
| Neyman | WMKO | 70 |
| Reinig | UCO | 74.6 |
| Velur | COO | 96 |
| Free | WMKO |  |
| Student |  | 40 |
| Johansson | WMKO | 70 |
| Wetherell | WMKO | 70 |
| Medeiros | WMKO | 70 |
| Nance | WMKO | 70 |
| Summers | WMKO | 70 |
| Mogensen | WMKO | 47 |
| Bouchez | KO | 96.14 |
| Kissner | WMKO | 47 |
| Chock | WMKO | 70 |
| Panteleev | WMKO | 70 |
| Morrison | WMKO | 70 |
| Macintosh | UCO | 123.9 |
| Hale | COO | 96 |
| Grace | WMKO | 70 |
| Doyle | WMKO | 47 |
| Contract Administrator | WMKO | 70 |
| Brown | COO | 70 |
| Johnson | WMKO |  |
| COO ME | COO |  |
| Stomski | WMKO |  |
| Tolleth | WMKO |  |
| Lu | COO |  |
| Peck | UCO | 80.8 |
| UC Financial Analyst | UCO | 57.94 |
| Morriso |  |  |

## Schedule

| ID | WBS | Task | Duration | Start | Finish | Total slack | Constraint | Resources | Work | Cost |
| --- | --- | --- | --- | --- | --- | --- | --- | --- | --- | --- |
| 1 | 1 | **NGAO Design** | 1166d? | 2005-10-03 | 2010-03-22 | 0d |  |  | 37061h | 2,486,328.54 |
| 2 | 1.1 | Proposal | 195d? | 2005-10-03 | 2006-06-30 | 971d | finish no earlier than 2006-06-30 |  |  |  |
| 3 | 1.2 | System Design | 413d? | 2006-10-02 | 2008-04-30 | 493d | finish no earlier than 2008-04-30 |  |  |  |
| 4 | 1.3 | **Preliminary Design** | 515d? | 2008-04-01 | 2010-03-22 | 0d |  |  | 37061h | 2,486,328.54 |
| 5 | 1.3.1 | Reserved | 1d? | 2008-05-01 | 2008-05-01 | 492d | start no earlier than 2008-05-01 |  |  |  |
| 6 | 1.3.2 | **PD Phase Management** | 515d? | 2008-04-01 | 2010-03-22 | 0d |  |  | 10442h | 726,690.23 |
| 7 | 1.3.2.1 | **Planning** | 479d? | 2008-04-01 | 2010-01-29 | 36d |  |  | 1940h | 180,207.52 |
| 8 | 1.3.2.1.1 | **Replans (PD phase)** | 309d? | 2008-04-01 | 2009-06-05 | 206d |  |  | 386h | 40,308.18 |
| 9 | 1.3.2.1.1.1 | **Replan based on SDR** | 102d? | 2008-04-01 | 2008-08-20 | 413d |  |  | 70h | 7,410.44 |
| 10 | 1.3.2.1.1.1.1 | Response to SDR Report | 3d? | 2008-04-01 | 2008-05-05 | 490d |  | Wizinowich [33.3%]; Dekany [8.3%]; Gavel [8.3%] | 12h | 1,291.48 |
| 11 | 1.3.2.1.1.1.2 | Response to SSC Report | 11d? | 2008-04-01 | 2008-06-16 | 460d |  | Wizinowich [4.5%] | 4h | 416 |
| 12 | 1.3.2.1.1.1.3 | Replan KAON | 78d? | 2008-04-01 | 2008-08-20 | 413d |  | Wizinowich [3.8%]; Dekany [0.6%]; Gavel [0.6%] | 32h | 3,414.96 |
| 13 | 1.3.2.1.1.1.4 | Replan MS Project Plan | 26d? | 2008-04-01 | 2008-08-20 | 413d |  | Wizinowich [10.6%] | 22h | 2,288 |
| 14 | 1.3.2.1.1.2 | **Phased Implementation Planning** | 130d? | 2008-05-05 | 2008-10-31 | 361d |  |  | 156h | 16,276.84 |
| 15 | 1.3.2.1.1.2.1 | Phased Implementation - Plan | 27d? | 2008-05-05 | 2008-06-10 | 464d | start no earlier than 2008-05-05 | Wizinowich [7.4%]; Dekany [0.9%]; Gavel [0.9%] | 20h | 2,123.48 |
| 16 | 1.3.2.1.1.2.2 | Phased Implementation - SDR Proposed System Baseline | 98d? | 2008-06-02 | 2008-10-15 | 373d | finish no earlier than 2008-10-15 | Wizinowich [2%] | 16h | 1,664 |
| 17 | 1.3.2.1.1.2.3 | Phased Implementation - SDR Proposed System Phasing | 98d? | 2008-06-02 | 2008-10-15 | 373d | finish no earlier than 2008-10-15 | Wizinowich [2%] | 16h | 1,664 |
| 18 | 1.3.2.1.1.2.4 | Phased Implementation - Keck AO Upgrade Option | 43d? | 2008-08-18 | 2008-10-15 | 373d | start no earlier than 2008-08-18 | Wizinowich [2.3%] | 8h | 832 |
| 19 | 1.3.2.1.1.2.5 | Phased Implementation - Descope Options | 43d? | 2008-08-18 | 2008-10-15 | 373d | start no earlier than 2008-08-18 | Wizinowich [4.7%] | 16h | 1,664 |
| 20 | 1.3.2.1.1.2.6 | Phased Implementation - Cost Savings Options | 43d? | 2008-06-02 | 2008-10-15 | 373d | start no earlier than 2008-06-02 | Wizinowich [2.3%]; Gavel [2.3%] | 16h | 1,900.8 |
| 21 | 1.3.2.1.1.2.7 | Phased Implementation - Wavefront Error Budgets | 30d? | 2008-07-21 | 2008-08-29 | 406d | start no earlier than 2008-07-21 | Dekany [16.7%] | 40h | 3,845.6 |
| 22 | 1.3.2.1.1.2.8 | Phased Implementation - Report | 110d? | 2008-06-02 | 2008-10-31 | 361d | start no earlier than 2008-06-02 | Wizinowich [1.8%]; Dekany [0.5%]; Gavel [0.5%] | 24h | 2,582.96 |
| 23 | 1.3.2.1.1.3 | Replan 1 | 10d? | 2008-10-27 | 2008-11-07 | 356d | finish no earlier than 2008-11-07 | Dekany [20%]; Gavel [20%]; Wizinowich [45%]; Lockwood [1.2%]; Velur [3.8%]; Neyman [1.2%]; Le Mignant [1.2%]; Johansson [2.5%]; Reinig [2.5%]; Bell [1.2%]; Wetherell [1.2%] | 80h | 8,363.15 |
| 24 | 1.3.2.1.1.4 | Replan 2 | 10d? | 2009-05-25 | 2009-06-05 | 206d | finish no earlier than 2009-06-05 | Dekany [20%]; Gavel [20%]; Wizinowich [40%]; Wetherell [2.5%]; Bell [1.2%]; Reinig [3.8%]; Johansson [2.5%]; Le Mignant [2.5%]; Neyman [1.2%]; Velur [5%]; Lockwood [1.2%] | 80h | 8,257.75 |

Notes:
- 6: PW
- 7: PW
- 8: PW
- 9: PW
- 14: PW
- 23: PW
- 24: PW

| ID | WBS | Task | Type | Duration | Start | Finish | Total slack | Constraint | Resources | Work | Cost |
| --- | --- | --- | --- | --- | --- | --- | --- | --- | --- | --- | --- |
| 25 | 1.3.2.1.2 | **WMKO FY Plans** |  | 280d? | 2008-05-05 | 2009-05-29 | 211d |  |  | 40h | 4,160 |
| 26 | 1.3.2.1.2.1 | Support WMKO FY09 Planning |  | 20d? | 2008-05-05 | 2008-05-30 | 471d | start no earlier than 2008-05-05 | Wizinowich [6.2%] | 10h | 1,040 |
| 27 | 1.3.2.1.2.2 | Support WMKO FY10 Planning |  | 85d? | 2009-02-02 | 2009-05-29 | 211d | start no earlier than 2009-02-02 | Wizinowich [4.4%] | 30h | 3,120 |
| 28 | 1.3.2.1.3 | **Cost Estimation** |  | 351d? | 2008-08-15 | 2009-12-18 | 66d |  |  | 584h | 48,125.42 |
| 29 | 1.3.2.1.3.1 | NFIRAOS Cost Comparison |  | 33d? | 2008-08-15 | 2008-09-30 | 384d | start no earlier than 2008-08-15 | Dekany [18.2%]; Neyman [3%]; Gavel [6.1%]; Velur [3%]; Johansson [3%]; Wizinowich [6.1%] | 104h | 10,304.32 |
| 30 | 1.3.2.1.3.2 | Cost Estimation for SEMP |  | 20d? | 2009-11-23 | 2009-12-18 | 66d | start no earlier than 2009-11-23 | Dekany [37.5%]; Gavel [25%]; Max [6.2%]; Wizinowich [37.5%]; Nance [12.5%]; Neyman [18.8%]; Le Mignant [18.8%]; Bell [12.5%]; Johansson [25%]; Wetherell [9.4%]; Reinig [12.5%]; Kupke [9.4%]; Lockwood [12.5%]; Velur [9.4%]; Brown [25%]; COO ME [18.8%]; Hale [9.4%] | 480h | 37,821.1 |
| 31 | 1.3.2.1.4 | **Systems Engineering Management Plan** |  | 218d? | 2009-04-01 | 2010-01-29 | 36d |  |  | 930h | 87,613.92 |
| 32 | 1.3.2.1.4.1 | **Project Plan** |  | 50d? | 2009-11-02 | 2010-01-08 | 51d |  |  | 530h | 48,810.5 |
| 33 | 1.3.2.1.4.1.1 | PBS, WBS & Task Definition |  | 15d? | 2009-11-02 | 2009-11-20 | 86d | start no earlier than 2009-11-02 | Dekany [33.3%]; Gavel [33.3%]; Wizinowich [33.3%]; Max [8.3%]; Reinig [12.5%]; Wetherell [8.3%]; Johansson [12.5%]; Le Mignant [12.5%]; Neyman [8.3%]; Bell [8.3%]; Velur [33.3%]; Lockwood [12.5%] | 260h | 23,802.45 |
| 34 | 1.3.2.1.4.1.2 | Full Schedule (MS Project Plan) |  | 25d? | 2009-12-07 | 2010-01-08 | 51d | start no earlier than 2009-12-07 | Wizinowich [30%]; Dekany [15%]; Gavel [15%]; Velur [20%]; Bell [5%]; Neyman [7.5%]; Le Mignant [10%]; Johansson [10%]; Wetherell [5%]; Lockwood [7.5%]; Reinig [10%] | 270h | 25,008.05 |
| 35 | 1.3.2.1.4.2 | **Detailed Design Phase Plan** |  | 177d? | 2009-04-01 | 2009-12-03 | 77d |  |  | 320h | 30,614.46 |
| 36 | 1.3.2.1.4.2.1 | Detailed Design Plan v1 (FY10 planning) |  | 33d? | 2009-04-01 | 2009-05-15 | 221d | finish no earlier than 2009-05-15 | Wizinowich [15.2%] | 40h | 4,160 |
| 37 | 1.3.2.1.4.2.2 | Detailed Design Plan v2 (TSIP proposal) |  | 18d? | 2009-07-15 | 2009-08-07 | 161d | start no earlier than 2009-07-15 | Wizinowich [22.2%]; Dekany [27.8%]; Gavel [27.8%] | 40h | 4,246.96 |
| 38 | 1.3.2.1.4.2.3 | Detailed Design Plan Final Version |  | 19d? | 2009-11-09 | 2009-12-03 | 77d | start no earlier than 2009-11-09 | Wizinowich [46.1%]; Dekany [19.7%]; Gavel [19.7%]; Max [6.6%]; Lockwood [65.8%]; Nance; Bell; Neyman; Le Mignant; Johansson; Reinig; Velur | 240h | 22,207.5 |
| 39 | 1.3.2.1.4.3 | SEMP Document |  | 15d? | 2010-01-11 | 2010-01-29 | 36d | start no earlier than 2010-01-11 | Wizinowich [30%]; Dekany [20%]; Gavel [13.3%]; Max [3.3%] | 80h | 8,188.96 |
| 40 | 1.3.2.2 | **Project Management & Meetings** |  | 477d? | 2008-05-01 | 2010-02-26 | 16d |  |  | 2294h | 194,437 |
| 41 | 1.3.2.2.1 | **Senior Management Committee** |  | 477d? | 2008-05-01 | 2010-02-26 | 16d |  |  | 624h | 57,757 |
| 42 | 1.3.2.2.1.1 | Senior Management Activities |  | 477d? | 2008-05-01 | 2010-02-26 | 16d | finish no earlier than 2010-02-26 | Dekany [2%]; Gavel [2%]; Max [0.7%]; Wizinowich [3.3%] | 300h | 30,230.5 |
| 43 | 1.3.2.2.1.2 | Senior Management Telecons |  | 477d? | 2008-05-01 | 2010-02-26 | 16d | finish no earlier than 2010-02-26 | Dekany [2%]; Gavel [2%]; Max [2%]; Wizinowich [2%] | 300h | 25,030.5 |
| 44 | 1.3.2.2.1.3 | Implement Full-Time Systems Engineer |  | 87d? | 2009-10-01 | 2010-01-29 | 36d | finish no earlier than 2010-01-29 | Wizinowich [3.4%] | 24h | 2,496 |
| 45 | 1.3.2.2.2 | **Team Meetings** |  | 477d? | 2008-05-01 | 2010-02-26 | 16d |  |  | 1670h | 136,680 |
| 46 | 1.3.2.2.2.1 | Meeting Participation |  | 477d? | 2008-05-01 | 2010-02-26 | 16d | start no earlier than 2008-05-01 | Dekany [4.2%]; Gavel [4.2%]; Wizinowich [4.2%]; Le Mignant [3.9%]; Johansson [4.3%]; Neyman [3.9%]; Bell [2.1%]; Adkins [2.4%]; Kupke [2.4%]; Lockwood [2.4%]; Velur [3.9%]; Wetherell [3.3%]; Reinig [2.6%]; COO ME [2.6%] | 1670h | 136,680 |
| 47 | 1.3.2.2.2.2 | Team Meeting #1 (CIT - 1 day) | milestone | 0d | 2008-05-01 | 2008-05-01 | 493d | start no earlier than 2008-05-01 |  |  |  |
| 48 | 1.3.2.2.2.3 | Team Meeting #2 (telecon) | milestone | 0d | 2008-06-13 | 2008-06-13 | 462d | start no earlier than 2008-06-13 |  |  |  |
| 49 | 1.3.2.2.2.4 | Team Meeting #3 (telecon) | milestone | 0d? | 2008-07-11 | 2008-07-11 | 442d | start no earlier than 2008-07-11 |  |  |  |
| 50 | 1.3.2.2.2.5 | Team Meeting #4 (telecon) | milestone | 0d | 2008-08-15 | 2008-08-15 | 417d | start no earlier than 2008-08-15 |  |  |  |
| 51 | 1.3.2.2.2.6 | Team Meeting #5 (UC - 3 days) | milestone | 0d? | 2008-09-18 | 2008-09-18 | 392d | finish no earlier than 2008-09-18 |  |  |  |
| 52 | 1.3.2.2.2.7 | Team Meeting #6 (telecon) | milestone | 0d | 2008-10-17 | 2008-10-17 | 372d | start no earlier than 2008-10-17 |  |  |  |
| 53 | 1.3.2.2.2.8 | Team Meeting #7 (telecon) | milestone | 0d | 2008-11-14 | 2008-11-14 | 352d | start no earlier than 2008-11-14 |  |  |  |
| 54 | 1.3.2.2.2.9 | Team Meeting #8 (telecon) | milestone | 0d | 2008-12-12 | 2008-12-12 | 332d | start no earlier than 2008-12-12 |  |  |  |
| 55 | 1.3.2.2.2.10 | Team Meeting #9 (telecon) | milestone | 0d | 2009-01-16 | 2009-01-16 | 306d | finish no earlier than 2009-01-16 |  |  |  |
| 56 | 1.3.2.2.2.11 | Team Meeting #10 (WMKO - 4 days) | milestone | 0d | 2009-02-10 | 2009-02-10 | 290d | start no earlier than 2009-02-10 |  |  |  |
| 57 | 1.3.2.2.2.12 | Team Meeting #11 (telecon) | milestone | 0d | 2009-03-13 | 2009-03-13 | 267d | start no earlier than 2009-03-13 |  |  |  |
| 58 | 1.3.2.2.2.13 | Team Meeting #12 (telecon) | milestone | 0d | 2009-04-17 | 2009-04-17 | 242d | start no earlier than 2009-04-17 |  |  |  |
| 59 | 1.3.2.2.2.14 | Team Meeting #13 (telecon) | milestone | 0d | 2009-05-15 | 2009-05-15 | 221d | finish no earlier than 2009-05-15 |  |  |  |
| 60 | 1.3.2.2.2.15 | Team Meeting #14 (telecon) | milestone | 0d | 2009-06-12 | 2009-06-12 | 201d | finish no earlier than 2009-06-12 |  |  |  |
| 61 | 1.3.2.2.2.16 | Team Meeting #15 (telecon) | milestone | 0d | 2009-07-17 | 2009-07-17 | 177d | start no earlier than 2009-07-17 |  |  |  |
| 62 | 1.3.2.2.2.17 | Team Meeting #16 (CIT - 3 days)) | milestone | 0d | 2009-08-20 | 2009-08-20 | 152d | finish no earlier than 2009-08-20 |  |  |  |
| 63 | 1.3.2.2.2.18 | Team Meeting #17 (telecon) | milestone | 0d | 2009-09-18 | 2009-09-18 | 132d | start no earlier than 2009-09-18 |  |  |  |
| 64 | 1.3.2.2.2.19 | Team Meeting #18 (telecon) | milestone | 0d | 2009-10-16 | 2009-10-16 | 112d | start no earlier than 2009-10-16 |  |  |  |
| 65 | 1.3.2.2.2.20 | Team Meeting #19 (telecon) | milestone | 0d | 2009-11-13 | 2009-11-13 | 92d | start no earlier than 2009-11-13 |  |  |  |
| 66 | 1.3.2.2.2.21 | Team Meeting #20 (telecon) | milestone | 0d | 2009-12-11 | 2009-12-11 | 72d | start no earlier than 2009-12-11 |  |  |  |
| 67 | 1.3.2.2.2.22 | Team Meeting #21 (telecon) | milestone | 0d | 2010-01-15 | 2010-01-15 | 47d | start no earlier than 2010-01-15 |  |  |  |

Notes:
- 25: PW
- 26: PW
- 27: PW
- 28: RD
- 29: RD
- 30: RD
- 31: PW
- 33: PW
- 34: PW
- 35: PW
- 36: PW
- 37: PW
- 38: PW
- 39: PW
- 40: PW
- 41: PW
- 42: PW
- 43: PW
- 44: PW
- 45: PW

| ID | WBS | Task | Type | Duration | Start | Finish | Total slack | Constraint | Resources | Work | Cost |
| --- | --- | --- | --- | --- | --- | --- | --- | --- | --- | --- | --- |
| 68 | 1.3.2.2.3 | **Director Telecons** |  | 390d | 2008-05-09 | 2009-11-06 | 97d |  |  |  |  |
| 69 | 1.3.2.2.3.1 | Director Telecon #1 | milestone | 0d | 2008-05-09 | 2008-05-09 | 487d | start no earlier than 2008-05-09 |  |  |  |
| 70 | 1.3.2.2.3.2 | Director Telecon #2 | milestone | 0d | 2008-06-09 | 2008-06-09 | 466d | start no earlier than 2008-06-09 |  |  |  |
| 71 | 1.3.2.2.3.3 | Director Telecon #3 | milestone | 0d | 2008-11-07 | 2008-11-07 | 357d | start no earlier than 2008-11-07 |  |  |  |
| 72 | 1.3.2.2.3.4 | Director Telecon #4 | milestone | 0d | 2009-05-08 | 2009-05-08 | 227d | start no earlier than 2009-05-08 |  |  |  |
| 73 | 1.3.2.2.3.5 | Director Telecon #5 | milestone | 0d | 2009-11-06 | 2009-11-06 | 97d | start no earlier than 2009-11-06 |  |  |  |
| 74 | 1.3.2.3 | **Tracking & Reporting** |  | 478d? | 2008-04-30 | 2010-02-26 | 16d |  |  | 869h | 84,320.39 |
| 75 | 1.3.2.3.1 | **Monthly Status Reports** |  | 477d? | 2008-05-01 | 2010-02-26 | 16d |  |  | 546h | 48,858.75 |
| 76 | 1.3.2.3.1.1 | Monthly Team Status Reports |  | 477d? | 2008-05-01 | 2010-02-26 | 16d | start no earlier than 2008-05-01 | Wizinowich [1%]; Max [0.5%]; Gavel [1%]; Dekany [1%]; Reinig [0.6%]; Johansson [0.8%]; Le Mignant [0.7%]; Velur [1%]; Kupke [0.5%]; Neyman [0.5%]; Lockwood [0.5%]; Bell [0.3%]; Adkins [0.5%]; Wetherell [0.4%] | 340h | 29,079.95 |
| 77 | 1.3.2.3.1.2 | Monthly Project Reports (TSIP, Directors) |  | 467d? | 2008-05-15 | 2010-02-26 | 16d | start no earlier than 2008-05-15 | Wizinowich [2.4%]; Dekany [0.5%]; Gavel [0.5%]; Adkins [0.5%]; Max [0.5%] | 170h | 16,034.8 |
| 78 | 1.3.2.3.1.3 | TSIP Project Report Telecons |  | 464d? | 2008-05-20 | 2010-02-26 | 16d | start no earlier than 2008-05-20 | Adkins [0.5%]; Wizinowich [0.5%] | 36h | 3,744 |
| 79 | 1.3.2.3.2 | **SSC Meetings** |  | 459.88d? | 2008-04-30 | 2010-02-02 | 34.12d |  |  | 91h | 9,768.36 |
| 80 | 1.3.2.3.2.1 | SSC Meeting (CIT) - SDR report | milestone | 0d | 2008-04-30 | 2008-04-30 | 494d | start no earlier than 2008-04-30 |  |  |  |
| 81 | 1.3.2.3.2.2 | SSC Meeting (Keck) |  | 1.12d | 2008-06-18 | 2008-06-19 | 457.88d | start no earlier than 2008-06-18 | Dekany; Gavel; Wizinowich | 13h | 1,395.48 |
| 82 | 1.3.2.3.2.3 | SSC Meeting (UCSC) |  | 1.12d | 2008-11-03 | 2008-11-04 | 359.88d | start no earlier than 2008-11-03 | Dekany; Gavel; Wizinowich | 13h | 1,395.48 |
| 83 | 1.3.2.3.2.4 | SSC Meeting (Keck) |  | 1.12d | 2009-02-19 | 2009-02-20 | 281.88d | start no earlier than 2009-02-19 | Dekany; Gavel; Wizinowich | 13h | 1,395.48 |
| 84 | 1.3.2.3.2.5 | SSC Meeting (CIT) |  | 1.12d | 2009-04-29 | 2009-04-30 | 232.88d | start no earlier than 2009-04-29 | Dekany; Gavel; Wizinowich | 13h | 1,395.48 |
| 85 | 1.3.2.3.2.6 | SSC Meeting (Keck) |  | 1.12d | 2009-06-17 | 2009-06-18 | 197.88d | start no earlier than 2009-06-17 | Dekany; Gavel; Wizinowich | 13h | 1,395.48 |
| 86 | 1.3.2.3.2.7 | SSC Meeting (UCSC) |  | 1.12d | 2009-11-03 | 2009-11-04 | 98.88d | start no earlier than 2009-11-03 | Dekany; Gavel; Wizinowich | 13h | 1,395.48 |
| 87 | 1.3.2.3.2.8 | SSC Meeting (Keck) |  | 1.88d? | 2010-02-01 | 2010-02-02 | 34.12d | start no earlier than 2010-02-01 | Dekany [50%]; Gavel [50%]; Wizinowich [60%] | 13h | 1,395.48 |
| 88 | 1.3.2.3.3 | **Other Presentations** |  | 350d? | 2008-06-02 | 2009-10-02 | 121d |  |  | 232h | 25,693.28 |
| 89 | 1.3.2.3.3.1 | SPIE AO Conference Presentations/Papers |  | 15d? | 2008-06-02 | 2008-06-20 | 456d | start no earlier than 2008-06-02 | Dekany [33.3%]; Gavel [33.3%]; Wizinowich [33.3%] | 120h | 13,349.6 |
| 90 | 1.3.2.3.3.2 | SPIE AO Conference (Marseille) |  | 5d? | 2008-06-23 | 2008-06-28 | 451d | finish no earlier than 2008-06-28 |  |  |  |
| 91 | 1.3.2.3.3.3 | Keck Science Meeting 08 |  | 3d | 2008-09-18 | 2008-09-22 | 390d | start no earlier than 2008-09-18 | Dekany; Gavel; Wizinowich | 56h | 6,171.84 |
| 92 | 1.3.2.3.3.4 | Keck Science Meeting 09 |  | 3d | 2009-09-17 | 2009-09-21 | 130d | start no earlier than 2009-09-17 | Dekany; Gavel; Wizinowich | 56h | 6,171.84 |
| 93 | 1.3.2.3.3.5 | Other |  | 195d? | 2009-01-05 | 2009-10-02 | 121d | finish no earlier than 2009-10-02 |  |  |  |

Notes:
- 68: PW
- 69: PW
- 70: PW
- 71: PW
- 72: PW
- 73: PW
- 74: PW
- 75: PW
- 79: PW
- 88: PW

| ID | WBS | Task | Type | Duration | Start | Finish | Total slack | Constraint | Resources | Work | Cost |
| --- | --- | --- | --- | --- | --- | --- | --- | --- | --- | --- | --- |
| 94 | 1.3.2.4 | **Proposals** |  | 348d? | 2008-06-02 | 2009-09-30 | 123d |  |  | 480h | 4,594.8 |
| 95 | 1.3.2.4.1 | Advancement Support |  | 348d? | 2008-06-02 | 2009-09-30 | 123d | start no earlier than 2008-06-02 | Free [2.9%] | 80h |  |
| 96 | 1.3.2.4.2 | TSIP Proposal for DDR |  | 25d? | 2009-07-28 | 2009-08-31 | 145d | finish no earlier than 2009-08-31 | Dekany [10%]; Gavel [10%]; Max [10%]; Free [90%] | 240h | 4,594.8 |
| 97 | 1.3.2.4.3 | Other Proposal |  | 20d? | 2009-09-03 | 2009-09-30 | 123d | finish no earlier than 2009-09-30 | Free | 160h |  |
| 98 | 1.3.2.5 | **Programmatic Risk Assessment & Mitigation** |  | 400d? | 2008-05-19 | 2009-11-27 | 81d |  |  | 200h | 20,973.92 |
| 99 | 1.3.2.5.1 | **Risk Assessment** |  | 213.25d? | 2008-09-04 | 2009-06-30 | 189d |  |  | 60h | 6,413.92 |
| 100 | 1.3.2.5.1.1 | Programmatic Risk Assessment v1 |  | 6.25d? | 2008-09-04 | 2008-09-12 | 396d | finish no earlier than 2008-09-12 | Wizinowich [40%]; Dekany [8%]; Gavel [8%]; Adkins [8.9%] | 32h | 3,414.96 |
| 101 | 1.3.2.5.1.2 | Programmatic Risk Assessment v2 |  | 2d? | 2009-06-29 | 2009-06-30 | 189d | finish no earlier than 2009-06-30 | Wizinowich; Dekany; Gavel; Adkins | 28h | 2,998.96 |
| 102 | 1.3.2.5.2 | **Risk Mitigation** |  | 400d? | 2008-05-19 | 2009-11-27 | 81d |  |  | 140h | 14,560 |
| 103 | 1.3.2.5.2.1 | Laser Procurement |  | 350d? | 2008-05-26 | 2009-09-25 | 126d | finish no earlier than 2009-09-25 | Wizinowich [1.4%] | 40h | 4,160 |
| 104 | 1.3.2.5.2.2 | Science Instruments |  | 35d? | 2008-10-06 | 2008-11-21 | 346d | finish no earlier than 2008-11-21 | Wizinowich [14.3%] | 40h | 4,160 |
| 105 | 1.3.2.5.2.3 | Funding |  | 95d? | 2008-05-19 | 2008-09-26 | 386d | finish no earlier than 2008-09-26 | Wizinowich [5.3%] | 40h | 4,160 |
| 106 | 1.3.2.5.2.4 | Identify Long Lead Procurements |  | 40d? | 2009-10-05 | 2009-11-27 | 81d | start no earlier than 2009-10-05 | Wizinowich [6.2%] | 20h | 2,080 |
| 107 | 1.3.2.6 | **Preliminary Design Review** |  | 404.33d? | 2008-09-02 | 2010-03-22 | 0d |  |  | 498h | 43,598.2 |
| 108 | 1.3.2.6.1 | Define Success Criteria for all Reviews |  | 8.33d? | 2008-09-02 | 2008-09-12 | 396d | finish no earlier than 2008-09-12 | Wizinowich [60%]; Dekany [12%]; Gavel [12%]; Max [6%] | 60h | 5,997.92 |
| 109 | 1.3.2.6.2 | Review Setup (Date, Participants, Charter) |  | 5d? | 2009-09-07 | 2009-09-11 | 136d | start no earlier than 2009-09-07 | Wizinowich [30%]; Max [10%] | 16h | 1,248 |
| 110 | 1.3.2.6.3 | Preliminary Design Report |  | 12d? | 2010-01-11 | 2010-01-26 | 39d | start no earlier than 2010-01-11 | Wizinowich [52.1%]; Dekany [15.6%]; Gavel [15.6%]; Max [4.2%]; Neyman [2.1%]; Le Mignant [2.1%]; Johansson [2.1%]; Reinig [3.1%]; Velur [5.2%]; Kupke [2.1%] | 100h | 9,866.5 |
| 111 | 1.3.2.6.4 | Review Package Distributed |  | 1d? | 2010-01-27 | 2010-01-27 | 38d | start no earlier than 2010-01-27 | Wizinowich [75%] | 6h | 624 |
| 112 | 1.3.2.6.5 | Reviewer Comments Received | milestone | 0d | 2010-02-10 | 2010-02-10 | 29d | start no earlier than 2010-02-10 |  |  |  |
| 113 | 1.3.2.6.6 | Reviewer Comments Addressed |  | 5d? | 2010-02-11 | 2010-02-17 | 23d | start no earlier than 2010-02-11 | Wizinowich [50%]; Dekany [30%]; Gavel [30%]; Max [40%]; Reinig [5%]; Velur [15%]; Bell [2.5%]; Wetherell [2.5%]; Neyman [5%]; Le Mignant [5%]; Johansson [5%]; Kupke [5%]; Lockwood [5%] | 80h | 6,391.34 |
| 114 | 1.3.2.6.7 | PDR Presentation Preparation |  | 15d? | 2010-02-01 | 2010-02-19 | 21d | start no earlier than 2010-02-01 | Wizinowich [16.7%]; Dekany [10%]; Gavel [10%]; Reinig [3.3%]; Kupke [1.7%]; Lockwood [1.7%]; Velur [5%]; Wetherell [0.8%]; Bell [0.8%]; Neyman [1.7%]; Le Mignant [2.5%]; Johansson [2.5%] | 68h | 6,680.54 |
| 115 | 1.3.2.6.8 | Preliminary Design Review |  | 1d? | 2010-02-22 | 2010-02-22 | 20d | start no earlier than 2010-02-22 | Wizinowich [1250%]; Dekany [1250%]; Max [1250%]; Gavel [1250%]; Velur; Reinig; Lockwood; Kupke; Wetherell; Le Mignant; Neyman; Johansson; COO ME | 120h | 8,688.48 |
| 116 | 1.3.2.6.9 | Reviewer Report Received | milestone | 0d | 2010-03-15 | 2010-03-15 | 6d | start no earlier than 2010-03-15 |  |  |  |
| 117 | 1.3.2.6.10 | Response to Reviewer Report |  | 5d? | 2010-03-16 | 2010-03-22 | 0d | start no earlier than 2010-03-16 | Wizinowich [40%]; Dekany [20%]; Gavel [20%]; Max [20%]; Reinig [5%]; Kupke [2.5%]; Velur [5%]; Neyman [2.5%]; Le Mignant [2.5%]; Johansson [2.5%] | 48h | 4,101.42 |

Notes:
- 94: PW
- 98: PW
- 99: PW
- 102: PW
- 107: PW

| ID | WBS | Task | Duration | Start | Finish | Total slack | Constraint | Resources | Work | Cost |
| --- | --- | --- | --- | --- | --- | --- | --- | --- | --- | --- |
| 118 | 1.3.2.7 | **Project Support** | 477d? | 2008-05-01 | 2010-02-26 | 16d |  |  | 4161h | 198,558.4 |
| 119 | 1.3.2.7.1 | Administrative/Contract Support | 477d? | 2008-05-01 | 2010-02-26 | 16d | start no earlier than 2008-05-01 | Tyau [20.6%]; Contract Administrator [2.1%]; Wizinowich [10.4%]; UC Financial Analyst [24.4%] | 1565h | 76,617 |
| 120 | 1.3.2.7.2 | Shared Infrastructure | 430d? | 2008-07-07 | 2010-02-26 | 16d | finish no earlier than 2010-02-26 | Chock [5.8%] | 200h | 14,000 |
| 121 | 1.3.2.7.3 | Research Time | 477d? | 2008-05-01 | 2010-02-26 | 16d | start no earlier than 2008-05-01 | McGrath [47.3%]; Le Mignant [15.5%] | 2396h | 107,941.4 |
| 122 | 1.3.3 | **Systems Engineering** | 479d? | 2008-04-01 | 2010-01-29 | 36d |  |  | 9473h | 546,861.63 |
| 123 | 1.3.3.1 | **Science Case Requirements** | 457d? | 2008-05-01 | 2010-01-29 | 36d |  |  | 4005h | 141,652.6 |
| 124 | 1.3.3.1.1 | **Science Case Requirements** | 447d? | 2008-05-01 | 2010-01-15 | 46d |  |  | 2701h | 102,413 |
| 125 | 1.3.3.1.1.1 | **Requirements for new Science Drivers** | 183d? | 2008-05-01 | 2009-01-12 | 310d |  |  | 440h | 12,428 |
| 126 | 1.3.3.1.1.1.1 | Astrometry Science in Sparse Fields | 71d? | 2008-10-06 | 2009-01-12 | 310d | finish no earlier than 2009-01-12 | McGrath [7%]; Student [14.1%]; Max [3.5%] | 140h | 4,676 |
| 127 | 1.3.3.1.1.1.2 | Resolved Stellar Populations in Crowded Fields | 61d? | 2008-07-14 | 2008-10-06 | 380d | finish no earlier than 2008-10-06 | Student [24.6%]; Max [8.2%] | 160h | 4,800 |
| 128 | 1.3.3.1.1.1.3 | Debris Disks & Young Stellar Objects | 61d? | 2008-07-14 | 2008-10-06 | 380d | finish no earlier than 2008-10-06 | McGrath [8.2%]; Max [8.2%] | 80h | 1,476 |
| 129 | 1.3.3.1.1.1.4 | QSO Host Galaxies | 52d? | 2008-05-01 | 2008-07-11 | 441d | finish no earlier than 2008-07-11 | McGrath [9.6%]; Max [4.8%] | 60h | 1,476 |
| 130 | 1.3.3.1.1.2 | **Extend SCRD Discussion of Science Drivers** | 168d? | 2008-05-01 | 2008-12-22 | 325d |  |  | 601h | 28,761 |
| 131 | 1.3.3.1.1.2.1 | Nearby AGNs | 52d? | 2008-05-01 | 2008-07-11 | 441d | finish no earlier than 2008-07-11 | McGrath [4.8%]; Max [2.4%] | 30h | 738 |
| 132 | 1.3.3.1.1.2.2 | Gravitational Lensing | 52d? | 2008-05-01 | 2008-07-11 | 441d | finish no earlier than 2008-07-11 | McGrath [9.6%]; Max [1%] | 44h | 1,476 |
| 133 | 1.3.3.1.1.2.3 | Backup Science | 52d? | 2008-05-01 | 2008-07-11 | 441d | finish no earlier than 2008-07-11 | McGrath [4.8%]; Max [1%]; Le Mignant [4.8%] | 44h | 2,138 |
| 134 | 1.3.3.1.1.2.4 | Ice Giant Planets | 61d? | 2008-07-14 | 2008-10-06 | 380d | finish no earlier than 2008-10-06 | McGrath [2%] | 10h | 369 |
| 135 | 1.3.3.1.1.2.5 | GR at Galactic Center | 61d? | 2008-07-14 | 2008-10-06 | 380d | finish no earlier than 2008-10-06 | Student [16.4%]; Max [3.1%] | 95h | 3,200 |
| 136 | 1.3.3.1.1.2.6 | Extrasolar Planets | 52d? | 2008-10-06 | 2008-12-16 | 329d | start no earlier than 2008-10-06 | McGrath [9.6%]; Macintosh [19.2%]; Max [4.8%] | 140h | 11,388 |
| 137 | 1.3.3.1.1.2.7 | Asteroids | 52d? | 2008-05-01 | 2008-07-11 | 441d | finish no earlier than 2008-07-11 | Student [9.6%]; Le Mignant [4.8%]; Max [1.9%] | 68h | 3,000 |
| 138 | 1.3.3.1.1.2.8 | QSO Host Galaxies | 116d? | 2008-07-14 | 2008-12-22 | 325d | finish no earlier than 2008-12-22 | McGrath [6.5%]; Max [2.2%] | 80h | 2,214 |
| 139 | 1.3.3.1.1.2.9 | Backup Science - NGS & Acquisition Camera | 61d? | 2008-07-14 | 2008-10-06 | 380d | finish no earlier than 2008-10-06 | McGrath [4.1%]; Le Mignant [6.1%]; Neyman [4.1%]; Max [4.1%] | 90h | 4,238 |
| 140 | 1.3.3.1.1.3 | **Characterize PSF Stability, Knowledge & Subtraction Requirements** | 226d? | 2008-10-06 | 2009-08-17 | 155d |  |  | 1340h | 52,368 |
| 141 | 1.3.3.1.1.3.1 | Nearby AGNs | 226d? | 2008-10-06 | 2009-08-17 | 155d | finish no earlier than 2009-08-17 | McGrath [8.8%]; Student [19.9%]; Max [3.3%] | 580h | 20,304 |
| 142 | 1.3.3.1.1.3.2 | Galactic Center Astrometry | 97d? | 2008-10-06 | 2009-02-17 | 284d | start no earlier than 2008-10-06 | Student [20.6%]; Max [3.9%] | 190h | 6,400 |
| 143 | 1.3.3.1.1.3.3 | Extrasolar Planets | 96d? | 2009-01-12 | 2009-05-25 | 215d | start no earlier than 2009-01-12 | McGrath [5.2%]; Student [15.6%]; Macintosh [10.4%]; Max [2.6%] | 260h | 16,188 |
| 144 | 1.3.3.1.1.3.4 | Minor Planet Multiplicity | 36d? | 2008-10-20 | 2008-12-08 | 335d | start no earlier than 2008-10-20 | Student [27.8%]; Max [3.5%] | 90h | 3,200 |
| 145 | 1.3.3.1.1.3.5 | QSO Host Galaxies | 81d? | 2008-10-06 | 2009-01-26 | 300d | finish no earlier than 2009-01-26 | McGrath [6.2%]; Student [18.5%]; Max [9.3%] | 220h | 6,276 |
| 146 | 1.3.3.1.1.4 | Characterize Sensitivity & Background Requirements | 96d? | 2009-01-12 | 2009-05-25 | 215d | finish no earlier than 2009-05-25 | McGrath [15.6%]; Max [5.2%] | 160h | 4,428 |
| 147 | 1.3.3.1.1.5 | Science Requirements Summary Matrix | 165d? | 2009-05-25 | 2010-01-08 | 51d | finish no earlier than 2010-01-08 | McGrath [6.1%]; Max [1.5%] | 100h | 2,952 |
| 148 | 1.3.3.1.1.6 | SEMP Input | 75d? | 2009-10-05 | 2010-01-15 | 46d | start no earlier than 2009-10-05 | McGrath [6.7%]; Max [3.3%] | 60h | 1,476 |

Notes:
- 118: PW
- 122: RD
- 123: CM
- 124: CM

| ID | WBS | Task | Duration | Start | Finish | Total slack | Constraint | Resources | Work | Cost |
| --- | --- | --- | --- | --- | --- | --- | --- | --- | --- | --- |
| 149 | 1.3.3.1.2 | **Science Observing Planning & Execution** | 379d? | 2008-08-04 | 2010-01-14 | 47d |  |  | 480h | 20,794 |
| 150 | 1.3.3.1.2.1 | Key Science Driver Observing Scenarios | 120d? | 2008-08-04 | 2009-01-16 | 306d | start no earlier than 2008-08-04 | McGrath [13.5%]; Le Mignant [8.3%]; Max [3.1%] | 240h | 10,397 |
| 151 | 1.3.3.1.2.2 | Design Reference Missions | 119d? | 2009-08-03 | 2010-01-14 | 47d | start no earlier than 2009-08-03 | McGrath [13.7%]; Le Mignant [8.5%]; Max [3.2%] | 240h | 10,397 |
| 152 | 1.3.3.1.3 | **Science Performance Input** | 315d? | 2008-10-06 | 2009-12-18 | 66d |  |  | 180h | 4,797 |
| 153 | 1.3.3.1.3.1 | Define Science Driver Parameters for Performance Budgets | 12d? | 2008-10-13 | 2008-10-28 | 364d | start no earlier than 2008-10-13 | McGrath [10.4%]; Max [10.4%] | 20h | 369 |
| 154 | 1.3.3.1.3.2 | Input to User Interfaces, Planning & Observing Tools | 300d? | 2008-10-06 | 2009-11-27 | 81d | finish no earlier than 2009-11-27 | McGrath [3.3%] | 80h | 2,952 |
| 155 | 1.3.3.1.3.3 | Input to Preliminary Operations Concept Document | 275d? | 2008-12-01 | 2009-12-18 | 66d | finish no earlier than 2009-12-18 | McGrath [1.8%]; Max [1.8%] | 80h | 1,476 |
| 156 | 1.3.3.1.4 | **Science Competitiveness** | 380d? | 2008-07-07 | 2009-12-18 | 66d |  |  | 144h | 3,837.6 |
| 157 | 1.3.3.1.4.1 | Update List of Science Goals for Other Facilities | 380d? | 2008-07-07 | 2009-12-18 | 66d | finish no earlier than 2009-12-18 | McGrath [1.4%]; Max [0.7%] | 64h | 1,623.6 |
| 158 | 1.3.3.1.4.2 | Evaluate NGAO Potential to Compliment Other Facilities | 380d? | 2008-07-07 | 2009-12-18 | 66d | finish no earlier than 2009-12-18 | McGrath [1.3%]; Max [0.3%] | 50h | 1,476 |
| 159 | 1.3.3.1.4.3 | Define NGAO Uniqueness Space | 380d? | 2008-07-07 | 2009-12-18 | 66d | finish no earlier than 2009-12-18 | McGrath [0.7%]; Max [0.3%] | 30h | 738 |
| 160 | 1.3.3.1.5 | **User Community Liaison** | 445d? | 2008-05-19 | 2010-01-29 | 36d |  |  | 220h | 2,583 |
| 161 | 1.3.3.1.5.1 | Enlist People to work on new NGAO Science Aspects | 358d? | 2008-05-19 | 2009-09-30 | 123d | finish no earlier than 2009-09-30 | Max [1.4%]; McGrath [0.7%] | 60h | 738 |
| 162 | 1.3.3.1.5.2 | **SSC & Keck Science Meeting** | 435d? | 2008-06-02 | 2010-01-29 | 36d |  |  | 160h | 1,845 |
| 163 | 1.3.3.1.5.2.1 | Prepare & Give Presentations | 435d? | 2008-06-02 | 2010-01-29 | 36d | finish no earlier than 2010-01-29 | Max [2%]; McGrath [1.1%] | 110h | 1,476 |
| 164 | 1.3.3.1.5.2.2 | Obtain & Document Feedback | 435d? | 2008-06-02 | 2010-01-29 | 36d | finish no earlier than 2010-01-29 | Max [1.1%]; McGrath [0.3%] | 50h | 369 |
| 165 | 1.3.3.1.6 | **Science Advisory Team Meetings** | 385d? | 2008-06-09 | 2009-11-27 | 81d |  |  | 280h | 7,228 |
| 166 | 1.3.3.1.6.1 | Prepare Minutes, Presentations & KAONs | 385d? | 2008-06-09 | 2009-11-27 | 81d | finish no earlier than 2009-11-27 | Max [2.6%]; McGrath [2.6%]; Le Mignant [0.6%] | 180h | 4,352 |
| 167 | 1.3.3.1.6.2 | Refine Science Requirements | 355d? | 2008-07-21 | 2009-11-27 | 81d | finish no earlier than 2009-11-27 | Le Mignant [0.7%] | 20h | 1,400 |
| 168 | 1.3.3.1.6.3 | Evaluate Science Impact of Proposed Changes | 355d? | 2008-07-21 | 2009-11-27 | 81d | finish no earlier than 2009-11-27 | Max [1.4%]; McGrath [1.4%] | 80h | 1,476 |
| 169 | 1.3.3.2 | **Requirements** | 410d? | 2008-05-26 | 2009-12-18 | 66d |  |  | 970h | 68,547 |
| 170 | 1.3.3.2.1 | **Operations Concept Document (OCD)** | 410d? | 2008-05-26 | 2009-12-18 | 66d |  |  | 480h | 34,552 |
| 171 | 1.3.3.2.1.1 | OCD Outline | 10d? | 2008-05-26 | 2008-06-06 | 466d | start no earlier than 2008-05-26 | Le Mignant [40%]; Wizinowich [10%] | 40h | 3,072 |
| 172 | 1.3.3.2.1.2 | OCD Release 1 | 45d? | 2008-12-01 | 2009-01-30 | 296d | start no earlier than 2008-12-01 | Le Mignant [33.3%]; Neyman [13.9%]; Wizinowich [2.8%]; Johansson [5.6%] | 200h | 14,340 |
| 173 | 1.3.3.2.1.3 | OCD Release 2 | 55d? | 2009-10-05 | 2009-12-18 | 66d | start no earlier than 2009-10-05 | Le Mignant [36.4%]; Neyman [11.4%]; Johansson [4.5%]; Wizinowich [2.3%] | 240h | 17,140 |

Notes:
- 149: CM
- 152: CM
- 156: CM
- 160: CM
- 165: CM
- 169: EJ
- 170: DLM
- 171: DLM
- 172: DLM
- 173: DLM

| ID | WBS | Task | Duration | Start | Finish | Total slack | Constraint | Resources | Work | Cost |
| --- | --- | --- | --- | --- | --- | --- | --- | --- | --- | --- |
| 174 | 1.3.3.2.2 | **System Requirements (SRD)** | 225d? | 2009-02-02 | 2009-12-11 | 71d |  |  | 80h | 5,600 |
| 175 | 1.3.3.2.2.1 | SRD Release I | 53d? | 2009-02-02 | 2009-04-15 | 243d | finish no earlier than 2009-04-15 | Johansson [11.8%] | 50h | 3,500 |
| 176 | 1.3.3.2.2.2 | SRD Release 2 | 10d? | 2009-11-30 | 2009-12-11 | 71d | finish no earlier than 2009-12-11 | Johansson [37.5%] | 30h | 2,100 |
| 177 | 1.3.3.2.3 | **Functional Requirements (FRD)** | 339d? | 2008-09-02 | 2009-12-18 | 66d |  |  | 250h | 21,395 |
| 178 | 1.3.3.2.3.1 | FRD Release 1 | 35d? | 2008-09-02 | 2008-10-20 | 370d | start no earlier than 2008-09-02 | Johansson [14.3%]; Dekany [10.7%]; Wizinowich [7.1%]; Gavel [10.7%] | 120h | 11,772.2 |
| 179 | 1.3.3.2.3.2 | FRD Release 2 | 35d? | 2009-11-02 | 2009-12-18 | 66d | start no earlier than 2009-11-02 | Johansson [17.9%]; Dekany [7.1%] | 70h | 5,422.8 |
| 180 | 1.3.3.2.3.3 | Compliance Matrix | 20d? | 2009-11-23 | 2009-12-18 | 66d | start no earlier than 2009-11-23 | Johansson [37.5%] | 60h | 4,200 |
| 181 | 1.3.3.2.4 | Software Standards (Define & Document) | 21d? | 2008-09-02 | 2008-09-30 | 384d | finish no earlier than 2008-09-30 | Johansson [11.9%]; Johnson [35.7%] | 80h | 1,400 |
| 182 | 1.3.3.2.5 | Component Standards (Define & Document) | 33d? | 2009-08-17 | 2009-09-30 | 123d | start no earlier than 2009-08-17 | Johansson [30.3%] | 80h | 5,600 |
| 183 | 1.3.3.3 | **Systems Engineering Analysis** | 427d? | 2008-05-01 | 2009-12-18 | 66d |  |  | 1790h | 143,769.16 |
| 184 | 1.3.3.3.1 | **Performance Budgets** | 389d? | 2008-06-24 | 2009-12-18 | 66d |  |  | 870h | 73,095.56 |
| 185 | 1.3.3.3.1.1 | Requirements Flowdown Report | 15d? | 2009-11-30 | 2009-12-18 | 66d | start no earlier than 2009-11-30 | Dekany [50%] | 60h | 5,768.4 |
| 186 | 1.3.3.3.1.2 | **Throughput & Background Budget** | 30d? | 2008-11-03 | 2008-12-12 | 331d |  |  | 80h | 7,691.2 |
| 187 | 1.3.3.3.1.2.1 | Thermal Background Analysis Software with Documentation | 15d? | 2008-11-03 | 2008-11-21 | 346d | finish no earlier than 2008-11-21 | Bouchez [41.7%] | 50h | 4,807 |
| 188 | 1.3.3.3.1.2.2 | Thermal Analysis | 10d? | 2008-12-01 | 2008-12-12 | 331d | finish no earlier than 2008-12-12 | Bouchez [37.5%] | 30h | 2,884.2 |
| 189 | 1.3.3.3.1.3 | **Wavefront & Encircled Energy** | 325d? | 2008-09-01 | 2009-11-27 | 81d |  |  | 370h | 36,595.96 |
| 190 | 1.3.3.3.1.3.1 | **WFE/EE Budget Tool** | 325d? | 2008-09-01 | 2009-11-27 | 81d |  |  | 322h | 31,981.24 |
| 191 | 1.3.3.3.1.3.1.1 | NGS TT & TTFA Sharpening Budgets | 31.5d? | 2008-10-06 | 2008-11-18 | 349.5d | start no earlier than 2008-10-06 | Dekany [23.8%] | 60h | 5,768.4 |
| 192 | 1.3.3.3.1.3.1.2 | Improved Bandwidth Model | 25d? | 2008-12-01 | 2009-01-02 | 316d | start no earlier than 2008-12-01 | Dekany [4%]; Gavel [36%] | 80h | 10,388.32 |
| 193 | 1.3.3.3.1.3.1.3 | Improved Atmospheric Dispersion Model | 15d? | 2008-09-01 | 2008-09-19 | 391d | start no earlier than 2008-09-01 | Bouchez [33.3%] | 40h | 3,845.6 |
| 194 | 1.3.3.3.1.3.1.4 | NFIRAOS Budget Comparison | 33d? | 2008-10-01 | 2008-11-14 | 351d | start no earlier than 2008-10-01 | Dekany [18.2%]; Neyman [9.1%] | 72h | 6,294.72 |
| 195 | 1.3.3.3.1.3.1.5 | Determine Additional Performance Modeling/Anchoring | 5d? | 2008-11-17 | 2008-11-21 | 346d | finish no earlier than 2008-11-21 | Dekany [25%] | 10h | 961.4 |
| 196 | 1.3.3.3.1.3.1.6 | Perform Additional Performance Modeling/Anchoring | 40d? | 2009-10-05 | 2009-11-27 | 81d | finish no earlier than 2009-11-27 | Dekany [6.2%]; Neyman [12.5%] | 60h | 4,722.8 |
| 197 | 1.3.3.3.1.3.2 | **WFE/EE Performance Analysis** | 195d? | 2008-12-01 | 2009-08-28 | 146d |  |  | 48h | 4,614.72 |
| 198 | 1.3.3.3.1.3.2.1 | Key Science Cases Analysis | 20d? | 2009-06-01 | 2009-06-26 | 191d | start no earlier than 2009-06-01 | Dekany [15%] | 24h | 2,307.36 |
| 199 | 1.3.3.3.1.3.2.2 | Additional Science Case Analysis | 20d? | 2009-08-03 | 2009-08-28 | 146d | finish no earlier than 2009-08-28 | Dekany [5%] | 8h | 769.12 |
| 200 | 1.3.3.3.1.3.2.3 | Laser Return Evaluation | 10d? | 2008-12-01 | 2008-12-12 | 331d | finish no earlier than 2008-12-12 | Dekany [20%] | 16h | 1,538.24 |

Notes:
- 174: EJ
- 175: EJ
- 176: EJ
- 177: EJ
- 178: EJ
- 179: EJ
- 180: EJ
- 181: EJ
- 182: EJ
- 183: RD
- 184: RD
- 185: RD
- 186: AB
- 189: RD
- 190: RD
- 191: RD
- 192: RD
- 193: AB
- 194: RD
- 195: RD
- 196: RD
- 197: RD
- 198: RD
- 199: RD
- 200: RD

| ID | WBS | Task | Duration | Start | Finish | Predecessors | Total slack | Free slack | Constraint | Resources | Work | Cost |
| --- | --- | --- | --- | --- | --- | --- | --- | --- | --- | --- | --- | --- |
| 201 | 1.3.3.3.1.4 | **Astrometric Precision** | 105d? | 2008-10-06 | 2009-02-27 |  | 276d |  |  |  | 200h | 11,840 |
| 202 | 1.3.3.3.1.4.1 | Develop Astrometric Budget Tool | 55d? | 2008-10-06 | 2008-12-19 |  | 326d |  | start no earlier than 2008-10-06 | Lu [13.6%]; Wizinowich [13.6%] | 120h | 6,240 |
| 203 | 1.3.3.3.1.4.2 | Galactic Center Astrometric Analysis | 40d? | 2009-01-05 | 2009-02-27 |  | 276d |  | start no earlier than 2009-01-05 | Neyman [25%] | 80h | 5,600 |
| 204 | 1.3.3.3.1.5 | **Observing Efficiency** | 266d? | 2008-06-24 | 2009-06-30 |  | 189d |  |  |  | 80h | 5,600 |
| 205 | 1.3.3.3.1.5.1 | Observing Efficiency Tool | 5d? | 2008-06-24 | 2008-06-30 |  | 450d |  | finish no earlier than 2008-06-30 | Le Mignant | 40h | 2,800 |
| 206 | 1.3.3.3.1.5.2 | Observing Efficiency Analysis | 5d? | 2009-06-24 | 2009-06-30 |  | 189d |  | finish no earlier than 2009-06-30 | Le Mignant | 40h | 2,800 |
| 207 | 1.3.3.3.1.6 | **Observing Uptime** | 250d? | 2008-12-01 | 2009-11-13 |  | 91d |  |  |  | 80h | 5,600 |
| 208 | 1.3.3.3.1.6.1 | Observing Uptime Tool | 10d? | 2008-12-01 | 2008-12-12 |  | 331d |  | start no earlier than 2008-12-01 | Neyman [50%] | 40h | 2,800 |
| 209 | 1.3.3.3.1.6.2 | Observing Uptime Analysis | 10d? | 2009-11-02 | 2009-11-13 |  | 91d |  | start no earlier than 2009-11-02 | Johansson [25%]; Neyman [25%] | 40h | 2,800 |
| 210 | 1.3.3.3.2 | **Modeling & Analysis** | 247d? | 2008-05-01 | 2009-04-10 |  | 246d |  |  |  | 840h | 65,073.6 |
| 211 | 1.3.3.3.2.1 | T/T Sharpening Study Report | 42d? | 2008-05-01 | 2008-06-27 |  | 451d |  | start no earlier than 2008-05-01 | Dekany [23.8%]; Neyman [47.6%] | 240h | 18,891.2 |
| 212 | 1.3.3.3.2.2 | Performance vs T/T NGS Report | 32d? | 2008-09-01 | 2008-10-14 |  | 374d |  | start no earlier than 2008-09-01 | Dekany [41.7%]; Neyman [62.5%] | 200h | 15,045.6 |
| 213 | 1.3.3.3.2.3 | Galactic Center Performance Report | 30d? | 2009-03-02 | 2009-04-10 |  | 246d |  | start no earlier than 2009-03-02 | Dekany [50%]; Neyman [50%] | 240h | 19,936.8 |
| 214 | 1.3.3.3.2.4 | PSF Libraries | 35d? | 2008-11-03 | 2008-12-19 |  | 326d |  | finish no earlier than 2008-12-19 | Neyman [57.1%] | 160h | 11,200 |
| 215 | 1.3.3.3.3 | PSF Calibration | 125d? | 2009-05-04 | 2009-10-23 |  | 106d |  | start no earlier than 2009-05-04 | Le Mignant [8%] | 80h | 5,600 |
| 216 | 1.3.3.4 | **System Architecture** | 411d? | 2008-05-05 | 2009-11-30 |  | 80d |  |  |  | 1070h | 72,784.16 |
| 217 | 1.3.3.4.1 | **System Hardware Architecture** | 391d? | 2008-06-02 | 2009-11-30 |  | 80d |  |  |  | 264h | 22,244.16 |
| 218 | 1.3.3.4.1.1 | Hybrid Rayleigh / Sodium Trade Study | 65d? | 2008-06-30 | 2008-09-26 |  | 386d |  | start no earlier than 2008-06-30 | Dekany [15.4%]; Neyman [15.4%] | 160h | 13,291.2 |
| 219 | 1.3.3.4.1.2 | Degraded Laser Power Trade Study | 10d? | 2008-08-04 | 2008-08-15 |  | 416d |  | start no earlier than 2008-08-04 | Neyman [50%] | 40h | 2,800 |
| 220 | 1.3.3.4.1.3 | System Architecture: Evaluate & Document Changes | 391d? | 2008-06-02 | 2009-11-30 |  | 80d |  | start no earlier than 2008-06-02 | Dekany [2%] | 64h | 6,152.96 |
| 221 | 1.3.3.4.2 | **Software Architecture** | 261d? | 2008-10-01 | 2009-09-30 |  | 123d |  |  |  | 162h | 5,460 |
| 222 | 1.3.3.4.2.1 | Evaluate Software Architecture Options | 20d? | 2008-10-01 | 2008-10-28 |  | 344d | 0d | start no earlier than 2008-10-01 | Johansson [9.4%]; Morrison [9.4%]; Johnson [12.5%] | 50h | 2,100 |
| 223 | 1.3.3.4.2.2 | Determine/Document Software Arch Approach | 20d? | 2008-10-29 | 2008-11-25 | 222 | 344d |  | finish no earlier than 2008-09-19 | Johansson [25%]; Johnson [25%] | 80h | 2,800 |
| 224 | 1.3.3.4.2.3 | Software Architecture: Evaluate & Document Changes | 221d? | 2008-11-26 | 2009-09-30 |  | 123d |  | finish no earlier than 2009-09-30 | Johnson [1.4%]; Johansson [0.5%] | 32h | 560 |

Notes:
- 201: PW
- 204: DLM
- 207: EJ
- 210: RD
- 215: DLM
- 216: RD
- 217: RD
- 221: EJ
- 222: EJ
- 223: EJ
- 224: EJ

| ID | WBS | Task | Duration | Start | Finish | Predecessors | Total slack | Free slack | Constraint | Resources | Work | Cost |
| --- | --- | --- | --- | --- | --- | --- | --- | --- | --- | --- | --- | --- |
| 225 | 1.3.3.4.3 | **Control Systems Architecture** | 261d? | 2008-10-01 | 2009-09-30 |  | 123d |  |  |  | 420h | 29,400 |
| 226 | 1.3.3.4.3.1 | Evaluate Control Systems Arch Options | 109d? | 2008-10-01 | 2009-03-02 |  | 123d | 0d | finish no earlier than 2009-03-02 | Johansson [9.2%] | 80h | 5,600 |
| 227 | 1.3.3.4.3.2 | Determine/Document Control Systems Arch | 36d? | 2009-03-03 | 2009-04-21 | 226 | 123d | 0d | start no earlier than 2008-11-17 | Johansson [34.7%] | 100h | 7,000 |
| 228 | 1.3.3.4.3.3 | Evaluate Motion Control Arch Options | 37d? | 2008-10-01 | 2008-11-20 |  | 327d | 0d | start no earlier than 2008-10-01 | Johansson [6.8%]; Wetherell [33.8%] | 120h | 8,400 |
| 229 | 1.3.3.4.3.4 | Determine/Document Motion Control Arch | 20d? | 2008-11-21 | 2008-12-18 | 228 | 327d |  |  | Johansson [18.8%]; Wetherell [18.8%] | 60h | 4,200 |
| 230 | 1.3.3.4.3.5 | Control Systems Architecture: Evaluate & Document Changes | 116d? | 2009-04-22 | 2009-09-30 | 227 | 123d |  |  | Johansson [4.3%]; Wetherell [2.2%] | 60h | 4,200 |
| 231 | 1.3.3.4.4 | **Operations Sequences Architecture** | 330d? | 2008-05-05 | 2009-08-07 |  | 161d |  |  |  | 224h | 15,680 |
| 232 | 1.3.3.4.4.1 | Define Required System Level Sequences | 10d? | 2008-05-05 | 2008-05-16 |  | 481d |  | start no earlier than 2008-05-05 | Le Mignant [50%] | 40h | 2,800 |
| 233 | 1.3.3.4.4.2 | Develop System Level Sequences Approach | 15d? | 2008-05-19 | 2008-06-06 |  | 466d |  | finish no earlier than 2008-06-06 | Le Mignant [33.3%] | 40h | 2,800 |
| 234 | 1.3.3.4.4.3 | Sequences Definition Document | 15d? | 2008-06-09 | 2008-06-27 |  | 451d |  | start no earlier than 2008-06-09 | Le Mignant [66.7%] | 80h | 5,600 |
| 235 | 1.3.3.4.4.4 | Sequences: Evaluate & Document Changes | 285d? | 2008-07-07 | 2009-08-07 |  | 161d |  | start no earlier than 2008-07-07 | Le Mignant [2.8%] | 64h | 4,480 |
| 236 | 1.3.3.5 | **External Interface Control** | 169d? | 2008-10-06 | 2009-05-28 |  | 212d |  |  |  | 244h | 18,872.18 |
| 237 | 1.3.3.5.1 | **Observatory Interfaces** | 147d? | 2008-10-06 | 2009-04-28 |  | 234d |  |  |  | 120h | 8,740 |
| 238 | 1.3.3.5.1.1 | AO System ICD | 15d? | 2009-02-02 | 2009-02-20 |  | 281d |  | finish no earlier than 2009-02-20 | Neyman [33.3%] | 40h | 2,800 |
| 239 | 1.3.3.5.1.2 | Laser System ICD | 10d? | 2008-10-06 | 2008-10-17 |  | 371d |  | finish no earlier than 2008-10-17 | Chin [12.5%]; Neyman [25%]; Adkins [12.5%] | 40h | 3,140 |
| 240 | 1.3.3.5.1.3 | Science Tools ICD | 20d? | 2009-04-01 | 2009-04-28 |  | 234d |  | start no earlier than 2009-04-01 | Le Mignant [15.6%]; Johansson | 40h | 2,800 |
| 241 | 1.3.3.5.2 | **Science Instrument Interfaces to NGAO** | 169d? | 2008-10-06 | 2009-05-28 |  | 212d |  |  |  | 124h | 10,132.18 |
| 242 | 1.3.3.5.2.1 | Generic Science Instrument ICD to AO | 20d? | 2008-10-06 | 2008-10-31 |  | 361d |  | finish no earlier than 2008-10-31 | Adkins [5%]; Neyman [12.5%]; Lockwood [2.5%]; Kupke [2.5%]; Bell [2.5%] | 40h | 3,049.64 |
| 243 | 1.3.3.5.2.2 | Generic Science Instrument ICD to NGAO Science Tools | 20d? | 2009-05-01 | 2009-05-28 |  | 212d |  | start no earlier than 2009-05-01 | Adkins [9.4%]; Le Mignant [9.4%]; Johansson | 40h | 3,310 |
| 244 | 1.3.3.5.2.3 | Interferometer Specific ICD | 20d? | 2008-11-03 | 2008-11-28 |  | 341d |  | finish no earlier than 2008-11-28 | Neyman [7.5%] | 12h | 840 |
| 245 | 1.3.3.5.2.4 | OSIRIS Specific ICD | 20d? | 2008-11-03 | 2008-11-28 |  | 341d |  | start no earlier than 2008-11-03 | Adkins [2.5%]; Kupke [1.2%]; Bell [1.2%] | 8h | 651.72 |
| 246 | 1.3.3.5.2.5 | NIR Camera Specific ICD | 20d? | 2008-11-03 | 2008-11-28 |  | 341d |  | start no earlier than 2008-11-03 | Adkins [1.2%]; Kupke [0.6%]; Lockwood [0.6%] | 4h | 342.85 |
| 247 | 1.3.3.5.2.6 | Visible Camera Specific ICD | 20d? | 2008-11-03 | 2008-11-28 |  | 341d |  | start no earlier than 2008-11-03 | Adkins [1.2%]; Kupke [0.6%]; Lockwood [0.6%] | 4h | 342.85 |
| 248 | 1.3.3.5.2.7 | d-IFS Specific ICD | 20d? | 2008-11-03 | 2008-11-28 |  | 341d |  | start no earlier than 2008-11-03 | Adkins [6.2%]; Wizinowich [2.5%]; Bell [1.2%] | 16h | 1,595.12 |

Notes:
- 225: EJ
- 226: EJ
- 227: EJ
- 228: EJ
- 229: EJ
- 230: EJ
- 231: DLM
- 236: CN
- 237: CN
- 238: CN
- 239: CN
- 240: DLM
- 241: SA
- 242: CN
- 243: DLM
- 244: CN
- 245: SA
- 246: SA
- 247: SA
- 248: SA

| ID | WBS | Task | Duration | Start | Finish | Total slack | Constraint | Resources | Work | Cost |
| --- | --- | --- | --- | --- | --- | --- | --- | --- | --- | --- |
| 249 | 1.3.3.6 | **Internal Interface Control** | 100d? | 2008-08-04 | 2008-12-19 | 326d |  |  | 280h | 24,796 |
| 250 | 1.3.3.6.1 | Diagram & Document Draft Outline | 40d? | 2008-08-04 | 2008-09-26 | 386d | finish no earlier than 2008-09-26 | Neyman [12.5%]; Wizinowich [3.1%] | 50h | 3,840 |
| 251 | 1.3.3.6.2 | Interface N-Squared Diagram | 25d? | 2008-10-06 | 2008-11-07 | 356d | start no earlier than 2008-10-06 | Neyman [20%]; Gavel [20%]; Velur [10%] | 100h | 10,064 |
| 252 | 1.3.3.6.3 | Interface Definition Document | 40d? | 2008-10-27 | 2008-12-19 | 326d | start no earlier than 2008-10-27 | Neyman [28.1%]; Gavel [6.2%]; Velur [6.2%] | 130h | 10,892 |
| 253 | 1.3.3.7 | **Configuration Control** | 109d? | 2009-05-01 | 2009-09-30 | 123d |  |  | 218h | 17,944.28 |
| 254 | 1.3.3.7.1 | Change Control Guidelines & Tools Definition | 109d? | 2009-05-01 | 2009-09-30 | 123d | start no earlier than 2009-05-01 | Wetherell [60.6%]; Johansson [13.8%]; Gavel [50%]; Dekany [50%]; Bell | 218h | 17,944.28 |
| 255 | 1.3.3.8 | **Documentation Control** | 5d? | 2009-01-12 | 2009-01-16 | 306d |  |  | 20h | 1,400 |
| 256 | 1.3.3.8.1 | Document Control Guidelines & Tools Definition | 5d? | 2009-01-12 | 2009-01-16 | 306d | finish no earlier than 2009-01-16 | Johansson [50%] | 20h | 1,400 |
| 257 | 1.3.3.9 | **Technical Risk Assessment & Mitigation** | 392d? | 2008-04-01 | 2009-09-30 | 123d |  |  | 756h | 44,766 |
| 258 | 1.3.3.9.1 | **Risk Assessment** | 229.2d? | 2008-10-13 | 2009-08-28 | 146d |  |  | 100h | 10,834.8 |
| 259 | 1.3.3.9.1.1 | Risk Assessment v1 | 13.2d? | 2008-10-13 | 2008-10-30 | 362d | finish no earlier than 2008-10-30 | Wizinowich [28.4%]; Gavel [28.4%] | 50h | 5,792 |
| 260 | 1.3.3.9.1.2 | Risk Assessment v2 | 12d? | 2009-08-13 | 2009-08-28 | 146d | finish no earlier than 2009-08-28 | Wizinowich [31.2%]; Dekany [31.2%] | 50h | 5,042.8 |
| 261 | 1.3.3.9.2 | **Risk Mitigation Efforts** | 392d? | 2008-04-01 | 2009-09-30 | 123d |  |  | 656h | 33,931.2 |
| 262 | 1.3.3.9.2.1 | **PSF Calibration** | 100d? | 2008-09-15 | 2009-01-30 | 296d |  |  | 200h | 14,680 |
| 263 | 1.3.3.9.2.1.1 | Support/Monitor Profiler Implementation | 100d? | 2008-09-15 | 2009-01-30 | 296d | start no earlier than 2008-09-15 | Neyman [22.5%]; Wizinowich [2.5%] | 200h | 14,680 |
| 264 | 1.3.3.9.2.2 | **Sky Coverage** | 135d? | 2008-10-06 | 2009-04-10 | 246d |  |  | 400h | 12,480 |
| 265 | 1.3.3.9.2.2.1 | Prototype NIR Tip/tilt Sensor | 135d? | 2008-10-06 | 2009-04-10 | 246d | start no earlier than 2008-10-06 | COO ME [25%]; Velur [12%] | 400h | 12,480 |
| 266 | 1.3.3.9.2.3 | **On-Sky & Lab Demonstration Coordination** | 392d? | 2008-04-01 | 2009-09-30 | 123d |  |  | 56h | 6,771.2 |
| 267 | 1.3.3.9.2.3.1 | Define Demonstrations | 34d? | 2008-04-01 | 2008-08-29 | 406d |  | Gavel [4.4%]; Wizinowich [1.5%] | 16h | 2,019.2 |
| 268 | 1.3.3.9.2.3.2 | Analyze & Document Demonstration Results | 261d? | 2008-10-01 | 2009-09-30 | 123d | start no earlier than 2008-10-01 | Gavel [1%]; Wizinowich [1%] | 40h | 4,752 |
| 269 | 1.3.3.10 | Preliminary Design Manual | 101.67d? | 2009-08-03 | 2009-12-22 | 64.33d | start no earlier than 2009-08-03 | Wizinowich [9.8%]; Dekany [4.4%]; Gavel [2.2%]; Reinig [0.2%]; Velur [0.4%]; Neyman [0.2%]; Le Mignant [0.4%]; Johansson [0.4%]; Kupke [0.2%]; Lockwood [0.2%] | 120h | 12,330.25 |
| 270 | 1.3.4 | **AO System Design** | 425d? | 2008-05-12 | 2009-12-25 | 61d |  |  | 10483h | 744,178.02 |
| 271 | 1.3.4.1 | AO Enclosure | 130d? | 2008-10-01 | 2009-03-31 | 254d | finish no earlier than 2009-03-31 | Bell [28.8%] | 300h | 20,868 |
| 272 | 1.3.4.2 | **Opto-Mechanical** | 371d? | 2008-06-02 | 2009-11-02 | 100d |  |  | 5373h | 348,841.62 |
| 273 | 1.3.4.2.1 | AO Support Structure | 50d? | 2008-11-03 | 2009-01-09 | 311d | start no earlier than 2008-11-03 | Lockwood [36%]; Gavel [4%] | 160h | 14,600.8 |
| 274 | 1.3.4.2.2 | Rotator | 13d? | 2009-03-12 | 2009-03-30 | 255d | start no earlier than 2009-03-12 | Lockwood [86.5%]; Kupke [17.3%]; Gavel [11.5%] | 120h | 10,262.1 |
| 275 | 1.3.4.2.3 | Optical Relays | 80d? | 2008-12-29 | 2009-04-17 | 241d | start no earlier than 2008-12-28 | Lockwood [30.2%]; Kupke [45.3%]; Gavel [7.8%] | 533h | 37,391.15 |
| 276 | 1.3.4.2.4 | Optical Switchyard | 70d? | 2008-08-04 | 2008-11-07 | 356d | start no earlier than 2008-08-04 | Lockwood [38.6%]; Kupke [25.7%]; Gavel [7.1%] | 400h | 30,994 |

Notes:
- 249: CN
- 250: CN
- 251: CN
- 252: CN
- 253: EJ
- 254: EJ
- 255: EJ
- 256: EJ
- 257: PW
- 258: PW
- 259: PW
- 260: PW
- 261: PW
- 263: CN
- 265: VV
- 266: DG
- 267: DG
- 268: DG
- 269: PW
- 270: DG
- 271: JB
- 272: DG
- 273: CL
- 274: CL
- 275: RK
- 276: RK

| ID | WBS | Task | Duration | Start | Finish | Predecessors | Total slack | Free slack | Constraint | Resources | Work | Cost |
| --- | --- | --- | --- | --- | --- | --- | --- | --- | --- | --- | --- | --- |
| 277 | 1.3.4.2.5 | **LGS Wavefront Sensor Assembly** | 203d? | 2008-06-02 | 2009-03-11 |  | 268d |  |  |  | 1520h | 75,200.45 |
| 278 | 1.3.4.2.5.1 | Review concept design for LGS WFS assembly (includes OSM) | 20d? | 2008-06-02 | 2008-06-27 |  | 268d | 0d | start no earlier than 2008-06-02 | COO ME [50%]; Velur [25%] | 120h | 3,840 |
| 279 | 1.3.4.2.5.2 | Develop to preliminary design level the opto-mechanical design for the LGS wavefront sensor unit. | 70d? | 2008-06-30 | 2008-10-03 | 278 | 268d | 0d |  | COO ME [50%]; Velur [25%] | 420h | 13,440 |
| 280 | 1.3.4.2.5.3 | Identify the issues with uplink TTM, asterism generation and OSM concepts to ensure it conforms to the dithering requirements. This is important when the LGSs have to move with the source | 19.25d? | 2008-10-06 | 2008-10-31 | 279 | 268d | 0d |  | Velur [18.7%]; COO ME [50%] | 100h | 2,688.45 |
| 281 | 1.3.4.2.5.4 | Develop to preliminary design level the opto-mechanical design for the LGS OSM. (overlaps with TT(FA) OSMs; hence costed there) | 10d? | 2008-11-03 | 2008-11-14 | 280 | 268d | 0d | start no earlier than 2008-09-15 | COO ME [25%]; Velur [25%] | 40h | 1,920 |
| 282 | 1.3.4.2.5.5 | Package and model the assembly | 20d? | 2008-11-17 | 2008-12-25 | 281 | 268d | 0d |  | COO ME [50%]; Velur [75%] | 200h | 11,520 |
| 283 | 1.3.4.2.5.6 | Develop background model and work out stray LGS light problems. | 13.33d? | 2008-12-25 | 2009-01-13 | 282 | 309.33d |  |  | Velur [75%] | 80h | 7,680 |
| 284 | 1.3.4.2.5.7 | Identify the motion control needs and specify solutions. | 20d? | 2008-12-25 | 2009-01-22 | 282 | 268d | 0d |  | Wetherell [50%]; Hale [50%]; Velur [50%] | 240h | 20,960 |
| 285 | 1.3.4.2.5.8 | Identify design risks and mitigation of the identified risks. | 4.67d? | 2009-01-22 | 2009-01-28 | 284 | 268d | 0d |  | COO ME [142%]; Velur [75%] | 80h | 2,592 |
| 286 | 1.3.4.2.5.9 | Develop a preliminary integration plan for the assembly. | 10d? | 2009-01-29 | 2009-02-11 | 285 | 268d | 0d |  | COO ME [62.5%]; Velur [40.9%] | 80h | 2,880 |
| 287 | 1.3.4.2.5.10 | LGS WFS Assembly Documentation | 20d? | 2009-02-12 | 2009-03-11 | 286 | 268d |  |  | COO ME [50%]; Velur [50%] | 160h | 7,680 |
| 288 | 1.3.4.2.6 | **NGS WFS/TWFS Assembly** | 143d? | 2009-04-16 | 2009-11-02 |  | 100d |  |  |  | 628h | 31,528 |
| 289 | 1.3.4.2.6.1 | Review concept design for NGS WFS and TWFS; jointly called NGS WFS assembly. | 10d? | 2009-04-16 | 2009-04-29 |  | 128.5d | 0d |  | COO ME [50%] | 40h |  |
| 290 | 1.3.4.2.6.2 | Develop to preliminary design level the opto-mechanical design for the NGS wavefront sensor assembly. | 28d? | 2009-04-30 | 2009-06-08 | 289 | 128.5d | 0d | start no earlier than 2009-01-19 | COO ME [44.6%]; Velur [44.6%] | 200h | 9,600 |
| 291 | 1.3.4.2.6.3 | Check compliance of design with the design of the field steering mirror assembly. | 14d? | 2009-06-09 | 2009-06-26 | 290 | 128.5d | 0d |  | Velur [44.6%]; COO ME [44.6%] | 100h | 4,800 |
| 292 | 1.3.4.2.6.4 | Package and model the NGS WFS assembly. | 18d? | 2009-06-29 | 2009-08-20 | 291 | 128.5d | 0d |  | COO ME [40.3%]; Velur [40.3%] | 116h | 5,568 |
| 293 | 1.3.4.2.6.5 | Identify the motion control needs and specify solutions. | 7d? | 2009-08-21 | 2009-08-31 | 292 | 128.5d | 0d |  | Hale [50%]; Wetherell [50%] | 56h | 4,648 |
| 294 | 1.3.4.2.6.6 | Identify design risks and mitigation of the identified risks. | 4.67d? | 2009-09-01 | 2009-09-07 | 293 | 128.5d | 0d |  | Velur [75%] | 28h | 2,688 |
| 295 | 1.3.4.2.6.7 | Check compliance with alignment plan for the NGS OSM (written as part of opto-mechanical relay sub-system design effort). | 4.83d? | 2009-09-07 | 2009-09-14 | 294 | 128.5d | 28.5d |  | COO ME [41.4%]; Velur [41.4%] | 32h | 1,536 |
| 296 | 1.3.4.2.6.8 | NGS WFS Assembly Documentation | 7d? | 2009-10-23 | 2009-11-02 | 295 | 100d |  | finish no earlier than 2009-11-02 | Velur [50%]; COO ME [50%] | 56h | 2,688 |
| 297 | 1.3.4.2.7 | **Low Order Wavefront Sensor Assembly** | 321d? | 2008-08-11 | 2009-11-02 |  | 100d |  |  |  | 1564h | 119,388.32 |
| 298 | 1.3.4.2.7.1 | Review concept design for LOWFS assembly. | 26.67d? | 2008-08-11 | 2008-09-16 |  | 148d | 0d | start no earlier than 2008-08-11 | COO ME [15%]; Hale [15%] | 64h | 3,072 |
| 299 | 1.3.4.2.7.2 | Investigate optimum method of dithering based on requirements. | 25.33d? | 2008-09-16 | 2008-10-21 | 298 | 148d | 2d |  | Hale [19.7%]; Velur [19.7%] | 80h | 7,680 |
| 300 | 1.3.4.2.7.3 | Develop to preliminary design level the opto-mechanical design for the tip-tilt and the TTFA-TWFS wavefront sensor units | 24d? | 2009-01-12 | 2009-02-12 | 299 | 147d | 0d |  | Hale [50%]; COO ME [50%]; Dekany [25%] | 240h | 13,830.72 |
| 301 | 1.3.4.2.7.4 | Develop to preliminary design level the opto-mechanical design for the LOWFS OSM | 13.33d? | 2009-02-13 | 2009-03-04 | 300 | 147d | 0d |  | Hale [75%]; COO ME [75%]; Velur [75%] | 240h | 15,360 |
| 302 | 1.3.4.2.7.5 | Make sure that the design doesn't preclude the inclusion of a PSF monitor later | 3.33d? | 2009-03-04 | 2009-03-09 | 301 | 147d | 0d |  | Velur [75%] | 20h | 1,920 |
| 303 | 1.3.4.2.7.6 | Package and model the assembly. | 13.33d? | 2009-03-09 | 2009-03-26 | 302 | 147d | 0d |  | COO ME [75%]; Velur [75%] | 160h | 7,680 |
| 304 | 1.3.4.2.7.7 | Develop thermal model and work emissivity details of the LOWFS assembly and feed into the overall emissivity budget | 10d? | 2009-03-27 | 2009-04-09 | 303 | 147d | 0d |  | Bouchez [50%] | 40h | 3,845.6 |
| 305 | 1.3.4.2.7.8 | Identify the motion control needs and specify solutions. | 60d? | 2009-04-10 | 2009-07-02 | 304 | 147d | 0d |  | Wetherell [25%]; Hale [25%]; Velur [25%] | 360h | 31,440 |
| 306 | 1.3.4.2.7.9 | Identify design risks and mitigation of the identified risks. | 10d? | 2009-07-03 | 2009-07-16 | 305 | 147d | 0d |  | Hale [50%]; Velur [50%] | 80h | 7,680 |
| 307 | 1.3.4.2.7.10 | Develop a preliminary integration plan for the assembly. | 13.33d? | 2009-07-17 | 2009-08-05 | 306 | 147d | 0d |  | Velur [75%] | 80h | 7,680 |
| 308 | 1.3.4.2.7.11 | Develop a test plan based on the design to test performance | 10d? | 2009-08-05 | 2009-08-19 | 307 | 147d | 47d |  | Hale [75%]; Velur [75%] | 120h | 11,520 |
| 309 | 1.3.4.2.7.12 | LOWFS Assembly Documentation | 6.67d? | 2009-10-23 | 2009-11-02 | 308 | 100d |  | finish no earlier than 2009-11-02 | Hale [75%]; Velur [75%] | 80h | 7,680 |

Notes:
- 277: VV
- 288: VV
- 297: VV

| ID | WBS | Task | Duration | Start | Finish | Total slack | Constraint | Resources | Work | Cost |
| --- | --- | --- | --- | --- | --- | --- | --- | --- | --- | --- |
| 310 | 1.3.4.2.8 | **Tip/Tilt Vibration Mitigation** | 40d? | 2008-07-07 | 2008-08-29 | 406d |  |  | 80h | 5,600 |
| 311 | 1.3.4.2.8.1 | TT Vibration Mitigation Analysis | 40d? | 2008-07-07 | 2008-08-29 | 406d | start no earlier than 2008-07-07 | Neyman [25%] | 80h | 5,600 |
| 312 | 1.3.4.2.9 | **Acquisition Cameras** | 305d? | 2008-09-01 | 2009-10-30 | 101d |  |  | 128h | 9,224.8 |
| 313 | 1.3.4.2.9.1 | Implementation Issues | 20d? | 2008-09-01 | 2008-09-26 | 386d | start no earlier than 2008-09-01 | Neyman [12.5%]; Le Mignant [12.5%] | 40h | 2,800 |
| 314 | 1.3.4.2.9.2 | Opto-Mechanical Design | 20d? | 2009-10-01 | 2009-10-30 | 101d | start no earlier than 2009-10-01 | Neyman [35%]; Panteleev [10%]; Lockwood [10%] | 88h | 6,424.8 |
| 315 | 1.3.4.2.10 | **Atmospheric Dispersion Correctors** | 96d? | 2008-10-17 | 2009-02-27 | 276d |  |  | 240h | 14,652 |
| 316 | 1.3.4.2.10.1 | LOWFS ADCs | 10d? | 2008-10-17 | 2008-10-30 | 362d | finish no earlier than 2008-10-30 | Kupke; Lockwood [75%] | 140h | 9,057 |
| 317 | 1.3.4.2.10.2 | NIR Science ADC | 5d? | 2008-12-24 | 2008-12-30 | 319d | finish no earlier than 2008-12-30 | Kupke; Lockwood [25%] | 50h | 2,797.5 |
| 318 | 1.3.4.2.10.3 | Visible Science & NGS WFS ADC | 5d? | 2009-02-23 | 2009-02-27 | 276d | finish no earlier than 2009-02-27 | Kupke; Lockwood [25%] | 50h | 2,797.5 |
| 319 | 1.3.4.3 | **Alignment, Calibration & Diagnostics** | 90d? | 2009-02-02 | 2009-06-05 | 206d |  |  | 505h | 37,068 |
| 320 | 1.3.4.3.1 | **Simulator** | 45d? | 2009-02-02 | 2009-04-03 | 251d |  |  | 250h | 19,178 |
| 321 | 1.3.4.3.1.1 | Simulator Requirements & Interfaces | 10d? | 2009-02-02 | 2009-02-13 | 286d | finish no earlier than 2009-02-13 | Neyman [50%]; Wizinowich [12.5%] | 50h | 3,840 |
| 322 | 1.3.4.3.1.2 | Simulator Optical Design | 10d? | 2009-02-16 | 2009-02-27 | 276d | finish no earlier than 2009-02-27 | Neyman [12.5%]; Wizinowich [50%] | 50h | 4,860 |
| 323 | 1.3.4.3.1.3 | Simulator Mechanical Design | 10d? | 2009-03-02 | 2009-03-13 | 266d | finish no earlier than 2009-03-13 | Neyman [12.5%]; Bell [62.5%] | 60h | 4,178 |
| 324 | 1.3.4.3.1.4 | Simulator Electrical Design | 10d? | 2009-03-09 | 2009-03-20 | 261d | finish no earlier than 2009-03-20 | Neyman [25%]; Wetherell [37.5%] | 50h | 3,500 |
| 325 | 1.3.4.3.1.5 | Simulator Assembly, Alignment & Test Plans | 10d? | 2009-03-23 | 2009-04-03 | 251d | start no earlier than 2009-03-23 | Neyman [50%] | 40h | 2,800 |
| 326 | 1.3.4.3.2 | **System Alignment Tools** | 45d? | 2009-04-06 | 2009-06-05 | 206d |  |  | 255h | 17,890 |
| 327 | 1.3.4.3.2.1 | Alignment Requirements & Interfaces | 10d? | 2009-04-06 | 2009-04-17 | 241d | finish no earlier than 2009-04-17 | Neyman [50%]; Kupke [12.5%]; Wizinowich [12.5%] | 60h | 4,323 |
| 328 | 1.3.4.3.2.2 | Alignment Optical Design | 10d? | 2009-04-20 | 2009-05-01 | 231d | finish no earlier than 2009-05-01 | Neyman [12.5%]; Kupke [50%] | 50h | 2,632 |
| 329 | 1.3.4.3.2.3 | Alignment Mechanical Design | 10d? | 2009-05-04 | 2009-05-15 | 221d | finish no earlier than 2009-05-15 | Neyman [12.5%]; Lockwood [50%] | 50h | 4,162 |
| 330 | 1.3.4.3.2.4 | Alignment Electrical Design | 10d? | 2009-05-11 | 2009-05-22 | 216d | finish no earlier than 2009-05-22 | Neyman [25%]; Wetherell [18.8%] | 35h | 2,450 |
| 331 | 1.3.4.3.2.5 | Alignment Assembly, Alignment & Test Plans | 10d? | 2009-05-25 | 2009-06-05 | 206d | finish no earlier than 2009-06-05 | Neyman [50%]; Kupke [12.5%]; Wizinowich [12.5%] | 60h | 4,323 |
| 332 | 1.3.4.4 | **Non-real-time Control** | 271d? | 2008-10-01 | 2009-10-14 | 113d |  |  | 1000h | 60,200 |
| 333 | 1.3.4.4.1 | AO Controls Infrastructure | 1d? | 2009-02-02 | 2009-02-02 | 295d | start no earlier than 2009-02-02 |  |  |  |

Notes:
- 310: CN
- 312: CN
- 315: RK
- 319: CN
- 320: CN
- 326: CN
- 332: EJ

| ID | WBS | Task | Type | Duration | Start | Finish | Predecessors | Total slack | Free slack | Constraint | Resources | Work | Cost |
| --- | --- | --- | --- | --- | --- | --- | --- | --- | --- | --- | --- | --- | --- |
| 334 | 1.3.4.4.2 | **AO Sequencer** |  | 88d? | 2008-10-01 | 2009-02-02 |  | 296d |  |  |  | 150h | 10,500 |
| 335 | 1.3.4.4.2.1 | AO Sequencer: Architecture |  | 44d? | 2008-10-01 | 2008-12-01 |  | 320d | 0d | finish no earlier than 2008-12-01 | Johansson [5.7%]; Morrison [17%] | 80h | 5,600 |
| 336 | 1.3.4.4.2.2 | AO Sequencer: Interface Control Document |  | 20d? | 2008-11-03 | 2008-11-28 |  | 321d | 1d | finish no earlier than 2008-11-28 | Johansson [6.2%]; Morrison [12.5%] | 30h | 2,100 |
| 337 | 1.3.4.4.2.3 | AO Sequencer: Software Module Design |  | 20d? | 2008-11-03 | 2008-11-28 |  | 321d | 1d | finish no earlier than 2008-11-28 | Johansson [9.4%]; Morrison [9.4%] | 30h | 2,100 |
| 338 | 1.3.4.4.2.4 | AO Sequencer: User Interface Design | milestone | 0d? | 2009-02-02 | 2009-02-02 |  | 296d |  | start no earlier than 2009-02-02 |  |  |  |
| 339 | 1.3.4.4.2.5 | AO Sequencer: Technical Specifications | milestone | 0d? | 2009-02-02 | 2009-02-02 |  | 296d |  | start no earlier than 2009-02-02 |  |  |  |
| 340 | 1.3.4.4.2.6 | AO Sequencer: Compliance Matrix | milestone | 0d? | 2009-02-02 | 2009-02-02 |  | 296d |  | start no earlier than 2009-02-02 |  |  |  |
| 341 | 1.3.4.4.2.7 | AO Sequencer: Test Plan | milestone | 0d? | 2009-02-02 | 2009-02-02 |  | 296d |  | start no earlier than 2009-02-02 |  |  |  |
| 342 | 1.3.4.4.2.8 | AO Sequencer: Summary Report |  | 20d? | 2008-12-02 | 2008-12-29 | 335, 336, 337 | 320d |  |  | Johansson [6.2%] | 10h | 700 |
| 343 | 1.3.4.4.3 | **AO Motion Control Software** |  | 80d? | 2009-01-05 | 2009-04-24 |  | 236d |  |  |  | 230h | 16,100 |
| 344 | 1.3.4.4.3.1 | Motion Control SW: Architecture |  | 40d? | 2009-01-05 | 2009-02-27 |  | 276d |  | finish no earlier than 2009-02-27 | Johansson [6.2%]; Morrison [18.8%] | 80h | 5,600 |
| 345 | 1.3.4.4.3.2 | Motion Control SW: ICD |  | 40d? | 2009-01-05 | 2009-02-27 |  | 276d |  | finish no earlier than 2009-02-27 | Johansson [6.2%]; Morrison [6.2%] | 40h | 2,800 |
| 346 | 1.3.4.4.3.3 | Motion Control SW: Module Design |  | 40d? | 2009-01-05 | 2009-02-27 |  | 276d |  | finish no earlier than 2009-02-27 | Johansson [6.2%]; Morrison [21.9%] | 90h | 6,300 |
| 347 | 1.3.4.4.3.4 | Motion Control SW: User Interface Design | milestone | 0d? | 2009-03-02 | 2009-03-02 |  | 276d |  | start no earlier than 2009-03-02 |  |  |  |
| 348 | 1.3.4.4.3.5 | Motion Control SW: Technical Specifications | milestone | 0d? | 2009-03-02 | 2009-03-02 |  | 276d |  | start no earlier than 2009-03-02 |  |  |  |
| 349 | 1.3.4.4.3.6 | Motion Control SW: Compliance Matrix | milestone | 0d? | 2009-03-02 | 2009-03-02 |  | 276d |  | start no earlier than 2009-03-02 |  |  |  |
| 350 | 1.3.4.4.3.7 | Motion Control SW: Test Plan | milestone | 0d? | 2009-03-02 | 2009-03-02 |  | 276d |  | start no earlier than 2009-03-02 |  |  |  |
| 351 | 1.3.4.4.3.8 | Motion Control SW: Summary Report |  | 40d? | 2009-03-02 | 2009-04-24 |  | 236d |  | finish no earlier than 2009-04-24 | Johansson [3.1%]; Morrison [3.1%] | 20h | 1,400 |
| 352 | 1.3.4.4.4 | **AO Device Control Software** |  | 118d? | 2009-05-04 | 2009-10-14 |  | 113d |  |  |  | 240h | 16,800 |
| 353 | 1.3.4.4.4.1 | Device Control: Software Architecture |  | 33d? | 2009-05-04 | 2009-06-17 |  | 132d | 0d | finish no earlier than 2009-06-17 | Morrison [30.3%] | 80h | 5,600 |
| 354 | 1.3.4.4.4.2 | Device Control: Interface Control Document |  | 22d? | 2009-06-18 | 2009-07-17 | 353 | 176d |  | finish no earlier than 2009-06-30 | Morrison [22.7%] | 40h | 2,800 |
| 355 | 1.3.4.4.4.3 | Device Control: Software Module Design |  | 56d? | 2009-07-15 | 2009-09-30 | 353 | 113d | 0d | finish no earlier than 2009-09-30 | Morrison [22.3%] | 100h | 7,000 |
| 356 | 1.3.4.4.4.4 | Device Control: User Interface Design | milestone | 0d? | 2009-06-15 | 2009-06-15 |  | 201d |  | start no earlier than 2009-06-15 |  |  |  |
| 357 | 1.3.4.4.4.5 | Device Control: Technical Specifications | milestone | 0d? | 2009-06-15 | 2009-06-15 |  | 201d |  | start no earlier than 2009-06-15 |  |  |  |
| 358 | 1.3.4.4.4.6 | Device Control: Compliance Matrix | milestone | 0d? | 2009-06-15 | 2009-06-15 |  | 201d |  | start no earlier than 2009-06-15 |  |  |  |
| 359 | 1.3.4.4.4.7 | Device Control: Test Plan | milestone | 0d? | 2009-06-15 | 2009-06-15 |  | 201d |  | start no earlier than 2009-06-15 |  |  |  |
| 360 | 1.3.4.4.4.8 | Device Control: Summary Report |  | 10d? | 2009-10-01 | 2009-10-14 | 355 | 113d |  | finish no earlier than 2009-09-14 | Morrison [25%] | 20h | 1,400 |

Notes:
- 334: EJ
- 343: EJ
- 352: DM

| ID | WBS | Task | Type | Duration | Start | Finish | Predecessors | Total slack | Free slack | Constraint | Resources | Work | Cost |
| --- | --- | --- | --- | --- | --- | --- | --- | --- | --- | --- | --- | --- | --- |
| 361 | 1.3.4.4.5 | **AO Motion Control Electronics** |  | 261d? | 2008-10-01 | 2009-09-30 |  | 123d |  |  |  | 60h | 4,200 |
| 362 | 1.3.4.4.5.1 | Motion Control HW: Spreadsheet |  | 261d? | 2008-10-01 | 2009-09-30 |  | 123d |  | finish no earlier than 2009-09-30 | Wetherell [2.9%] | 60h | 4,200 |
| 363 | 1.3.4.4.6 | **Non-RTC Electronics** |  | 96d? | 2009-02-02 | 2009-06-15 |  | 200d |  |  |  | 160h | 11,200 |
| 364 | 1.3.4.4.6.1 | Non-RTC Electronics: Architecture |  | 25d? | 2009-02-02 | 2009-03-06 |  | 220d | 0d | finish no earlier than 2009-03-06 | Wetherell [40%] | 80h | 5,600 |
| 365 | 1.3.4.4.6.2 | Non-RTC Electronics: Selection/Specification |  | 40d? | 2009-03-09 | 2009-05-01 | 364 | 220d | 20d |  | Wetherell [18.8%] | 60h | 4,200 |
| 366 | 1.3.4.4.6.3 | Non-RTC Electronics: Compliance Matrix |  | 1d? | 2009-04-06 | 2009-04-06 |  | 250d |  | start no earlier than 2009-04-06 |  |  |  |
| 367 | 1.3.4.4.6.4 | Non-RTC Electronics: Test Plan |  | 1d? | 2009-04-06 | 2009-04-06 |  | 250d |  | start no earlier than 2009-04-06 |  |  |  |
| 368 | 1.3.4.4.6.5 | Non-RTC Electronics: Documentation |  | 11d? | 2009-06-01 | 2009-06-15 | 365 | 200d |  | start no earlier than 2009-06-01 | Wetherell [22.7%] | 20h | 1,400 |
| 369 | 1.3.4.4.7 | **Non-RTC Lab System Integration & Test** |  | 0d? | 2009-02-02 | 2009-02-02 |  | 296d |  |  |  |  |  |
| 370 | 1.3.4.4.7.1 | Non-RTC I&T: Architecture | milestone | 0d? | 2009-02-02 | 2009-02-02 |  | 296d |  | start no earlier than 2009-02-02 |  |  |  |
| 371 | 1.3.4.4.7.2 | Non-RTC I&T: Electronics Specification & Selection | milestone | 0d? | 2009-02-02 | 2009-02-02 |  | 296d |  | start no earlier than 2009-02-02 |  |  |  |
| 372 | 1.3.4.4.7.3 | Non-RTC I&T: Test Plan | milestone | 0d? | 2009-02-02 | 2009-02-02 |  | 296d |  | start no earlier than 2009-02-02 |  |  |  |
| 373 | 1.3.4.4.7.4 | Non-RTC I&T: Summary Report | milestone | 0d? | 2009-02-02 | 2009-02-02 |  | 296d |  | start no earlier than 2009-02-02 |  |  |  |
| 374 | 1.3.4.4.8 | **Acquisition, Guiding & Offload (AGO) Control** |  | 47d? | 2009-04-27 | 2009-06-30 |  | 189d |  |  |  | 160h | 1,400 |
| 375 | 1.3.4.4.8.1 | AGO: Architecture |  | 47d? | 2009-04-27 | 2009-06-30 |  | 189d |  | finish no earlier than 2009-06-30 | Stomski [16%]; Le Mignant | 80h | 1,400 |
| 376 | 1.3.4.4.8.2 | AGO: ICD |  | 47d? | 2009-04-27 | 2009-06-30 |  | 189d |  | start no earlier than 2009-04-27 | Stomski [10.6%] | 40h |  |
| 377 | 1.3.4.4.8.3 | AGO: Software Module Design |  | 47d? | 2009-04-27 | 2009-06-30 |  | 189d |  | start no earlier than 2009-04-27 | Stomski [5.3%] | 20h |  |
| 378 | 1.3.4.4.8.4 | AGO: User Interface | milestone | 0d? | 2009-04-27 | 2009-04-27 |  | 236d |  | start no earlier than 2009-04-27 |  |  |  |
| 379 | 1.3.4.4.8.5 | AGO: Technical Specification | milestone | 0d? | 2009-04-27 | 2009-04-27 |  | 236d |  | start no earlier than 2009-04-27 |  |  |  |
| 380 | 1.3.4.4.8.6 | AGO: Compliance Matrix | milestone | 0d? | 2009-04-27 | 2009-04-27 |  | 236d |  | start no earlier than 2009-04-27 |  |  |  |
| 381 | 1.3.4.4.8.7 | AGO: Test Plan | milestone | 0d? | 2009-04-27 | 2009-04-27 |  | 236d |  | start no earlier than 2009-04-27 |  |  |  |
| 382 | 1.3.4.4.8.8 | AGO: Summary Report |  | 47d? | 2009-04-27 | 2009-06-30 |  | 189d |  | finish no earlier than 2009-06-30 | Stomski [5.3%] | 20h |  |
| 383 | 1.3.4.5 | **Real-time Control** |  | 425d? | 2008-05-12 | 2009-12-25 |  | 61d |  |  |  | 3105h | 262,656.4 |
| 384 | 1.3.4.5.1 | **RTC Processor** |  | 425d? | 2008-05-12 | 2009-12-25 |  | 61d |  |  |  | 2785h | 231,007.4 |
| 385 | 1.3.4.5.1.1 | RTC Technical Management |  | 3400h? | 2008-05-12 | 2009-12-25 |  | 61d |  | start no earlier than 2008-05-12 | Reinig [9.2%]; Gavel [4.4%] | 463h | 43,389.8 |
| 386 | 1.3.4.5.1.2 | Centroid/Wavefront Reconstruction Processing Requirements |  | 40d? | 2008-08-25 | 2008-10-17 |  | 371d |  | start no earlier than 2008-08-25 | Peck [89.1%] | 285h | 23,028 |
| 387 | 1.3.4.5.1.3 | Centroid/Wavefront Reconstruction Test Definition |  | 47d? | 2008-09-08 | 2008-11-11 |  | 354d |  | start no earlier than 2008-09-08 | Peck [21.3%] | 80h | 6,464 |
| 388 | 1.3.4.5.1.4 | Preconditioning & Scaling Processing Requirements |  | 75d? | 2008-10-06 | 2009-01-16 |  | 306d |  | start no earlier than 2008-10-06 | Peck [46.7%] | 280h | 22,624 |
| 389 | 1.3.4.5.1.5 | Preconditioning & Scaling Processing Test Definition |  | 26.67d? | 2008-12-29 | 2009-02-03 |  | 294.33d |  | start no earlier than 2008-12-28 | Peck [37.5%] | 80h | 6,464 |
| 390 | 1.3.4.5.1.6 | Low Order WFS Processing Requirements |  | 58.71d? | 2009-02-09 | 2009-04-30 |  | 232.29d |  | start no earlier than 2009-02-08 | Peck [59.6%] | 280h | 22,624 |
| 391 | 1.3.4.5.1.7 | Low Order WFS Processing Test Definition |  | 10d? | 2009-05-18 | 2009-05-29 |  | 211d |  | start no earlier than 2009-05-17 | Peck | 80h | 6,464 |
| 392 | 1.3.4.5.1.8 | Layer Combining & DM Processing Requirements |  | 37.03d? | 2009-06-01 | 2009-07-22 |  | 173.97d |  | start no earlier than 2009-05-31 | Peck [94.5%] | 280h | 22,624 |
| 393 | 1.3.4.5.1.9 | Camera Data Transfer Issues |  | 21.51d? | 2009-07-27 | 2009-08-25 |  | 149.49d |  | start no earlier than 2009-07-26 | Peck [46.5%] | 80h | 6,464 |
| 394 | 1.3.4.5.1.10 | Radial versus Rectilinear Voxels Trade Study |  | 66.36d? | 2008-12-01 | 2009-03-03 |  | 274.64d |  | start no earlier than 2008-12-01 | Peck [37.7%] | 200h | 16,160 |
| 395 | 1.3.4.5.1.11 | Define Required Bit Resolution |  | 22d? | 2008-09-01 | 2008-09-30 |  | 384d |  | start no earlier than 2008-09-01 | Peck [34.1%] | 60h | 4,848 |
| 396 | 1.3.4.5.1.12 | Characterize Single Event Upset |  | 27.69d? | 2009-08-24 | 2009-09-30 |  | 123.31d |  | start no earlier than 2009-08-23 | Peck [27.1%] | 60h | 4,848 |
| 397 | 1.3.4.5.1.13 | Power Characterization and Parameter Estimation |  | 10d? | 2009-10-05 | 2009-10-16 |  | 111d |  | start no earlier than 2009-10-04 | Peck | 80h | 6,464 |
| 398 | 1.3.4.5.1.14 | Voxel Communication Parameters |  | 10d? | 2009-11-30 | 2009-12-11 |  | 71d |  | start no earlier than 2009-11-30 | Peck | 80h | 6,464 |
| 399 | 1.3.4.5.1.15 | Diagnostic Control & I/O Requirements |  | 27.27d? | 2009-03-02 | 2009-04-08 |  | 248.73d |  | start no earlier than 2009-03-02 | Peck [45.8%] | 100h | 8,080 |
| 400 | 1.3.4.5.1.16 | Monitoring Control & I/O Requirements |  | 36.36d? | 2009-10-12 | 2009-12-01 |  | 79.64d |  | start no earlier than 2009-10-11 | Peck [34.4%] | 100h | 8,080 |
| 401 | 1.3.4.5.1.17 | Define Testing Procedures |  | 40d? | 2008-11-03 | 2008-12-26 |  | 321d |  | start no earlier than 2008-11-03 | Peck [25%] | 80h | 6,464 |
| 402 | 1.3.4.5.1.18 | Documentation |  | 126d? | 2009-06-08 | 2009-11-30 |  | 80d |  | start no earlier than 2009-06-08 | Peck [11.6%] | 117h | 9,453.6 |

Notes:
- 361: EW
- 363: EW
- 374: EJ
- 383: DG
- 384: DG
- 385: MR

| ID | WBS | Task | Duration | Start | Finish | Total slack | Constraint | Resources | Work | Cost |
| --- | --- | --- | --- | --- | --- | --- | --- | --- | --- | --- |
| 403 | 1.3.4.5.2 | **DMs & Tip/Tilt Stages** | 105d? | 2008-10-06 | 2009-02-27 | 276d |  |  | 320h | 31,649 |
| 404 | 1.3.4.5.2.1 | **Woofer DM/TT** | 105d? | 2008-10-06 | 2009-02-27 | 276d |  |  | 132h | 13,306.6 |
| 405 | 1.3.4.5.2.1.1 | Define Requirements | 20d? | 2008-10-06 | 2008-10-31 | 361d | start no earlier than 2008-10-06 | Gavel [10%] | 16h | 2,137.6 |
| 406 | 1.3.4.5.2.1.2 | Evaluate Tip/Tilt Mount Options | 30d? | 2008-12-01 | 2009-01-09 | 311d | finish no earlier than 2009-01-09 | Lockwood [16.7%]; Gavel [50%] | 44h | 3,996.4 |
| 407 | 1.3.4.5.2.1.3 | Evaluate Combined DM & Tip/Tilt Performance | 10d? | 2009-01-12 | 2009-01-23 | 301d | finish no earlier than 2009-01-23 | Gavel [20%] | 16h | 2,137.6 |
| 408 | 1.3.4.5.2.1.4 | Select Tip/Tilt Mount | 5d? | 2009-01-26 | 2009-01-30 | 296d | finish no earlier than 2009-01-30 | Gavel [10%]; Lockwood | 8h | 880.6 |
| 409 | 1.3.4.5.2.1.5 | Design Mechanical Package | 10d? | 2009-02-16 | 2009-02-27 | 276d | finish no earlier than 2009-02-27 | Lockwood [50%] | 40h | 3,462 |
| 410 | 1.3.4.5.2.1.6 | Obtain Quotes | 20d? | 2009-01-05 | 2009-01-30 | 296d | finish no earlier than 2009-01-30 | Lockwood [5%] | 8h | 692.4 |
| 411 | 1.3.4.5.2.2 | **Tweeter DM/TT** | 95d? | 2008-10-06 | 2009-02-13 | 286d |  |  | 48h | 5,095.4 |
| 412 | 1.3.4.5.2.2.1 | Define Requirements | 20d? | 2008-10-06 | 2008-10-31 | 361d | finish no earlier than 2008-10-31 | Gavel [5%] | 8h | 1,068.8 |
| 413 | 1.3.4.5.2.2.2 | Evaluate Options & Select Tip/Tilt Mount | 20d? | 2008-11-03 | 2008-11-28 | 341d | finish no earlier than 2008-11-28 | Lockwood [12.5%]; Gavel [50%] | 28h | 2,799.8 |
| 414 | 1.3.4.5.2.2.3 | Design Mechanical Package | 10d? | 2009-02-02 | 2009-02-13 | 286d | finish no earlier than 2009-02-13 | Lockwood [10%] | 8h | 692.4 |
| 415 | 1.3.4.5.2.2.4 | Obtain Quotes | 20d? | 2008-11-03 | 2008-11-28 | 341d | finish no earlier than 2008-11-28 | Gavel [2.5%] | 4h | 534.4 |
| 416 | 1.3.4.5.2.3 | **LOWFS DM/TT** | 95d? | 2008-10-06 | 2009-02-13 | 286d |  |  | 140h | 13,247 |
| 417 | 1.3.4.5.2.3.1 | Define Requirements including LOWFS Interface | 20d? | 2008-10-06 | 2008-10-31 | 361d | finish no earlier than 2008-10-31 | Gavel [50%]; Velur [12.5%] | 28h | 2,988.8 |
| 418 | 1.3.4.5.2.3.2 | Evaluate Options & Select Tip/Tilt Mount | 20d? | 2008-11-03 | 2008-11-28 | 341d | finish no earlier than 2008-11-28 | Lockwood [12.5%]; Gavel [50%] | 28h | 2,799.8 |
| 419 | 1.3.4.5.2.3.3 | Design Mechanical Package | 25d? | 2009-01-12 | 2009-02-13 | 286d | finish no earlier than 2009-02-13 | Lockwood [40%] | 80h | 6,924 |
| 420 | 1.3.4.5.2.3.4 | Obtain Quotes | 20d? | 2008-11-03 | 2008-11-28 | 341d | finish no earlier than 2008-11-28 | Gavel [2.5%] | 4h | 534.4 |
| 421 | 1.3.4.6 | **AO System Lab I&T** | 40d? | 2009-07-06 | 2009-08-28 | 146d |  |  | 200h | 14,544 |
| 422 | 1.3.4.6.1 | AO System Lab I&T Scope Definition | 10d? | 2009-07-06 | 2009-07-17 | 176d | finish no earlier than 2009-07-17 | Wizinowich [20%] | 16h | 1,664 |
| 423 | 1.3.4.6.2 | AO System Lab Facility Plan | 30d? | 2009-07-20 | 2009-08-28 | 146d | finish no earlier than 2009-08-28 | Neyman [10%] | 24h | 1,680 |
| 424 | 1.3.4.6.3 | AO System Lab Integration Plan | 30d? | 2009-07-20 | 2009-08-28 | 146d | finish no earlier than 2009-08-28 | Neyman [33.3%] | 80h | 5,600 |
| 425 | 1.3.4.6.4 | AO System Lab Test Plan | 25d? | 2009-07-27 | 2009-08-28 | 146d | finish no earlier than 2009-08-28 | Neyman [40%] | 80h | 5,600 |
| 426 | 1.3.5 | **Laser System Design** | 434d? | 2008-05-05 | 2009-12-31 | 57d |  |  | 2974h | 224,774 |
| 427 | 1.3.5.1 | **Laser Enclosure (LE)** | 40d? | 2009-01-19 | 2009-03-13 | 266d |  |  | 160h | 11,200 |
| 428 | 1.3.5.1.1 | LE Requirements & Interfaces | 20d? | 2009-01-19 | 2009-02-13 | 286d | finish no earlier than 2009-02-13 | Chin [12.5%]; Medeiros [12.5%] | 40h | 2,800 |
| 429 | 1.3.5.1.2 | LE Mechanical Design | 10d? | 2009-02-16 | 2009-02-27 | 276d | finish no earlier than 2009-02-27 | Chin; Medeiros [50%] | 50h | 3,500 |
| 430 | 1.3.5.1.3 | LE Environmental Control Design | 10d? | 2009-02-16 | 2009-02-27 | 276d | finish no earlier than 2009-02-27 | Chin; Nance [50%] | 50h | 3,500 |
| 431 | 1.3.5.1.4 | LE Assembly & Test Plans | 10d? | 2009-03-02 | 2009-03-13 | 266d | finish no earlier than 2009-03-13 | Chin; Nance [10%]; Medeiros [10%] | 20h | 1,400 |

Notes:
- 403: DG
- 404: DG
- 411: DG
- 416: DG
- 421: CN
- 422: PW
- 423: CN
- 424: CN
- 425: CN
- 426: CN
- 427: JC
- 428: JC
- 429: DM
- 430: CN
- 431: JC

| ID | WBS | Task | Type | Duration | Start | Finish | Predecessors | Total slack | Free slack | Constraint | Resources | Work | Cost |
| --- | --- | --- | --- | --- | --- | --- | --- | --- | --- | --- | --- | --- | --- |
| 432 | 1.3.5.2 | **Laser** |  | 421d? | 2008-05-05 | 2009-12-15 |  | 70d |  |  |  | 820h | 73,994 |
| 433 | 1.3.5.2.1 | Laser Project Management |  | 280d? | 2008-05-05 | 2009-05-29 |  | 211d |  | finish no earlier than 2009-05-29 | Adkins [6.7%]; Kissner [6.7%] | 300h | 22,650 |
| 434 | 1.3.5.2.2 | **ESO Laser Contract Milestones** |  | 336d | 2008-09-01 | 2009-12-15 |  | 70d |  |  |  |  |  |
| 435 | 1.3.5.2.2.1 | Laser PD Contract RFQ Issued | milestone | 0d | 2008-09-01 | 2008-09-01 |  | 406d |  | start no earlier than 2008-09-01 |  |  |  |
| 436 | 1.3.5.2.2.2 | Laser PD Quotes Received | milestone | 0d | 2008-10-30 | 2008-10-30 |  | 363d |  | start no earlier than 2008-10-30 |  |  |  |
| 437 | 1.3.5.2.2.3 | Laser PD Kick-off Meeting(s) | milestone | 0d | 2008-12-15 | 2008-12-15 |  | 331d |  | start no earlier than 2008-12-15 |  |  |  |
| 438 | 1.3.5.2.2.4 | Laser PDR | milestone | 0d | 2009-08-17 | 2009-08-17 |  | 156d |  | start no earlier than 2009-08-17 |  |  |  |
| 439 | 1.3.5.2.2.5 | Laser System Contract Kick-off Meeting | milestone | 0d | 2009-12-15 | 2009-12-15 |  | 70d |  | start no earlier than 2009-12-15 |  |  |  |
| 440 | 5.2.3.1 | **Laser Requirements** |  | 110d | 2008-05-05 | 2008-10-03 |  | 211d |  |  |  | 160h | 16,640 |
| 441 | 5.2.3.1.1 | Laser Performance Analysis |  | 20d | 2008-05-05 | 2008-05-30 |  | 211d | 0d | start no earlier than 2008-05-05 | Adkins [25%] | 40h | 4,160 |
| 442 | 5.2.3.1.2 | Laser Requirements Analysis |  | 20d | 2008-06-02 | 2008-06-27 | 441 | 211d | 0d |  | Adkins [25%] | 40h | 4,160 |
| 443 | 5.2.3.1.3 | Laser Requirements Development |  | 20d | 2008-06-30 | 2008-07-25 | 442 | 211d | 0d |  | Adkins [25%] | 40h | 4,160 |
| 444 | 5.2.3.1.4 | Laser Requirements Drafting and Revisions |  | 50d | 2008-07-28 | 2008-10-03 | 443 | 211d | 0d |  | Adkins [10%] | 40h | 4,160 |
| 445 | 5.2.3.2 | **Laser Preliminary ICD** |  | 20d | 2008-07-28 | 2008-08-22 |  | 411d |  |  |  | 40h | 4,160 |
| 446 | 5.2.3.2.1 | Laser ICD Drafting and Revisions |  | 20d | 2008-07-28 | 2008-08-22 | 443 | 411d |  |  | Adkins [25%] | 40h | 4,160 |
| 447 | 5.2.3.3 | **Laser Request for Proposals (RFP)** |  | 90d | 2008-10-06 | 2009-02-06 |  | 211d |  |  |  | 120h | 9,744 |
| 448 | 5.2.3.3.1 | Laser Proposal Drafting |  | 20d | 2008-10-06 | 2008-10-31 | 444 | 211d | 0d |  | Adkins [25%] | 40h | 4,160 |
| 449 | 5.2.3.3.2 | Laser Proposal Release |  | 10d | 2008-11-03 | 2008-11-14 | 448 | 211d | 0d |  | Adkins [25%]; Kissner [30%] | 40h | 2,792 |
| 450 | 5.2.3.3.3 | Laser Proposal Response Period |  | 3mo | 2008-11-17 | 2009-02-06 | 449 | 211d | 0d |  | Adkins [3.3%]; Kissner [5%] | 40h | 2,792 |
| 451 | 5.2.3.4 | **Laser RFP Response Report** |  | 40d | 2009-02-09 | 2009-04-03 |  | 211d |  |  |  | 120h | 12,480 |
| 452 | 5.2.3.4.1 | Laser Proposal Evaluation |  | 20d | 2009-02-09 | 2009-03-06 | 450 | 211d | 0d |  | Adkins [25%] | 40h | 4,160 |
| 453 | 5.2.3.4.2 | Laser Response Discussions |  | 20d | 2009-03-09 | 2009-04-03 | 452 | 251d |  |  | Adkins [25%] | 40h | 4,160 |
| 454 | 5.2.3.4.3 | Laser Report Drafting and Revisions |  | 20d | 2009-03-09 | 2009-04-03 | 452 | 211d | 0d |  | Adkins [25%] | 40h | 4,160 |
| 455 | 5.2.3.5 | **Laser Contract** |  | 40d | 2009-04-06 | 2009-05-29 |  | 211d |  |  |  | 80h | 8,320 |
| 456 | 5.2.3.5.1 | Laser Contract Drafting and Revisions |  | 20d | 2009-04-06 | 2009-05-01 | 454 | 211d | 0d |  | Adkins [25%] | 40h | 4,160 |
| 457 | 5.2.3.5.2 | Laser Contract Negotiations |  | 20d | 2009-05-04 | 2009-05-29 | 456 | 211d |  |  | Adkins [25%] | 40h | 4,160 |

Notes:
- 432: SA
- 433: SA
- 440: SA
- 445: SA
- 447: SA
- 451: SA
- 455: SA

| ID | WBS | Task | Duration | Start | Finish | Predecessors | Total slack | Free slack | Constraint | Resources | Work | Cost |
| --- | --- | --- | --- | --- | --- | --- | --- | --- | --- | --- | --- | --- |
| 458 | 1.3.5.3 | **Laser Launch Facility (LLF)** | 170d? | 2009-01-19 | 2009-09-11 |  | 136d |  |  |  | 856h | 59,920 |
| 459 | 1.3.5.3.1 | LLF Requirements & Interfaces | 20d? | 2009-01-19 | 2009-02-13 |  | 286d |  | finish no earlier than 2009-02-13 | Neyman [50%]; Chin | 100h | 7,000 |
| 460 | 1.3.5.3.2 | LLF Optical Design | 53d? | 2009-04-01 | 2009-06-12 |  | 201d |  | finish no earlier than 2009-06-12 | Neyman [14.2%]; Panteleev [47.2%] | 260h | 18,200 |
| 461 | 1.3.5.3.3 | LLF Launch Telescope Preliminary Design Contract | 100d? | 2009-03-16 | 2009-07-31 |  | 166d |  | start no earlier than 2009-03-16 | Neyman [9%]; Chin [3%] | 96h | 6,720 |
| 462 | 1.3.5.3.4 | LLF Mechanical Design | 45d? | 2009-06-01 | 2009-07-31 |  | 166d |  | finish no earlier than 2009-07-31 | Neyman; Medeiros [55.6%] | 220h | 15,400 |
| 463 | 1.3.5.3.5 | LLF Electrical Design | 30d? | 2009-07-20 | 2009-08-28 |  | 146d |  | start no earlier than 2009-07-20 | Neyman [8.3%]; Chin [41.7%] | 120h | 8,400 |
| 464 | 1.3.5.3.6 | LLF Assembly, Alignment & Test Plans | 10d? | 2009-08-31 | 2009-09-11 |  | 136d |  | finish no earlier than 2009-09-11 | Neyman [62.5%]; Chin | 60h | 4,200 |
| 465 | 1.3.5.4 | **Laser Safety Systems** | 65d? | 2009-08-03 | 2009-10-30 |  | 101d |  |  |  | 170h | 11,900 |
| 466 | 1.3.5.4.1 | **Personnel & Equipment Safety System** | 43d? | 2009-08-03 | 2009-09-30 |  | 123d |  |  |  | 130h | 9,100 |
| 467 | 1.3.5.4.1.1 | Safety Requirements & Interfaces | 10d? | 2009-08-03 | 2009-08-14 |  | 156d |  | start no earlier than 2009-08-03 | Chin [50%] | 40h | 2,800 |
| 468 | 1.3.5.4.1.2 | Safety Algorithms, Diagrams & Dataflow | 33d? | 2009-08-17 | 2009-09-30 |  | 123d |  | start no earlier than 2009-08-17 | Chin [7.6%] | 20h | 1,400 |
| 469 | 1.3.5.4.1.3 | Safety Communication Protocols & Methods | 33d? | 2009-08-17 | 2009-09-30 |  | 123d |  | start no earlier than 2009-08-17 | Chin [7.6%] | 20h | 1,400 |
| 470 | 1.3.5.4.1.4 | Safety Performance Estimate | 33d? | 2009-08-17 | 2009-09-30 |  | 123d |  | start no earlier than 2009-08-17 | Chin [7.6%] | 20h | 1,400 |
| 471 | 1.3.5.4.1.5 | Safety Electronics, Shutter & Interlocks | 33d? | 2009-08-17 | 2009-09-30 |  | 123d |  | start no earlier than 2009-08-17 | Wetherell [3.8%] | 10h | 700 |
| 472 | 1.3.5.4.1.6 | Safety Test Plans | 33d? | 2009-08-17 | 2009-09-30 |  | 123d |  | start no earlier than 2009-08-17 | Chin [3.8%]; Wetherell [3.8%] | 20h | 1,400 |
| 473 | 1.3.5.4.2 | **Laser Traffic Control System (LTCS) Modifications** | 20d? | 2009-10-05 | 2009-10-30 |  | 101d |  |  |  | 40h | 2,800 |
| 474 | 1.3.5.4.2.1 | LTCS Requirements & Interfaces | 20d? | 2009-10-05 | 2009-10-30 |  | 101d |  | start no earlier than 2009-10-05 | Summers [5%] | 8h | 560 |
| 475 | 1.3.5.4.2.2 | LTCS Algorithms, Diagrams & Dataflow | 20d? | 2009-10-05 | 2009-10-30 |  | 101d |  | start no earlier than 2009-10-05 | Summers [5%] | 8h | 560 |
| 476 | 1.3.5.4.2.3 | LTCS Communication Protocols & Methods | 20d? | 2009-10-05 | 2009-10-30 |  | 101d |  | start no earlier than 2009-10-05 | Summers [5%] | 8h | 560 |
| 477 | 1.3.5.4.2.4 | LTCS Performance Estimate | 20d? | 2009-10-05 | 2009-10-30 |  | 101d |  | start no earlier than 2009-10-05 | Summers [5%] | 8h | 560 |
| 478 | 1.3.5.4.2.5 | LTCS Test Plans | 20d? | 2009-10-05 | 2009-10-30 |  | 101d |  | start no earlier than 2009-10-05 | Summers [5%] | 8h | 560 |
| 479 | 1.3.5.5 | **Laser System Control (LSC)** | 327d? | 2008-10-01 | 2009-12-31 |  | 57d |  |  |  | 920h | 64,400 |
| 480 | 1.3.5.5.1 | **LSC Software** | 327d? | 2008-10-01 | 2009-12-31 |  | 57d |  |  |  | 610h | 42,700 |
| 481 | 1.3.5.5.1.1 | **LSC Sequencer** | 66d? | 2008-10-01 | 2008-12-31 |  | 318d |  |  |  | 140h | 9,800 |
| 482 | 1.3.5.5.1.1.1 | LSC Sequencer: Architecture | 44d? | 2008-10-01 | 2008-12-01 |  | 318d | 0d | finish no earlier than 2008-12-01 | Johansson [5.7%]; Morrison [17%] | 80h | 5,600 |
| 483 | 1.3.5.5.1.1.2 | LSC Sequencer: Interface Control Document | 22d? | 2008-12-02 | 2008-12-31 | 482 | 318d |  | start no earlier than 2008-12-02 | Morrison [11.4%] | 20h | 1,400 |
| 484 | 1.3.5.5.1.1.3 | LSC Sequencer: Software Module Design | 22d? | 2008-12-02 | 2008-12-31 | 482 | 318d |  | start no earlier than 2008-12-02 | Morrison [17%] | 30h | 2,100 |
| 485 | 1.3.5.5.1.1.4 | LSC Sequencer Summary Report | 22d? | 2008-12-02 | 2008-12-31 | 482 | 318d |  | start no earlier than 2008-12-02 | Morrison [5.7%] | 10h | 700 |

Notes:
- 458: CN
- 465: JC
- 466: JC
- 473: DS
- 479: EJ
- 480: EJ
- 481: EJ

| ID | WBS | Task | Duration | Start | Finish | Predecessors | Total slack | Free slack | Constraint | Resources | Work | Cost |
| --- | --- | --- | --- | --- | --- | --- | --- | --- | --- | --- | --- | --- |
| 486 | 1.3.5.5.1.2 | **LSC Motion Control SW** | 168d? | 2008-10-01 | 2009-05-22 |  | 216d |  |  |  | 230h | 16,100 |
| 487 | 1.3.5.5.1.2.1 | Motion Control SW: Architecture | 62d? | 2009-01-05 | 2009-03-31 |  | 254d |  | finish no earlier than 2009-03-31 | Morrison [16.1%] | 80h | 5,600 |
| 488 | 1.3.5.5.1.2.2 | Motion Control SW: ICD | 50d? | 2009-03-02 | 2009-05-08 |  | 226d |  | finish no earlier than 2009-05-08 | Morrison [10%] | 40h | 2,800 |
| 489 | 1.3.5.5.1.2.3 | Motion Control SW: Module Design | 50d? | 2009-03-02 | 2009-05-08 |  | 216d | 0d | finish no earlier than 2009-05-08 | Morrison [22.5%] | 90h | 6,300 |
| 490 | 1.3.5.5.1.2.4 | Motion Control SW: User Interface Design | 1d? | 2008-10-01 | 2008-10-01 |  | 383d |  | start no earlier than 2008-10-01 |  |  |  |
| 491 | 1.3.5.5.1.2.5 | Motion Control SW: Technical Specifications | 1d? | 2008-10-01 | 2008-10-01 |  | 383d |  | start no earlier than 2008-10-01 |  |  |  |
| 492 | 1.3.5.5.1.2.6 | Motion Control SW: Compliance Matrix | 1d? | 2008-10-01 | 2008-10-01 |  | 383d |  | start no earlier than 2008-10-01 |  |  |  |
| 493 | 1.3.5.5.1.2.7 | Motion Control SW: Test Plan | 1d? | 2008-10-01 | 2008-10-01 |  | 383d |  | start no earlier than 2008-10-01 |  |  |  |
| 494 | 1.3.5.5.1.2.8 | Motion Control SW: Summary Report | 10d? | 2009-05-11 | 2009-05-22 | 489 | 216d |  |  | Morrison [25%] | 20h | 1,400 |
| 495 | 1.3.5.5.1.3 | **LSC Device Control SW** | 327d? | 2008-10-01 | 2009-12-31 |  | 57d |  |  |  | 240h | 16,800 |
| 496 | 1.3.5.5.1.3.1 | Device Control: Software Architecture | 66d? | 2009-10-01 | 2009-12-31 |  | 57d |  | start no earlier than 2009-10-01 | Johansson [7.6%]; Morrison [7.6%] | 80h | 5,600 |
| 497 | 1.3.5.5.1.3.2 | Device Control: Interface Control Document | 66d? | 2009-10-01 | 2009-12-31 |  | 57d |  | start no earlier than 2009-10-01 | Johansson [3.8%]; Morrison [3.8%] | 40h | 2,800 |
| 498 | 1.3.5.5.1.3.3 | Device Control: Software Module Design | 66d? | 2009-10-01 | 2009-12-31 |  | 57d |  | start no earlier than 2009-10-01 | Johansson [9.5%]; Morrison [9.5%] | 100h | 7,000 |
| 499 | 1.3.5.5.1.3.4 | Device Control: User Interface Design | 1d? | 2008-10-01 | 2008-10-01 |  | 383d |  | start no earlier than 2008-10-01 |  |  |  |
| 500 | 1.3.5.5.1.3.5 | Device Control: Technical Specifications | 1d? | 2008-10-01 | 2008-10-01 |  | 383d |  | start no earlier than 2008-10-01 |  |  |  |
| 501 | 1.3.5.5.1.3.6 | Device Control: Compliance Matrix | 1d? | 2008-10-01 | 2008-10-01 |  | 383d |  | start no earlier than 2008-10-01 |  |  |  |
| 502 | 1.3.5.5.1.3.7 | Device Control: Test Plan | 1d? | 2008-10-01 | 2008-10-01 |  | 383d |  | start no earlier than 2008-10-01 |  |  |  |
| 503 | 1.3.5.5.1.3.8 | Device Control: Summary Report | 66d? | 2009-10-01 | 2009-12-31 |  | 57d |  | start no earlier than 2009-10-01 | Johansson [1.9%]; Morrison [1.9%] | 20h | 1,400 |
| 504 | 1.3.5.5.2 | **LSC Hardware** | 119d? | 2009-07-01 | 2009-12-14 |  | 70d |  |  |  | 310h | 21,700 |
| 505 | 1.3.5.5.2.1 | LSC Hardware Requirements & Interfaces | 23d? | 2009-07-01 | 2009-07-31 |  | 166d |  | start no earlier than 2009-07-01 | Neyman [21.7%]; Wetherell [16.3%]; Chin [10.9%] | 90h | 6,300 |
| 506 | 1.3.5.5.2.2 | LSC Motion Control Hardware | 43d? | 2009-07-20 | 2009-09-16 |  | 133d |  | start no earlier than 2009-07-20 | Wetherell [34.9%] | 120h | 8,400 |
| 507 | 1.3.5.5.2.3 | LSC Device Control Hardware | 53d? | 2009-10-01 | 2009-12-14 |  | 70d |  | start no earlier than 2009-10-01 | Wetherell [23.6%] | 100h | 7,000 |
| 508 | 1.3.5.6 | Laser System Lab I&T Plan | 20d? | 2009-10-05 | 2009-10-30 |  | 101d |  | finish no earlier than 2009-10-30 | Neyman [20%]; Chin; Nance | 48h | 3,360 |
| 509 | 1.3.6 | **Science Operations Tools Design** | 477d? | 2008-04-01 | 2010-01-27 |  | 38d |  |  |  | 1800h | 110,950 |
| 510 | 1.3.6.1 | **Multi-Systems Command Sequencer (MCS)** | 327d? | 2008-07-01 | 2009-09-30 |  | 123d |  |  |  | 620h | 39,200 |
| 511 | 1.3.6.1.1 | **MCS Infrastructure** | 294d? | 2008-07-07 | 2009-08-20 |  | 152d |  |  |  | 180h | 8,400 |
| 512 | 1.3.6.1.1.1 | **MCS Infrastructure Architecture** | 100d? | 2008-10-01 | 2009-02-17 |  | 284d |  |  |  | 140h | 5,600 |
| 513 | 1.3.6.1.1.1.1 | MCS Architecture | 20d? | 2008-10-01 | 2008-10-28 |  | 284d | 0d | finish no earlier than 2008-10-28 | Johansson [6.2%]; Le Mignant [6.2%]; Johnson [6.2%]; Morrison [6.2%] | 40h | 2,100 |
| 514 | 1.3.6.1.1.1.2 | MCS Operations Concept Document | 80d? | 2008-10-29 | 2009-02-17 | 513 | 284d |  |  | Johansson [3.1%]; Johnson [3.1%] | 40h | 1,400 |
| 515 | 1.3.6.1.1.1.3 | MCS Software Requirements | 80d? | 2008-10-29 | 2009-02-17 | 513 | 284d |  |  | Johansson [3.1%]; Johnson [3.1%] | 40h | 1,400 |
| 516 | 1.3.6.1.1.1.4 | MCS Module Definitions | 80d? | 2008-10-29 | 2009-02-17 | 513 | 284d |  |  | Johansson [1.6%]; Johnson [1.6%] | 20h | 700 |

Notes:
- 486: DM
- 495: DM
- 504: EW
- 505: EW
- 506: EW
- 507: EW
- 508: CN
- 509: DLM
- 510: EJ

| ID | WBS | Task | Duration | Start | Finish | Total slack | Constraint | Resources | Work | Cost |
| --- | --- | --- | --- | --- | --- | --- | --- | --- | --- | --- |
| 517 | 1.3.6.1.1.2 | **Coordination Sequence Support Library** | 294d? | 2008-07-07 | 2009-08-20 | 152d |  |  | 20h | 1,400 |
| 518 | 1.3.6.1.1.2.1 | Functional Requirements | 80d? | 2009-05-01 | 2009-08-20 | 152d | start no earlier than 2009-05-01 | Johansson [3.1%] | 20h | 1,400 |
| 519 | 1.3.6.1.1.2.2 | Interface Definitions | 1d? | 2008-07-07 | 2008-07-07 | 445d | start no earlier than 2008-07-07 |  |  |  |
| 520 | 1.3.6.1.1.3 | **Command Interface** | 294d? | 2008-07-07 | 2009-08-20 | 152d |  |  | 10h | 700 |
| 521 | 1.3.6.1.1.3.1 | Functional Requirements | 80d? | 2009-05-01 | 2009-08-20 | 152d | start no earlier than 2009-05-01 | Johansson [1.6%] | 10h | 700 |
| 522 | 1.3.6.1.1.3.2 | Interface Definitions | 1d? | 2008-07-07 | 2008-07-07 | 445d | finish no earlier than 2008-07-07 |  |  |  |
| 523 | 1.3.6.1.1.4 | **System Health** | 294d? | 2008-07-07 | 2009-08-20 | 152d |  |  | 10h | 700 |
| 524 | 1.3.6.1.1.4.1 | Functional Requirements | 80d? | 2009-05-01 | 2009-08-20 | 152d | start no earlier than 2009-05-01 | Johansson [1.6%] | 10h | 700 |
| 525 | 1.3.6.1.1.4.2 | Interface Definitions | 1d? | 2008-07-07 | 2008-07-07 | 445d | start no earlier than 2008-07-07 |  |  |  |
| 526 | 1.3.6.1.2 | **Setup Sequences: Configuration & Calibration** | 307d? | 2008-07-01 | 2009-09-02 | 143d |  |  | 100h | 7,000 |
| 527 | 1.3.6.1.2.1 | **Setup Sequences Common Structure** | 89d? | 2009-05-01 | 2009-09-02 | 143d |  |  | 60h | 4,200 |
| 528 | 1.3.6.1.2.1.1 | Setup Sequences Operations Concept Document | 89d? | 2009-05-01 | 2009-09-02 | 143d | start no earlier than 2009-05-01 | Johansson [2.8%] | 20h | 1,400 |
| 529 | 1.3.6.1.2.1.2 | Setup Sequences Software Requirements | 89d? | 2009-05-01 | 2009-09-02 | 143d | start no earlier than 2009-05-01 | Johansson [2.8%] | 20h | 1,400 |
| 530 | 1.3.6.1.2.1.3 | Setup Sequences Module Definitions | 89d? | 2009-05-01 | 2009-09-02 | 143d | start no earlier than 2009-05-01 | Johansson [2.8%] | 20h | 1,400 |
| 531 | 1.3.6.1.2.2 | **Configuration Sequences** | 89d? | 2008-07-01 | 2008-10-31 | 361d |  |  | 20h | 1,400 |
| 532 | 1.3.6.1.2.2.1 | Functional Requirements | 89d? | 2008-07-01 | 2008-10-31 | 361d | finish no earlier than 2008-10-31 | Le Mignant [2.8%] | 20h | 1,400 |
| 533 | 1.3.6.1.2.2.2 | Interface Definitions | 1d? | 2008-07-01 | 2008-07-01 | 449d | start no earlier than 2008-07-01 |  |  |  |
| 534 | 1.3.6.1.2.3 | **Calibration Sequences** | 89d? | 2008-07-01 | 2008-10-31 | 361d |  |  | 20h | 1,400 |
| 535 | 1.3.6.1.2.3.1 | Functional Requirements | 89d? | 2008-07-01 | 2008-10-31 | 361d | finish no earlier than 2008-10-31 | Le Mignant [2.8%] | 20h | 1,400 |
| 536 | 1.3.6.1.2.3.2 | Interface Definitions | 1d? | 2008-07-01 | 2008-07-01 | 449d | start no earlier than 2008-07-01 |  |  |  |
| 537 | 1.3.6.1.3 | **Observing Sequences** | 241d? | 2008-10-01 | 2009-09-02 | 143d |  |  | 240h | 16,800 |
| 538 | 1.3.6.1.3.1 | **Observing Sequences Common Structure** | 89d? | 2009-05-01 | 2009-09-02 | 143d |  |  | 120h | 8,400 |
| 539 | 1.3.6.1.3.1.1 | Observing Sequences Operations Concept Document | 89d? | 2009-05-01 | 2009-09-02 | 143d | start no earlier than 2009-05-01 | Le Mignant [4.2%]; Johansson [1.4%] | 40h | 2,800 |
| 540 | 1.3.6.1.3.1.2 | Observing Sequences Software Requirements | 89d? | 2009-05-01 | 2009-09-02 | 143d | start no earlier than 2009-05-01 | Johansson [5.6%] | 40h | 2,800 |
| 541 | 1.3.6.1.3.1.3 | Observing Sequences Module Definitions | 89d? | 2009-05-01 | 2009-09-02 | 143d | start no earlier than 2009-05-01 | Johansson [2.8%]; Le Mignant [2.8%] | 40h | 2,800 |

| ID | WBS | Task | Duration | Start | Finish | Predecessors | Total slack | Free slack | Constraint | Resources | Work | Cost |
| --- | --- | --- | --- | --- | --- | --- | --- | --- | --- | --- | --- | --- |
| 542 | 1.3.6.1.3.2 | **Acquisition Sequences** | 89d? | 2009-05-01 | 2009-09-02 |  | 143d |  |  |  | 60h | 4,200 |
| 543 | 1.3.6.1.3.2.1 | Functional Requirements | 89d? | 2009-05-01 | 2009-09-02 |  | 143d |  | start no earlier than 2009-05-01 | Le Mignant [4.2%]; Johansson [1.4%] | 40h | 2,800 |
| 544 | 1.3.6.1.3.2.2 | Interface Definitions | 89d? | 2009-05-01 | 2009-09-02 |  | 143d |  | start no earlier than 2009-05-01 | Johansson [2.8%] | 20h | 1,400 |
| 545 | 1.3.6.1.3.3 | **Observing Sequences** | 89d? | 2008-10-01 | 2009-02-02 |  | 295d |  |  |  | 20h | 1,400 |
| 546 | 1.3.6.1.3.3.1 | Functional Requirements | 89d? | 2008-10-01 | 2009-02-02 |  | 295d |  | finish no earlier than 2009-02-02 | Le Mignant [2.8%] | 20h | 1,400 |
| 547 | 1.3.6.1.3.3.2 | Interface Definitions | 1d? | 2008-10-01 | 2008-10-01 |  | 383d |  | start no earlier than 2008-10-01 |  |  |  |
| 548 | 1.3.6.1.3.4 | **Quality Monitoring Sequences** | 89d? | 2008-10-01 | 2009-02-02 |  | 295d |  |  |  | 20h | 1,400 |
| 549 | 1.3.6.1.3.4.1 | Functional Requirements | 89d? | 2008-10-01 | 2009-02-02 |  | 295d |  | finish no earlier than 2009-02-02 | Le Mignant [2.8%] | 20h | 1,400 |
| 550 | 1.3.6.1.3.4.2 | Interface Definitions | 1d? | 2008-10-01 | 2008-10-01 |  | 383d |  | start no earlier than 2008-10-01 |  |  |  |
| 551 | 1.3.6.1.3.5 | **Optimization Sequences** | 89d? | 2008-10-01 | 2009-02-02 |  | 295d |  |  |  | 20h | 1,400 |
| 552 | 1.3.6.1.3.5.1 | Functional Requirements | 89d? | 2008-10-01 | 2009-02-02 |  | 295d |  | finish no earlier than 2009-02-02 | Le Mignant [2.8%] | 20h | 1,400 |
| 553 | 1.3.6.1.3.5.2 | Interface Definitions | 1d? | 2008-10-01 | 2008-10-01 |  | 383d |  | start no earlier than 2008-10-01 |  |  |  |
| 554 | 1.3.6.1.4 | **Alarm Handler & Troubleshooting Sequences** | 261d? | 2008-10-01 | 2009-09-30 |  | 123d |  |  |  | 100h | 7,000 |
| 555 | 1.3.6.1.4.1 | **Alarm Handler & Troubleshooting Common Structure** | 43d? | 2009-08-03 | 2009-09-30 |  | 123d |  |  |  | 100h | 7,000 |
| 556 | 1.3.6.1.4.1.1 | Alarm & Troubleshooting Operations Concept Document | 43d? | 2009-08-03 | 2009-09-30 |  | 123d |  | finish no earlier than 2009-09-30 | Le Mignant [8.7%]; Morrison [2.9%] | 40h | 2,800 |
| 557 | 1.3.6.1.4.1.2 | Alarm & Troubleshooting Software Requirements | 43d? | 2009-08-03 | 2009-09-30 |  | 123d |  | finish no earlier than 2009-09-30 | Morrison [5.8%] | 20h | 1,400 |
| 558 | 1.3.6.1.4.1.3 | Alarm & Troubleshooting Module Definitions | 43d? | 2009-08-03 | 2009-09-30 |  | 123d |  | finish no earlier than 2009-09-30 | Morrison [5.8%]; Le Mignant [5.8%] | 40h | 2,800 |
| 559 | 1.3.6.1.4.2 | **Alarm Handler Sequences** | 1d? | 2008-10-01 | 2008-10-01 |  | 383d |  |  |  |  |  |
| 560 | 1.3.6.1.4.2.1 | Functional Requirements | 1d? | 2008-10-01 | 2008-10-01 |  | 383d |  | start no earlier than 2008-10-01 |  |  |  |
| 561 | 1.3.6.1.4.2.2 | Interface Definitions | 1d? | 2008-10-01 | 2008-10-01 |  | 383d |  | start no earlier than 2008-10-01 |  |  |  |
| 562 | 1.3.6.1.4.3 | **Troubleshooting Sequences** | 1d? | 2008-10-01 | 2008-10-01 |  | 383d |  |  |  |  |  |
| 563 | 1.3.6.1.4.3.1 | Functional Requirements | 1d? | 2008-10-01 | 2008-10-01 |  | 383d |  | start no earlier than 2008-10-01 |  |  |  |
| 564 | 1.3.6.1.4.3.2 | Interface Definitions | 1d? | 2008-10-01 | 2008-10-01 |  | 383d |  | start no earlier than 2008-10-01 |  |  |  |
| 565 | 1.3.6.2 | **User Interfaces** | 477d? | 2008-04-01 | 2010-01-27 |  | 38d |  |  |  | 500h | 28,350 |
| 566 | 1.3.6.2.1 | **User Interface (UI) Infrastructure** | 393d? | 2008-04-01 | 2009-10-01 |  | 122d |  |  |  | 180h | 5,950 |
| 567 | 1.3.6.2.1.1 | **UI Infrastructure Architecture** | 64d? | 2009-02-02 | 2009-04-30 |  | 232d |  |  |  | 120h | 1,750 |
| 568 | 1.3.6.2.1.1.1 | UI Architecture | 20d? | 2009-02-02 | 2009-02-27 |  | 254d | 0d | finish no earlier than 2009-02-27 | Johnson [21.9%]; Le Mignant | 40h | 350 |
| 569 | 1.3.6.2.1.1.2 | UI Operations Concept Document | 22d? | 2009-03-02 | 2009-03-31 | 568 | 254d |  | start no earlier than 2009-03-02 | Le Mignant [11.4%]; Johnson [11.4%] | 40h | 1,400 |
| 570 | 1.3.6.2.1.1.3 | UI Software Requirements | 13d? | 2009-04-01 | 2009-04-17 |  | 241d |  | start no earlier than 2009-04-01 | Johnson [19.2%] | 20h |  |
| 571 | 1.3.6.2.1.1.4 | UI Module Definitions | 9d? | 2009-04-20 | 2009-04-30 |  | 232d |  | finish no earlier than 2009-04-30 | Johnson [27.8%] | 20h |  |

Notes:
- 565: DLM

| ID | WBS | Task | Duration | Start | Finish | Total slack | Constraint | Resources | Work | Cost |
| --- | --- | --- | --- | --- | --- | --- | --- | --- | --- | --- |
| 572 | 1.3.6.2.1.2 | **UI Command Interface to MCS** | 89d? | 2009-06-01 | 2009-10-01 | 122d |  |  | 40h | 2,800 |
| 573 | 1.3.6.2.1.2.1 | Functional Requirements | 89d? | 2009-06-01 | 2009-10-01 | 122d | start no earlier than 2009-06-01 | Morrison [2.8%] | 20h | 1,400 |
| 574 | 1.3.6.2.1.2.2 | Interface Definitions | 89d? | 2009-06-01 | 2009-10-01 | 122d | start no earlier than 2009-06-01 | Morrison [2.8%] | 20h | 1,400 |
| 575 | 1.3.6.2.1.3 | **UI Command Interface to Pre- & Post-Observing Tools** | 393d? | 2008-04-01 | 2009-10-01 | 122d |  |  | 20h | 1,400 |
| 576 | 1.3.6.2.1.3.1 | Functional Requirements | 89d? | 2009-06-01 | 2009-10-01 | 122d | start no earlier than 2009-06-01 | Morrison [2.8%] | 20h | 1,400 |
| 577 | 1.3.6.2.1.3.2 | Interface Definitions | 89d? | 2008-04-01 | 2008-08-01 | 426d |  |  |  |  |
| 578 | 1.3.6.2.2 | **Setup User Interfaces** | 260d? | 2008-10-01 | 2009-09-29 | 124d |  |  | 80h | 5,600 |
| 579 | 1.3.6.2.2.1 | **Setup UI Common Structure** | 260d? | 2008-10-01 | 2009-09-29 | 124d |  |  | 50h | 3,500 |
| 580 | 1.3.6.2.2.1.1 | Setup UI Operations Concept Document | 130d? | 2008-10-01 | 2009-03-31 | 254d | start no earlier than 2008-10-01 | Le Mignant [1.9%] | 20h | 1,400 |
| 581 | 1.3.6.2.2.1.2 | Setup UI Software Requirements | 87d? | 2009-06-01 | 2009-09-29 | 124d | start no earlier than 2009-06-01 | Morrison [1.4%] | 10h | 700 |
| 582 | 1.3.6.2.2.1.3 | Setup UI Module Definitions | 87d? | 2009-06-01 | 2009-09-29 | 124d | start no earlier than 2009-06-01 | Morrison [2.9%] | 20h | 1,400 |
| 583 | 1.3.6.2.2.2 | **Setup UI Configurations** | 130d? | 2008-10-01 | 2009-03-31 | 254d |  |  | 15h | 1,050 |
| 584 | 1.3.6.2.2.2.1 | Functional Requirements | 130d? | 2008-10-01 | 2009-03-31 | 254d | finish no earlier than 2009-03-31 | Le Mignant [1.4%] | 15h | 1,050 |
| 585 | 1.3.6.2.2.2.2 | Interface Definitions | 130d? | 2008-10-01 | 2009-03-31 | 254d | finish no earlier than 2009-03-31 |  |  |  |
| 586 | 1.3.6.2.2.3 | **Setup UI Calibrations** | 130d? | 2008-10-01 | 2009-03-31 | 254d |  |  | 15h | 1,050 |
| 587 | 1.3.6.2.2.3.1 | Functional Requirements | 130d? | 2008-10-01 | 2009-03-31 | 254d | finish no earlier than 2009-03-31 | Le Mignant [1.4%] | 15h | 1,050 |
| 588 | 1.3.6.2.2.3.2 | Interface Definitions | 130d? | 2008-10-01 | 2009-03-31 | 254d | finish no earlier than 2009-03-31 |  |  |  |
| 589 | 1.3.6.2.3 | **Observations User Interfaces** | 346d? | 2008-10-01 | 2010-01-27 | 38d |  |  | 240h | 16,800 |
| 590 | 1.3.6.2.3.1 | **Observations UI Common Structure** | 86d? | 2009-04-01 | 2009-07-29 | 168d |  |  | 130h | 9,100 |
| 591 | 1.3.6.2.3.1.1 | Observations UI Operations Concept Document | 86d? | 2009-04-01 | 2009-07-29 | 168d | start no earlier than 2009-04-01 | Le Mignant [4.4%]; Morrison | 40h | 2,800 |
| 592 | 1.3.6.2.3.1.2 | Observations UI Software Requirements | 86d? | 2009-04-01 | 2009-07-29 | 168d | start no earlier than 2009-04-01 | Morrison [1.5%] | 10h | 700 |
| 593 | 1.3.6.2.3.1.3 | Observations UI Module Definitions | 86d? | 2009-04-01 | 2009-07-29 | 168d | start no earlier than 2009-04-01 | Morrison [5.8%]; Le Mignant [5.8%] | 80h | 5,600 |
| 594 | 1.3.6.2.3.2 | **Acquisition & AO Control UI** | 216d? | 2009-04-01 | 2010-01-27 | 38d |  |  | 30h | 2,100 |
| 595 | 1.3.6.2.3.2.1 | Functional Requirements | 216d? | 2009-04-01 | 2010-01-27 | 38d | start no earlier than 2009-04-01 | Le Mignant [1.2%] | 20h | 1,400 |
| 596 | 1.3.6.2.3.2.2 | Interface Definitions | 173d? | 2009-04-01 | 2009-11-27 | 81d | start no earlier than 2009-04-01 | Morrison [0.7%] | 10h | 700 |

| ID | WBS | Task | Duration | Start | Finish | Total slack | Constraint | Resources | Work | Cost |
| --- | --- | --- | --- | --- | --- | --- | --- | --- | --- | --- |
| 597 | 1.3.6.2.3.3 | **Observing Sequences UI** | 173d? | 2008-10-01 | 2009-05-29 | 211d |  |  | 20h | 1,400 |
| 598 | 1.3.6.2.3.3.1 | Functional Requirements | 173d? | 2008-10-01 | 2009-05-29 | 211d | finish no earlier than 2009-05-29 | Le Mignant [1.4%] | 20h | 1,400 |
| 599 | 1.3.6.2.3.3.2 | Interface Definitions | 173d? | 2008-10-01 | 2009-05-29 | 211d | finish no earlier than 2009-05-29 |  |  |  |
| 600 | 1.3.6.2.3.4 | **Status & Graph UI** | 173d? | 2008-10-01 | 2009-05-29 | 211d |  |  | 20h | 1,400 |
| 601 | 1.3.6.2.3.4.1 | Functional Requirements | 173d? | 2008-10-01 | 2009-05-29 | 211d | finish no earlier than 2009-05-29 | Le Mignant [1.4%] | 20h | 1,400 |
| 602 | 1.3.6.2.3.4.2 | Interface Definitions | 173d? | 2008-10-01 | 2009-05-29 | 211d | finish no earlier than 2009-05-29 |  |  |  |
| 603 | 1.3.6.2.3.5 | **Advanced Monitoring UI** | 173d? | 2008-10-01 | 2009-05-29 | 211d |  |  | 20h | 1,400 |
| 604 | 1.3.6.2.3.5.1 | Functional Requirements | 173d? | 2008-10-01 | 2009-05-29 | 211d | finish no earlier than 2009-05-29 | Le Mignant [1.4%] | 20h | 1,400 |
| 605 | 1.3.6.2.3.5.2 | Interface Definitions | 173d? | 2008-10-01 | 2009-05-29 | 211d | finish no earlier than 2009-05-29 |  |  |  |
| 606 | 1.3.6.2.3.6 | **Optimization & Troubleshooting UI** | 173d? | 2008-10-01 | 2009-05-29 | 211d |  |  | 20h | 1,400 |
| 607 | 1.3.6.2.3.6.1 | Functional Requirements | 173d? | 2008-10-01 | 2009-05-29 | 211d | finish no earlier than 2009-05-29 | Le Mignant [1.4%] | 20h | 1,400 |
| 608 | 1.3.6.2.3.6.2 | Interface Definitions | 173d? | 2008-10-01 | 2009-05-29 | 211d | finish no earlier than 2009-05-29 |  |  |  |
| 609 | 1.3.6.3 | **Pre- & Post-Observing Science Support Tools** | 217d? | 2009-01-01 | 2009-10-30 | 101d |  |  | 610h | 42,700 |
| 610 | 1.3.6.3.1 | **User Documentation** | 174d? | 2009-01-01 | 2009-09-01 | 144d |  |  | 20h | 1,400 |
| 611 | 1.3.6.3.1.1 | User Documentation Operations Concept | 174d? | 2009-01-01 | 2009-09-01 | 144d | finish no earlier than 2009-09-01 | Le Mignant [0.7%] | 10h | 700 |
| 612 | 1.3.6.3.1.2 | User Documentation Functional Requirements | 174d? | 2009-01-01 | 2009-09-01 | 144d | finish no earlier than 2009-09-01 | Le Mignant [0.7%] | 10h | 700 |
| 613 | 1.3.6.3.2 | **Science Observations Planning Tools** | 148d? | 2009-01-07 | 2009-07-31 | 166d |  |  | 340h | 23,800 |
| 614 | 1.3.6.3.2.1 | **NGS Star Finder** | 148d? | 2009-01-07 | 2009-07-31 | 166d |  |  | 60h | 4,200 |
| 615 | 1.3.6.3.2.1.1 | Operations Concept | 148d? | 2009-01-07 | 2009-07-31 | 166d | finish no earlier than 2009-07-31 | Le Mignant [1.7%] | 20h | 1,400 |
| 616 | 1.3.6.3.2.1.2 | Functional Requirements & Use Case Definitions | 148d? | 2009-01-07 | 2009-07-31 | 166d | finish no earlier than 2009-07-31 | Le Mignant [3.4%] | 40h | 2,800 |
| 617 | 1.3.6.3.2.1.3 | Interface Definitions | 148d? | 2009-01-07 | 2009-07-31 | 166d | finish no earlier than 2009-07-31 |  |  |  |
| 618 | 1.3.6.3.2.1.4 | Module Definitions | 148d? | 2009-01-07 | 2009-07-31 | 166d | finish no earlier than 2009-07-31 |  |  |  |
| 619 | 1.3.6.3.2.2 | **Performance Prediction Tool** | 148d? | 2009-01-07 | 2009-07-31 | 166d |  |  | 140h | 9,800 |
| 620 | 1.3.6.3.2.2.1 | Operations Concept | 148d? | 2009-01-07 | 2009-07-31 | 166d | finish no earlier than 2009-07-31 | Le Mignant [3.4%] | 40h | 2,800 |
| 621 | 1.3.6.3.2.2.2 | Functional Requirements & Use Case Definitions | 148d? | 2009-01-07 | 2009-07-31 | 166d | finish no earlier than 2009-07-31 | Le Mignant [3.4%] | 40h | 2,800 |
| 622 | 1.3.6.3.2.2.3 | Interface Definitions | 148d? | 2009-01-07 | 2009-07-31 | 166d | finish no earlier than 2009-07-31 | Johansson [1.7%] | 20h | 1,400 |
| 623 | 1.3.6.3.2.2.4 | Module Definitions | 148d? | 2009-01-07 | 2009-07-31 | 166d | finish no earlier than 2009-07-31 | Johansson [1.7%]; Le Mignant [1.7%] | 40h | 2,800 |

Notes:
- 609: DLM

| ID | WBS | Task | Duration | Start | Finish | Total slack | Constraint | Resources | Work | Cost |
| --- | --- | --- | --- | --- | --- | --- | --- | --- | --- | --- |
| 624 | 1.3.6.3.2.3 | **Observation Planning & Efficiency Tool** | 148d? | 2009-01-07 | 2009-07-31 | 166d |  |  | 140h | 9,800 |
| 625 | 1.3.6.3.2.3.1 | Operations Concept | 148d? | 2009-01-07 | 2009-07-31 | 166d | finish no earlier than 2009-07-31 | Le Mignant [3.4%] | 40h | 2,800 |
| 626 | 1.3.6.3.2.3.2 | Functional Requirements & Use Case Definitions | 148d? | 2009-01-07 | 2009-07-31 | 166d | finish no earlier than 2009-07-31 | Le Mignant [3.4%] | 40h | 2,800 |
| 627 | 1.3.6.3.2.3.3 | Interface Definitions | 148d? | 2009-01-07 | 2009-07-31 | 166d | finish no earlier than 2009-07-31 | Johansson [1.7%] | 20h | 1,400 |
| 628 | 1.3.6.3.2.3.4 | Module Definitions | 148d? | 2009-01-07 | 2009-07-31 | 166d | finish no earlier than 2009-07-31 | Johansson [1.7%]; Le Mignant [1.7%] | 40h | 2,800 |
| 629 | 1.3.6.3.2.4 | **Laser Clearinghouse Coordination Tool** | 148d? | 2009-01-07 | 2009-07-31 | 166d |  |  |  |  |
| 630 | 1.3.6.3.2.4.1 | Operations Concept | 148d? | 2009-01-07 | 2009-07-31 | 166d | finish no earlier than 2009-07-31 |  |  |  |
| 631 | 1.3.6.3.2.4.2 | Functional Requirements & Use Case Definitions | 148d? | 2009-01-07 | 2009-07-31 | 166d | finish no earlier than 2009-07-31 |  |  |  |
| 632 | 1.3.6.3.2.4.3 | Interface Definitions | 148d? | 2009-01-07 | 2009-07-31 | 166d | finish no earlier than 2009-07-31 |  |  |  |
| 633 | 1.3.6.3.2.4.4 | Module Definitions | 148d? | 2009-01-07 | 2009-07-31 | 166d | finish no earlier than 2009-07-31 |  |  |  |
| 634 | 1.3.6.3.3 | **Data Products** | 195d? | 2009-02-02 | 2009-10-30 | 101d |  |  | 250h | 17,500 |
| 635 | 1.3.6.3.3.1 | **Generic Data Products** | 152d? | 2009-02-02 | 2009-09-01 | 144d |  |  | 80h | 5,600 |
| 636 | 1.3.6.3.3.1.1 | Operations Concept | 152d? | 2009-02-02 | 2009-09-01 | 144d | finish no earlier than 2009-09-01 | Le Mignant [1.6%] | 20h | 1,400 |
| 637 | 1.3.6.3.3.1.2 | Functional Requirements & Use Case Definitions | 152d? | 2009-02-02 | 2009-09-01 | 144d | finish no earlier than 2009-09-01 | Le Mignant [3.3%] | 40h | 2,800 |
| 638 | 1.3.6.3.3.1.3 | Interface Definitions | 152d? | 2009-02-02 | 2009-09-01 | 144d | finish no earlier than 2009-09-01 | Johansson [1.6%] | 20h | 1,400 |
| 639 | 1.3.6.3.3.2 | **Science Data Quality Assessment** | 195d? | 2009-02-02 | 2009-10-30 | 101d |  |  | 160h | 11,200 |
| 640 | 1.3.6.3.3.2.1 | **Quality Metrics & Logged Information** | 152d? | 2009-02-02 | 2009-09-01 | 144d |  |  | 80h | 5,600 |
| 641 | 1.3.6.3.3.2.1.1 | Operations Concept | 152d? | 2009-02-02 | 2009-09-01 | 144d | finish no earlier than 2009-09-01 | Le Mignant [3.3%] | 40h | 2,800 |
| 642 | 1.3.6.3.3.2.1.2 | Functional Requirements & Use Case Definitions | 152d? | 2009-02-02 | 2009-09-01 | 144d | finish no earlier than 2009-09-01 | Le Mignant [3.3%] | 40h | 2,800 |
| 643 | 1.3.6.3.3.2.1.3 | Interface Definitions | 152d? | 2009-02-02 | 2009-09-01 | 144d | finish no earlier than 2009-09-01 |  |  |  |
| 644 | 1.3.6.3.3.2.2 | **PSF Calibration** | 195d? | 2009-02-02 | 2009-10-30 | 101d |  |  | 80h | 5,600 |
| 645 | 1.3.6.3.3.2.2.1 | Operations Concept | 195d? | 2009-02-02 | 2009-10-30 | 101d | finish no earlier than 2009-10-30 | Le Mignant [2.6%] | 40h | 2,800 |
| 646 | 1.3.6.3.3.2.2.2 | Functional Requirements & Use Case Definitions | 195d? | 2009-02-02 | 2009-10-30 | 101d | finish no earlier than 2009-10-30 | Le Mignant [2.6%] | 40h | 2,800 |
| 647 | 1.3.6.3.3.2.2.3 | Interface Definitions | 195d? | 2009-02-02 | 2009-10-30 | 101d | finish no earlier than 2009-10-30 |  |  |  |
| 648 | 1.3.6.3.3.2.2.4 | Module Definitions | 195d? | 2009-02-02 | 2009-10-30 | 101d | finish no earlier than 2009-10-30 |  |  |  |

| ID | WBS | Task | Type | Duration | Start | Finish | Predecessors | Total slack | Free slack | Constraint | Resources | Work | Cost |
| --- | --- | --- | --- | --- | --- | --- | --- | --- | --- | --- | --- | --- | --- |
| 649 | 1.3.6.3.3.3 | **Science Data Archiving** |  | 195d? | 2009-02-02 | 2009-10-30 |  | 101d |  |  |  | 10h | 700 |
| 650 | 1.3.6.3.3.3.1 | Operations Concept |  | 195d? | 2009-02-02 | 2009-10-30 |  | 101d |  | finish no earlier than 2009-10-30 | Le Mignant [0.6%] | 10h | 700 |
| 651 | 1.3.6.3.3.3.2 | Functional Requirements & Use Case Definitions |  | 195d? | 2009-02-02 | 2009-10-30 |  | 101d |  | finish no earlier than 2009-10-30 |  |  |  |
| 652 | 1.3.6.3.3.3.3 | Interface Definitions |  | 195d? | 2009-02-02 | 2009-10-30 |  | 101d |  | finish no earlier than 2009-10-30 |  |  |  |
| 653 | 1.3.6.4 | **Data Server** |  | 45d? | 2008-12-01 | 2009-02-02 |  | 296d |  |  |  | 70h | 700 |
| 654 | 1.3.6.4.1 | Data Server: Architecture |  | 23d? | 2008-12-01 | 2008-12-31 |  | 298d | 2d | finish no earlier than 2008-12-31 | Johansson [5.4%]; Johnson [16.3%] | 40h | 700 |
| 655 | 1.3.6.4.2 | Data Server: HW & SW Specification & Selection |  | 10d? | 2009-01-05 | 2009-01-16 | 654 | 296d | 0d | start no earlier than 2009-01-05 | Johnson [25%] | 20h |  |
| 656 | 1.3.6.4.3 | Data Server: Software Design | milestone | 0d? | 2009-02-02 | 2009-02-02 |  | 296d |  | start no earlier than 2009-02-02 |  |  |  |
| 657 | 1.3.6.4.4 | Data Server: Compliance Matrix | milestone | 0d? | 2009-02-02 | 2009-02-02 |  | 296d |  | start no earlier than 2009-02-02 |  |  |  |
| 658 | 1.3.6.4.5 | Data Server: Test Plan | milestone | 0d? | 2009-02-02 | 2009-02-02 |  | 296d |  | start no earlier than 2009-02-02 |  |  |  |
| 659 | 1.3.6.4.6 | Data Server: Summary Report |  | 10d? | 2009-01-19 | 2009-01-30 | 655 | 296d |  |  | Johnson [12.5%] | 10h |  |
| 660 | 1.3.7 | **Telescope & Summit Engineering Design** |  | 215d? | 2008-12-08 | 2009-10-02 |  | 121d |  |  |  | 1101h | 75,472 |
| 661 | 1.3.7.1 | Telescope Performance |  | 1d? | 2009-05-04 | 2009-05-04 |  | 230d |  | start no earlier than 2009-05-04 |  |  |  |
| 662 | 1.3.7.2 | **Infrastructure Modifications for AO** |  | 110d? | 2009-05-04 | 2009-10-02 |  | 121d |  |  |  | 660h | 45,797.2 |
| 663 | 1.3.7.2.1 | Infrastructure Requirements & Interfaces |  | 20d? | 2009-05-04 | 2009-05-29 |  | 211d |  | finish no earlier than 2009-05-29 | Bell [37.5%]; Wetherell; Wizinowich [60%] | 90h | 6,613.6 |
| 664 | 1.3.7.2.2 | Infrastructure Mechanical Modifications |  | 45d? | 2009-06-01 | 2009-07-31 |  | 166d |  | finish no earlier than 2009-07-31 | Bell; Medeiros [33.3%]; Mogensen | 160h | 10,505.6 |
| 665 | 1.3.7.2.3 | Infrastructure Electrical Modifications |  | 45d? | 2009-07-06 | 2009-09-04 |  | 141d |  | finish no earlier than 2009-09-04 | Nance [33.3%] | 120h | 8,400 |
| 666 | 1.3.7.2.4 | Infrastructure Glycol Cooling Modifications |  | 45d? | 2009-07-13 | 2009-09-11 |  | 136d |  | finish no earlier than 2009-09-11 | Nance [38.9%] | 140h | 9,800 |
| 667 | 1.3.7.2.5 | Infrastructure CCR Modifications |  | 45d? | 2009-07-13 | 2009-09-11 |  | 136d |  | finish no earlier than 2009-09-11 | Nance [11.1%] | 40h | 2,800 |
| 668 | 1.3.7.2.6 | Infrastructure Implementation & Test Plans |  | 25d? | 2009-08-31 | 2009-10-02 |  | 121d |  | finish no earlier than 2009-10-02 | Bell [25%]; Medeiros; Nance; Chin | 110h | 7,678 |
| 669 | 1.3.7.3 | **Infrastructure modifications for Laser System** |  | 110d? | 2009-05-04 | 2009-10-02 |  | 121d |  |  |  | 280h | 19,564.8 |
| 670 | 1.3.7.3.1 | Infrastructure Requirements & Interfaces |  | 20d? | 2009-05-04 | 2009-05-29 |  | 211d |  | finish no earlier than 2009-05-29 | Bell [25%]; Chin; Nance | 70h | 4,882.4 |
| 671 | 1.3.7.3.2 | Infrastructure Mechanical Modifications |  | 45d? | 2009-06-29 | 2009-08-28 |  | 146d |  | finish no earlier than 2009-08-28 | Medeiros [13.9%] | 50h | 3,500 |
| 672 | 1.3.7.3.3 | Infrastructure Electrical Modifications |  | 45d? | 2009-07-06 | 2009-09-04 |  | 141d |  | finish no earlier than 2009-09-04 | Nance [11.1%] | 40h | 2,800 |
| 673 | 1.3.7.3.4 | Infrastructure Glycol Cooling Modifications |  | 45d? | 2009-07-13 | 2009-09-11 |  | 136d |  | finish no earlier than 2009-09-11 | Nance [13.9%] | 50h | 3,500 |
| 674 | 1.3.7.3.5 | Infrastructure Implementation & Test Plans |  | 25d? | 2009-08-31 | 2009-10-02 |  | 121d |  | finish no earlier than 2009-10-02 | Bell [20%]; Chin; Medeiros; Nance | 70h | 4,882.4 |
| 675 | 1.3.7.4 | OSIRIS Modifications |  | 15d? | 2009-01-12 | 2009-01-30 |  | 296d |  | start no earlier than 2009-01-12 | Adkins [16.7%]; Tolleth [33.3%]; Medeiros [33.3%] | 100h | 4,880 |

Notes:
- 653: EJ
- 660: CN
- 662: JB
- 663: JB
- 664: DM
- 665: CN
- 666: CN
- 667: CN
- 668: JB
- 669: JB
- 670: JB
- 671: DM
- 672: CN
- 673: CN
- 674: JB
- 675: SA

| ID | WBS | Task | Duration | Start | Finish | Total slack | Constraint | Resources | Work | Cost |
| --- | --- | --- | --- | --- | --- | --- | --- | --- | --- | --- |
| 676 | 1.3.7.5 | **Interferometer Modifications** | 40d? | 2008-12-08 | 2009-01-30 | 296d |  |  | 61h | 5,230 |
| 677 | 1.3.7.5.1 | Optical Design of Post Field Selector Optics | 40d? | 2008-12-08 | 2009-01-30 | 296d | finish no earlier than 2009-01-30 | Wizinowich [7.8%]; Kupke [6.2%] | 45h | 3,566 |
| 678 | 1.3.7.5.2 | Evaluation of Optical Design Impact on Interferometer | 40d? | 2008-12-08 | 2009-01-30 | 296d | start no earlier than 2008-12-08 | Wizinowich [5%] | 16h | 1,664 |
| 679 | 1.3.8 | **Telescope Integration & Test** | 55d? | 2009-10-05 | 2009-12-18 | 66d |  |  | 622h | 45,194.4 |
| 680 | 1.3.8.1 | **Old AO/Laser Removal** | 20d? | 2009-10-05 | 2009-10-30 | 101d |  |  | 120h | 8,159.2 |
| 681 | 1.3.8.1.1 | AO Removal Plan | 20d? | 2009-10-05 | 2009-10-30 | 101d | start no earlier than 2009-10-05 | Nance [7.5%]; Bell [15%]; Wetherell [12.5%]; Wizinowich [2.5%]; Doyle | 60h | 4,143.2 |
| 682 | 1.3.8.1.2 | Laser Removal Plan | 20d? | 2009-10-05 | 2009-10-30 | 101d | start no earlier than 2009-10-05 | Chin [2.5%]; Medeiros [12.5%]; Doyle [5%]; Grace [10%]; Nance [7.5%] | 60h | 4,016 |
| 683 | 1.3.8.2 | Laser Enclosure Integration | 1d? | 2009-10-05 | 2009-10-05 | 120d | start no earlier than 2009-10-05 |  |  |  |
| 684 | 1.3.8.3 | AO Enclosure Integration | 1d? | 2009-10-05 | 2009-10-05 | 120d | start no earlier than 2009-10-05 |  |  |  |
| 685 | 1.3.8.4 | **AO System Install + I&T** | 35d? | 2009-11-02 | 2009-12-18 | 66d |  |  | 170h | 12,027.2 |
| 686 | 1.3.8.4.1 | Opto-Mechanical Integration Plan | 27d? | 2009-11-02 | 2009-12-08 | 74d | start no earlier than 2009-11-02 | Wizinowich [1.9%]; Bell [9.3%]; Neyman [16.7%] | 60h | 4,327.2 |
| 687 | 1.3.8.4.2 | Electronics Integration Plan | 35d? | 2009-11-02 | 2009-12-18 | 66d | start no earlier than 2009-11-02 | Wetherell [14.3%] | 40h | 2,800 |
| 688 | 1.3.8.4.3 | Computer Integration Plan | 35d? | 2009-11-02 | 2009-12-18 | 66d | start no earlier than 2009-11-02 | Chock [7.1%] | 20h | 1,400 |
| 689 | 1.3.8.4.4 | AO System Integration Plan | 35d? | 2009-11-02 | 2009-12-18 | 66d | start no earlier than 2009-11-02 | Neyman [14.3%] | 40h | 2,800 |
| 690 | 1.3.8.4.5 | AO System Test Plan | 35d? | 2009-11-02 | 2009-12-18 | 66d | start no earlier than 2009-11-02 | Neyman [3.6%] | 10h | 700 |
| 691 | 1.3.8.5 | **Laser System Install + I&T** | 35d? | 2009-11-02 | 2009-12-18 | 66d |  |  | 212h | 15,248 |
| 692 | 1.3.8.5.1 | Laser System Installation & Integration Plan | 35d? | 2009-11-02 | 2009-12-18 | 66d | finish no earlier than 2009-12-18 | Chin [21.4%]; Nance [7.1%]; Medeiros [7.1%]; Wetherell [7.1%]; Neyman [7.1%]; Adkins [2.9%] | 148h | 10,632 |
| 693 | 1.3.8.5.2 | Laser System Test Plan | 35d? | 2009-11-02 | 2009-12-18 | 66d | start no earlier than 2009-11-02 | Neyman [14.3%]; Wetherell [1.4%]; Johansson [2.9%]; Chin [2.9%]; Adkins [1.4%] | 64h | 4,616 |
| 694 | 1.3.8.6 | LGS AO System On-sky I&T Plan | 10d? | 2009-11-02 | 2009-11-13 | 91d | finish no earlier than 2009-11-13 | Le Mignant [25%]; Wizinowich [25%] | 40h | 3,480 |
| 695 | 1.3.8.7 | Performance Characterization | 1d? | 2009-11-02 | 2009-11-02 | 100d | start no earlier than 2009-11-02 |  |  |  |
| 696 | 1.3.8.8 | Science Verification Plan | 20d? | 2009-11-02 | 2009-11-27 | 81d | finish no earlier than 2009-11-27 | Le Mignant [37.5%]; Wizinowich [12.5%] | 80h | 6,280 |
| 697 | 1.3.9 | **Operations Transition** | 232d? | 2009-01-09 | 2009-11-30 | 80d |  |  | 166h | 12,208.26 |
| 698 | 1.3.9.1 | **Operations Plans** | 65d? | 2009-09-01 | 2009-11-30 | 80d |  |  | 96h | 6,968.26 |
| 699 | 1.3.9.1.1 | Operations Support Plan | 65d? | 2009-09-01 | 2009-11-30 | 80d | finish no earlier than 2009-11-30 | Le Mignant [7.7%] | 40h | 2,800 |
| 700 | 1.3.9.1.2 | Operations Maintenance & Spares Plan Template | 65d? | 2009-09-01 | 2009-11-30 | 80d | start no earlier than 2009-09-01 | Wetherell [5.4%]; Bell [3.1%]; Lockwood [1.2%]; Velur [1.2%] | 56h | 4,168.26 |

Notes:
- 676: PW
- 677: PW
- 678: PW
- 679: CN
- 680: JB
- 681: JB
- 682: DM
- 685: CN
- 686: CN
- 687: EW
- 688: JC
- 689: CN
- 690: CN
- 691: JC
- 692: JC
- 693: CN
- 694: DLM
- 696: DLM
- 697: DLM
- 698: DLM
- 699: DLM
- 700: EW

| ID | WBS | Task | Duration | Start | Finish | Total slack | Constraint | Resources | Work | Cost |
| --- | --- | --- | --- | --- | --- | --- | --- | --- | --- | --- |
| 701 | 1.3.9.2 | **Operations Handover** | 232d? | 2009-01-09 | 2009-11-30 | 80d |  |  | 70h | 5,240 |
| 702 | 1.3.9.2.1 | Operations Personnel Training Plan | 65d? | 2009-09-01 | 2009-11-30 | 80d | finish no earlier than 2009-11-30 | Le Mignant [7.7%]; Wizinowich [1.9%] | 50h | 3,840 |
| 703 | 1.3.9.2.2 | Documentation Transition Plan | 232d? | 2009-01-09 | 2009-11-30 | 80d | finish no earlier than 2009-11-30 | Le Mignant [1.1%] | 20h | 1,400 |

Notes:
- 701: DLM
- 702: DLM
- 703: DLM
